# < Project Name >

Schedule from MS Project, 2005-01-03 to 2005-08-23.

## Calendars

- Standard: Mon-Fri 08:00-12:00, 13:00-17:00; Sat-Sun off.

## Schedule

| ID | WBS | Task | Type | Duration | Start | Finish | Predecessors | Baseline start | Baseline finish | Baseline duration | Total slack | Free slack | Text4 |
| --- | --- | --- | --- | --- | --- | --- | --- | --- | --- | --- | --- | --- | --- |
| 1 | 1 | **DEFINE** |  | 23.5d | 2005-01-03 | 2005-02-03 |  | 2005-01-03 | 2005-02-03 | 23.5d | 0d |  | {052ABCD0-FD27-4490-B44D-790D5A6B7FFF} |
| 2 | 1.1 | **Establish project** |  | 2.5d | 2005-01-03 | 2005-01-05 |  | 2005-01-03 | 2005-01-05 | 2.5d | 0d |  | {DBF5387B-EF76-42D4-BE07-0AA4F67A2CD8} |
| 3 | 1.1.1 | Define project organization |  | 0.5d | 2005-01-03 | 2005-01-03 |  | 2005-01-03 | 2005-01-03 | 0.5d | 0d |  | {E317BD52-C0D3-46DD-9026-355EC8C133E1} |
| 4 | 1.1.2 | Create initial Thought Map |  | 0.5d | 2005-01-03 | 2005-01-03 | 3 | 2005-01-03 | 2005-01-03 | 0.5d | 0d |  | {8B05C810-A5F3-4AE5-8B82-366A9CDEE435} |
| 5 | 1.1.3 | Create Project Charter v0.1 |  | 0.25d | 2005-01-04 | 2005-01-04 | 4 | 2005-01-04 | 2005-01-04 | 0.25d | 0d |  | {A83BC83E-1CDF-485D-99D5-DE2E85356B3D} |
| 6 | 1.1.4 | Define general Project Plan v0.1 |  | 0.25d | 2005-01-04 | 2005-01-04 | 5 | 2005-01-04 | 2005-01-04 | 0.25d | 0d |  | {F01B4A14-BAA0-4ACF-B7FA-D1D616D25D00} |
| 7 | 1.1.5 | Circulate charter & plan for feedback |  | 1d | 2005-01-04 | 2005-01-05 | 6 | 2005-01-04 | 2005-01-05 | 1d | 0d |  | {FC2415D7-A225-4020-AB9A-C1294E3D0E79} |
| 8 | 1.2 | **Define business scope** |  | 4.25d | 2005-01-05 | 2005-01-11 | 7 | 2005-01-05 | 2005-01-11 | 4.25d | 0d |  | {66784109-9B87-4127-957E-B7484936B9C8} |
| 9 | 1.2.1 | Review background work products |  | 1d | 2005-01-05 | 2005-01-06 |  | 2005-01-05 | 2005-01-06 | 1d | 0d |  | {797499B3-91EE-4C11-9FC3-FA0D6524FE67} |
| 10 | 1.2.2 | Identify customer and supplier stakeholders |  | 0.25d | 2005-01-06 | 2005-01-06 | 9 | 2005-01-06 | 2005-01-06 | 0.25d | 0d |  | {D714BA91-7993-4BCC-B996-BD975A77D724} |
| 11 | 1.2.3 | Draft preliminary problem statement |  | 0.25d | 2005-01-06 | 2005-01-06 | 10 | 2005-01-06 | 2005-01-06 | 0.25d | 0d |  | {76C81E15-B8AD-4173-AEF3-F77FD05044CE} |
| 12 | 1.2.4 | Define essential inputs/outputs |  | 0.5d | 2005-01-07 | 2005-01-07 | 11 | 2005-01-07 | 2005-01-07 | 0.5d | 1.75d | 0d | {927160F9-830B-4C38-BC78-D3BDC5CF9922} |
| 13 | 1.2.5 | Identify driving requirements |  | 0.25d | 2005-01-07 | 2005-01-07 | 12 | 2005-01-07 | 2005-01-07 | 0.25d | 1.75d | 0d | {D6608FED-0F1A-428C-883F-E59B72D878EE} |
| 14 | 1.2.6 | Draft SIPOC v0.1 |  | 0.5d | 2005-01-07 | 2005-01-10 | 13 | 2005-01-07 | 2005-01-10 | 0.5d | 1.75d | 0d | {6B7F47A8-352E-4C8F-B9E9-0131AA96C6F1} |
| 15 | 1.2.7 | Circulate SIPOC drafts for feedback |  | 1d | 2005-01-10 | 2005-01-11 | 14 | 2005-01-10 | 2005-01-11 | 1d | 1.75d | 0d | {99DBF8AC-17D8-4D36-A695-846B7114818A} |
| 16 | 1.2.8 | Update SIPOC v0.2 |  | 0.5d | 2005-01-11 | 2005-01-11 | 15 | 2005-01-11 | 2005-01-11 | 0.5d | 1.75d |  | {809143EB-E211-4200-B86F-4770E8C3D597} |
| 17 | 1.3 | **Estimate unit quality levels** |  | 1.5d | 2005-01-07 | 2005-01-10 | 11 | 2005-01-07 | 2005-01-10 | 1.5d | 0d |  | {95F38B0A-F477-41E7-81FA-804736EC4584} |
| 18 | 1.3.1 | Identify processing units |  | 0.25d | 2005-01-07 | 2005-01-07 |  | 2005-01-07 | 2005-01-07 | 0.25d | 0d |  | {7D705E6B-2BFB-44AC-9B02-49A8F7DD534B} |
| 19 | 1.3.2 | Review unit defect scenarios |  | 0.5d | 2005-01-07 | 2005-01-07 | 18 | 2005-01-07 | 2005-01-07 | 0.5d | 0d |  | {EF5BDD21-D22D-4E96-B72D-28A2967329CC} |
| 20 | 1.3.3 | Estimate "as is" Sigma Score |  | 0.25d | 2005-01-07 | 2005-01-07 | 19 | 2005-01-07 | 2005-01-07 | 0.25d | 0d |  | {110CFEE3-8D71-4B51-8C70-6676E3AA9B7B} |
| 21 | 1.3.4 | Define target Sigma Score expectation |  | 0.5d | 2005-01-10 | 2005-01-10 | 20 | 2005-01-10 | 2005-01-10 | 0.5d | 0d |  | {93D094E2-E94F-4DF9-B0AC-64168A59DDEB} |
| 22 | 1.4 | **Define project approach** |  | 3d | 2005-01-10 | 2005-01-13 | 17 | 2005-01-10 | 2005-01-13 | 3d | 0d |  | {D784DC2A-985C-442C-9A11-9E5B3AC6FBCA} |
| 23 | 1.4.1 | Define initial effort and cost estimate |  | 1d | 2005-01-10 | 2005-01-11 |  | 2005-01-10 | 2005-01-11 | 1d | 0d |  | {B9EE9A9D-C747-48F7-9653-9D2BC448B50A} |
| 24 | 1.4.2 | Review estimates with stakeholders |  | 1d | 2005-01-11 | 2005-01-12 | 23 | 2005-01-11 | 2005-01-12 | 1d | 0d |  | {35593EC5-4F28-4492-BEE0-3D31736CF9B4} |
| 25 | 1.4.3 | Narrow approach alternatives |  | 1d | 2005-01-12 | 2005-01-13 | 24 | 2005-01-12 | 2005-01-13 | 1d | 0d |  | {844BECD0-0C58-4FB1-9CFA-CCE06F58C229} |
| 26 | 1.4.4 | Make Go/NoGo decision | milestone | 0d | 2005-01-13 | 2005-01-13 | 25 | 2005-01-13 | 2005-01-13 | 0d | 0d |  | {73ECF6B5-D99A-439A-B723-4D2ED942823B} |

Notes:
- 1: Text3: <sync-guid>{052ABCD0-FD27-4490-B44D-790D5A6B7FFF}</sync-guid><sync-parentguid>{69CAB05D-8790-4A69-A093-1D8EDB5A2679}</sync-parentguid><sync-checksum>-630500944</sync-checksum><sync-rootid>0</sync-rootid><sync-itemtype>0</sync-itemtype><sync-timestamp>12/2 / Text5: 1/2004 9:44:26 AM</sync-timestamp><sync-itemid>2</sync-itemid><sync-prioritymapping>0:0-0/1:700-1000/2:300-699/3:1-299</sync-prioritymapping>
- 2: Text3: <sync-guid>{DBF5387B-EF76-42D4-BE07-0AA4F67A2CD8}</sync-guid><sync-parentguid>{052ABCD0-FD27-4490-B44D-790D5A6B7FFF}</sync-parentguid><sync-checksum>-1790217176</sync-checksum><sync-rootid>0</sync-rootid><sync-itemtype>0</sync-itemtype><sync-timestamp>12 / Text5: 21/2004 9:44:26 AM</sync-timestamp><sync-itemid>21</sync-itemid><sync-prioritymapping>0:0-0/1:700-1000/2:300-699/3:1-299</sync-prioritymapping>
- 3: Text3: <sync-guid>{E317BD52-C0D3-46DD-9026-355EC8C133E1}</sync-guid><sync-parentguid>{DBF5387B-EF76-42D4-BE07-0AA4F67A2CD8}</sync-parentguid><sync-checksum>1254375907</sync-checksum><sync-rootid>0</sync-rootid><sync-itemtype>0</sync-itemtype><sync-timestamp>12/2 / Text5: 1/2004 9:44:26 AM</sync-timestamp><sync-itemid>20</sync-itemid><sync-prioritymapping>0:0-0/1:700-1000/2:300-699/3:1-299</sync-prioritymapping>
- 4: Text3: <sync-guid>{8B05C810-A5F3-4AE5-8B82-366A9CDEE435}</sync-guid><sync-parentguid>{DBF5387B-EF76-42D4-BE07-0AA4F67A2CD8}</sync-parentguid><sync-checksum>-897588586</sync-checksum><sync-rootid>0</sync-rootid><sync-itemtype>0</sync-itemtype><sync-timestamp>12/2 / Text5: 1/2004 9:44:26 AM</sync-timestamp><sync-itemid>463</sync-itemid><sync-prioritymapping>0:0-0/1:700-1000/2:300-699/3:1-299</sync-prioritymapping>
- 5: Text3: <sync-guid>{A83BC83E-1CDF-485D-99D5-DE2E85356B3D}</sync-guid><sync-parentguid>{DBF5387B-EF76-42D4-BE07-0AA4F67A2CD8}</sync-parentguid><sync-checksum>1707864219</sync-checksum><sync-rootid>0</sync-rootid><sync-itemtype>0</sync-itemtype><sync-timestamp>12/2 / Text5: 1/2004 9:44:26 AM</sync-timestamp><sync-itemid>19</sync-itemid><sync-prioritymapping>0:0-0/1:700-1000/2:300-699/3:1-299</sync-prioritymapping>
- 6: Text3: <sync-guid>{F01B4A14-BAA0-4ACF-B7FA-D1D616D25D00}</sync-guid><sync-parentguid>{DBF5387B-EF76-42D4-BE07-0AA4F67A2CD8}</sync-parentguid><sync-checksum>-1241409073</sync-checksum><sync-rootid>0</sync-rootid><sync-itemtype>0</sync-itemtype><sync-timestamp>12 / Text5: 21/2004 9:44:26 AM</sync-timestamp><sync-itemid>18</sync-itemid><sync-prioritymapping>0:0-0/1:700-1000/2:300-699/3:1-299</sync-prioritymapping>
- 7: Text3: <sync-guid>{FC2415D7-A225-4020-AB9A-C1294E3D0E79}</sync-guid><sync-parentguid>{DBF5387B-EF76-42D4-BE07-0AA4F67A2CD8}</sync-parentguid><sync-checksum>-149686399</sync-checksum><sync-rootid>0</sync-rootid><sync-itemtype>0</sync-itemtype><sync-timestamp>12/2 / Text5: 1/2004 9:44:26 AM</sync-timestamp><sync-itemid>17</sync-itemid><sync-prioritymapping>0:0-0/1:700-1000/2:300-699/3:1-299</sync-prioritymapping>
- 8: Text3: <sync-guid>{66784109-9B87-4127-957E-B7484936B9C8}</sync-guid><sync-parentguid>{052ABCD0-FD27-4490-B44D-790D5A6B7FFF}</sync-parentguid><sync-checksum>-799411873</sync-checksum><sync-rootid>0</sync-rootid><sync-itemtype>0</sync-itemtype><sync-timestamp>12/2 / Text5: 1/2004 9:44:27 AM</sync-timestamp><sync-itemid>456</sync-itemid><sync-prioritymapping>0:0-0/1:700-1000/2:300-699/3:1-299</sync-prioritymapping>
- 9: Text3: <sync-guid>{797499B3-91EE-4C11-9FC3-FA0D6524FE67}</sync-guid><sync-parentguid>{66784109-9B87-4127-957E-B7484936B9C8}</sync-parentguid><sync-checksum>33974796</sync-checksum><sync-rootid>0</sync-rootid><sync-itemtype>0</sync-itemtype><sync-timestamp>12/21 / Text5: 2004 9:44:27 AM</sync-timestamp><sync-itemid>455</sync-itemid><sync-prioritymapping>0:0-0/1:700-1000/2:300-699/3:1-299</sync-prioritymapping>
- 10: Text3: <sync-guid>{D714BA91-7993-4BCC-B996-BD975A77D724}</sync-guid><sync-parentguid>{66784109-9B87-4127-957E-B7484936B9C8}</sync-parentguid><sync-checksum>1603277660</sync-checksum><sync-rootid>0</sync-rootid><sync-itemtype>0</sync-itemtype><sync-timestamp>12/2 / Text5: 1/2004 9:44:27 AM</sync-timestamp><sync-itemid>459</sync-itemid><sync-prioritymapping>0:0-0/1:700-1000/2:300-699/3:1-299</sync-prioritymapping>
- 11: Text3: <sync-guid>{76C81E15-B8AD-4173-AEF3-F77FD05044CE}</sync-guid><sync-parentguid>{66784109-9B87-4127-957E-B7484936B9C8}</sync-parentguid><sync-checksum>-1354452924</sync-checksum><sync-rootid>0</sync-rootid><sync-itemtype>0</sync-itemtype><sync-timestamp>12 / Text5: 21/2004 9:44:27 AM</sync-timestamp><sync-itemid>458</sync-itemid><sync-prioritymapping>0:0-0/1:700-1000/2:300-699/3:1-299</sync-prioritymapping>
- 12: Text3: <sync-guid>{927160F9-830B-4C38-BC78-D3BDC5CF9922}</sync-guid><sync-parentguid>{66784109-9B87-4127-957E-B7484936B9C8}</sync-parentguid><sync-checksum>835213668</sync-checksum><sync-rootid>0</sync-rootid><sync-itemtype>0</sync-itemtype><sync-timestamp>12/21 / Text5: 2004 9:44:27 AM</sync-timestamp><sync-itemid>457</sync-itemid><sync-prioritymapping>0:0-0/1:700-1000/2:300-699/3:1-299</sync-prioritymapping>
- 13: Text3: <sync-guid>{D6608FED-0F1A-428C-883F-E59B72D878EE}</sync-guid><sync-parentguid>{66784109-9B87-4127-957E-B7484936B9C8}</sync-parentguid><sync-checksum>-964403882</sync-checksum><sync-rootid>0</sync-rootid><sync-itemtype>0</sync-itemtype><sync-timestamp>12/2 / Text5: 1/2004 9:44:27 AM</sync-timestamp><sync-itemid>460</sync-itemid><sync-prioritymapping>0:0-0/1:700-1000/2:300-699/3:1-299</sync-prioritymapping>
- 14: Text3: <sync-guid>{6B7F47A8-352E-4C8F-B9E9-0131AA96C6F1}</sync-guid><sync-parentguid>{66784109-9B87-4127-957E-B7484936B9C8}</sync-parentguid><sync-checksum>-1973478264</sync-checksum><sync-rootid>0</sync-rootid><sync-itemtype>0</sync-itemtype><sync-timestamp>12 / Text5: 21/2004 9:44:27 AM</sync-timestamp><sync-itemid>454</sync-itemid><sync-prioritymapping>0:0-0/1:700-1000/2:300-699/3:1-299</sync-prioritymapping>
- 15: Text3: <sync-guid>{99DBF8AC-17D8-4D36-A695-846B7114818A}</sync-guid><sync-parentguid>{66784109-9B87-4127-957E-B7484936B9C8}</sync-parentguid><sync-checksum>-1401541238</sync-checksum><sync-rootid>0</sync-rootid><sync-itemtype>0</sync-itemtype><sync-timestamp>12 / Text5: 21/2004 9:44:27 AM</sync-timestamp><sync-itemid>453</sync-itemid><sync-prioritymapping>0:0-0/1:700-1000/2:300-699/3:1-299</sync-prioritymapping>
- 16: Text3: <sync-guid>{809143EB-E211-4200-B86F-4770E8C3D597}</sync-guid><sync-parentguid>{66784109-9B87-4127-957E-B7484936B9C8}</sync-parentguid><sync-checksum>882654686</sync-checksum><sync-rootid>0</sync-rootid><sync-itemtype>0</sync-itemtype><sync-timestamp>12/21 / Text5: 2004 9:44:27 AM</sync-timestamp><sync-itemid>452</sync-itemid><sync-prioritymapping>0:0-0/1:700-1000/2:300-699/3:1-299</sync-prioritymapping>
- 17: Text3: <sync-guid>{95F38B0A-F477-41E7-81FA-804736EC4584}</sync-guid><sync-parentguid>{052ABCD0-FD27-4490-B44D-790D5A6B7FFF}</sync-parentguid><sync-checksum>2038350869</sync-checksum><sync-rootid>0</sync-rootid><sync-itemtype>0</sync-itemtype><sync-timestamp>12/2 / Text5: 1/2004 9:44:27 AM</sync-timestamp><sync-itemid>467</sync-itemid><sync-prioritymapping>0:0-0/1:700-1000/2:300-699/3:1-299</sync-prioritymapping>
- 18: Text3: <sync-guid>{7D705E6B-2BFB-44AC-9B02-49A8F7DD534B}</sync-guid><sync-parentguid>{95F38B0A-F477-41E7-81FA-804736EC4584}</sync-parentguid><sync-checksum>-1020297919</sync-checksum><sync-rootid>0</sync-rootid><sync-itemtype>0</sync-itemtype><sync-timestamp>12 / Text5: 21/2004 9:44:27 AM</sync-timestamp><sync-itemid>466</sync-itemid><sync-prioritymapping>0:0-0/1:700-1000/2:300-699/3:1-299</sync-prioritymapping>
- 19: Text3: <sync-guid>{EF5BDD21-D22D-4E96-B72D-28A2967329CC}</sync-guid><sync-parentguid>{95F38B0A-F477-41E7-81FA-804736EC4584}</sync-parentguid><sync-checksum>1912405490</sync-checksum><sync-rootid>0</sync-rootid><sync-itemtype>0</sync-itemtype><sync-timestamp>12/2 / Text5: 1/2004 9:44:27 AM</sync-timestamp><sync-itemid>465</sync-itemid><sync-prioritymapping>0:0-0/1:700-1000/2:300-699/3:1-299</sync-prioritymapping>
- 20: Text3: <sync-guid>{110CFEE3-8D71-4B51-8C70-6676E3AA9B7B}</sync-guid><sync-parentguid>{95F38B0A-F477-41E7-81FA-804736EC4584}</sync-parentguid><sync-checksum>1863900044</sync-checksum><sync-rootid>0</sync-rootid><sync-itemtype>0</sync-itemtype><sync-timestamp>12/2 / Text5: 1/2004 9:44:27 AM</sync-timestamp><sync-itemid>464</sync-itemid><sync-prioritymapping>0:0-0/1:700-1000/2:300-699/3:1-299</sync-prioritymapping>
- 21: Text3: <sync-guid>{93D094E2-E94F-4DF9-B0AC-64168A59DDEB}</sync-guid><sync-parentguid>{95F38B0A-F477-41E7-81FA-804736EC4584}</sync-parentguid><sync-checksum>-348472596</sync-checksum><sync-rootid>0</sync-rootid><sync-itemtype>0</sync-itemtype><sync-timestamp>12/2 / Text5: 1/2004 9:44:27 AM</sync-timestamp><sync-itemid>468</sync-itemid><sync-prioritymapping>0:0-0/1:700-1000/2:300-699/3:1-299</sync-prioritymapping>
- 22: Text3: <sync-guid>{D784DC2A-985C-442C-9A11-9E5B3AC6FBCA}</sync-guid><sync-parentguid>{052ABCD0-FD27-4490-B44D-790D5A6B7FFF}</sync-parentguid><sync-checksum>38900712</sync-checksum><sync-rootid>0</sync-rootid><sync-itemtype>0</sync-itemtype><sync-timestamp>12/30 / Text5: 2004 1:12:02 PM</sync-timestamp><sync-itemid>337</sync-itemid><sync-prioritymapping>0:0-0/1:700-1000/2:300-699/3:1-299</sync-prioritymapping>
- 23: Text3: <sync-guid>{B9EE9A9D-C747-48F7-9653-9D2BC448B50A}</sync-guid><sync-parentguid>{D784DC2A-985C-442C-9A11-9E5B3AC6FBCA}</sync-parentguid><sync-checksum>-2104965376</sync-checksum><sync-rootid>0</sync-rootid><sync-itemtype>0</sync-itemtype><sync-timestamp>12 / Text5: 21/2004 9:44:28 AM</sync-timestamp><sync-itemid>334</sync-itemid><sync-prioritymapping>0:0-0/1:700-1000/2:300-699/3:1-299</sync-prioritymapping>
- 24: Text3: <sync-guid>{35593EC5-4F28-4492-BEE0-3D31736CF9B4}</sync-guid><sync-parentguid>{D784DC2A-985C-442C-9A11-9E5B3AC6FBCA}</sync-parentguid><sync-checksum>-134218625</sync-checksum><sync-rootid>0</sync-rootid><sync-itemtype>0</sync-itemtype><sync-timestamp>12/2 / Text5: 1/2004 9:44:28 AM</sync-timestamp><sync-itemid>335</sync-itemid><sync-prioritymapping>0:0-0/1:700-1000/2:300-699/3:1-299</sync-prioritymapping>
- 25: Text3: <sync-guid>{844BECD0-0C58-4FB1-9CFA-CCE06F58C229}</sync-guid><sync-parentguid>{D784DC2A-985C-442C-9A11-9E5B3AC6FBCA}</sync-parentguid><sync-checksum>760263632</sync-checksum><sync-rootid>0</sync-rootid><sync-itemtype>0</sync-itemtype><sync-timestamp>12/21 / Text5: 2004 9:44:28 AM</sync-timestamp><sync-itemid>336</sync-itemid><sync-prioritymapping>0:0-0/1:700-1000/2:300-699/3:1-299</sync-prioritymapping>
- 26: Text3: <sync-guid>{73ECF6B5-D99A-439A-B723-4D2ED942823B}</sync-guid><sync-parentguid>{D784DC2A-985C-442C-9A11-9E5B3AC6FBCA}</sync-parentguid><sync-checksum>1562936720</sync-checksum><sync-rootid>0</sync-rootid><sync-itemtype>0</sync-itemtype><sync-timestamp>12/3 / Text5: 0/2004 1:12:02 PM</sync-timestamp><sync-itemid>333</sync-itemid><sync-prioritymapping>0:0-0/1:700-1000/2:300-699/3:1-299</sync-prioritymapping>

| ID | WBS | Task | Type | Duration | Start | Finish | Predecessors | Baseline start | Baseline finish | Baseline duration | Total slack | Free slack | Text4 |
| --- | --- | --- | --- | --- | --- | --- | --- | --- | --- | --- | --- | --- | --- |
| 27 | 1.5 | **Define Project Charter** |  | 7d | 2005-01-13 | 2005-01-24 | 8, 22 | 2005-01-13 | 2005-01-24 | 7d | 0d |  | {95C1E3C6-1AE4-4509-9531-35D9F8A9BCED} |
| 28 | 1.5.1 | Solidify project goals & objectives |  | 1d | 2005-01-13 | 2005-01-14 |  | 2005-01-13 | 2005-01-14 | 1d | 0d |  | {961251E7-97D7-4741-803C-C4734D4E1BDB} |
| 29 | 1.5.2 | Define project deliverables |  | 1d | 2005-01-14 | 2005-01-17 | 28 | 2005-01-14 | 2005-01-17 | 1d | 0d |  | {00C2F6D4-3110-403C-A659-3BFDBF94E74A} |
| 30 | 1.5.3 | Finalize project approach |  | 1d | 2005-01-17 | 2005-01-18 | 29 | 2005-01-17 | 2005-01-18 | 1d | 0d |  | {27C34C0A-26FE-46ED-88C7-A5DAEF59A0D7} |
| 31 | 1.5.4 | Draft Project Charter v0.2 |  | 1d | 2005-01-18 | 2005-01-19 | 30 | 2005-01-18 | 2005-01-19 | 1d | 0d |  | {12B531B0-BDAA-4838-85C4-7E0BBE68AABF} |
| 32 | 1.5.5 | Review charter with stakeholders |  | 1d | 2005-01-19 | 2005-01-20 | 31 | 2005-01-19 | 2005-01-20 | 1d | 2d | 0d | {96EAC459-3267-4EE9-A1C1-BFBCB991A8C5} |
| 33 | 1.5.6 | Revise charter issues and key factors |  | 1d | 2005-01-20 | 2005-01-21 | 32 | 2005-01-20 | 2005-01-21 | 1d | 2d | 0d | {B18F62FE-0FC4-49AD-A062-F80109F0D560} |
| 34 | 1.5.7 | Revise charter and general plan v0.3 |  | 1d | 2005-01-21 | 2005-01-24 | 33 | 2005-01-21 | 2005-01-24 | 1d | 2d | 0d | {84DA25AE-A4CE-410E-AE9A-7CA6F0CB20F2} |
| 35 | 1.5.8 | Approve project charter & general plan | milestone | 0d | 2005-01-24 | 2005-01-24 | 34 | 2005-01-24 | 2005-01-24 | 0d | 2d |  | {D2076031-AF57-4A8A-B7DC-BA2F0CCC2451} |
| 36 | 1.6 | **Create initial plan** |  | 9d | 2005-01-19 | 2005-02-01 | 31 | 2005-01-19 | 2005-02-01 | 9d | 0d |  | {A91E6A09-5564-42DF-BC94-943042708C6D} |
| 37 | 1.6.1 | Identify external milestones |  | 1d | 2005-01-19 | 2005-01-20 |  | 2005-01-19 | 2005-01-20 | 1d | 0d |  | {314B74CF-4CE7-4B2D-86C7-0B83DA99896A} |
| 38 | 1.6.2 | Develop phase level estimates |  | 1d | 2005-01-20 | 2005-01-21 | 37 | 2005-01-20 | 2005-01-21 | 1d | 0d |  | {3861BF0B-8995-4280-A965-22D5DF576ACC} |
| 39 | 1.6.3 | Reconcile external milestones |  | 1d | 2005-01-21 | 2005-01-24 | 38 | 2005-01-21 | 2005-01-24 | 1d | 0d |  | {487D1546-CC36-406D-9A55-822C8BB995BF} |
| 40 | 1.6.4 | Create timebox project schedule |  | 1d | 2005-01-24 | 2005-01-25 | 39 | 2005-01-24 | 2005-01-25 | 1d | 0d |  | {4D2A47C0-CA50-4228-BD68-6A927DA72498} |
| 41 | 1.6.5 | Build Project Plan v0.2 |  | 1d | 2005-01-25 | 2005-01-26 | 40 | 2005-01-25 | 2005-01-26 | 1d | 0d |  | {E81F6F39-7CB2-439F-94B1-4DBD5CCF634A} |
| 42 | 1.6.6 | Update Project Charter v0.2 |  | 1d | 2005-01-26 | 2005-01-27 | 27, 41 | 2005-01-26 | 2005-01-27 | 1d | 0d |  | {A47DD7F5-5F03-4495-A229-6260A08A4297} |
| 43 | 1.6.7 | Recirculate charter & plan |  | 1d | 2005-01-27 | 2005-01-28 | 42 | 2005-01-27 | 2005-01-28 | 1d | 0d |  | {700ACF25-2FCC-4F69-B763-419D4AED0598} |
| 44 | 1.6.8 | Conduct Charter-Plan peer review |  | 1d | 2005-01-28 | 2005-01-31 | 43 | 2005-01-28 | 2005-01-31 | 1d | 0d |  | {F1B25DDD-DA91-4876-BD05-38758A839B1F} |
| 45 | 1.6.9 | Finalize Charter v0.3 & Plan v0.3 |  | 1d | 2005-01-31 | 2005-02-01 | 44 | 2005-01-31 | 2005-02-01 | 1d | 0d |  | {9A9724A9-9455-40A1-93B5-1FDCB199CB12} |
| 46 | 1.6.10 | Approve final charter & plan | milestone | 0d | 2005-02-01 | 2005-02-01 | 45 | 2005-02-01 | 2005-02-01 | 0d | 0d |  | {D24E5221-86D6-41DF-9C47-73E0F8DC32C0} |
| 47 | 1.7 | **Conduct phase QA assessment** |  | 2d | 2005-02-01 | 2005-02-03 | 36 | 2005-02-01 | 2005-02-03 | 2d | 80.5d |  | {1EA21F57-364A-4A96-AB24-46E7B0D52A6A} |
| 48 | 1.7.1 | Consolidate phase results |  | 0.5d | 2005-02-01 | 2005-02-01 |  | 2005-02-01 | 2005-02-01 | 0.5d | 80.5d | 0d | {408EBB86-EBE3-44FD-8CDA-E4DAEFDB50B4} |
| 49 | 1.7.2 | Conduct phase self-assessment |  | 0.25d | 2005-02-02 | 2005-02-02 | 48 | 2005-02-02 | 2005-02-02 | 0.25d | 80.5d | 0d | {9C310BE6-A6F5-4ECF-9651-AE1CD1F4D4A0} |
| 50 | 1.7.3 | Conduct QA assessment |  | 0.5d | 2005-02-02 | 2005-02-02 | 49 | 2005-02-02 | 2005-02-02 | 0.5d | 80.5d | 0d | {88EA8770-12DE-448A-B20A-D2C3D2A02DAA} |
| 51 | 1.7.4 | Review assessment feedback |  | 0.25d | 2005-02-02 | 2005-02-02 | 50 | 2005-02-02 | 2005-02-02 | 0.25d | 80.5d | 0d | {6DE05BE5-78A0-4275-8CFF-2AE874F15406} |
| 52 | 1.7.5 | Implement QA feedback |  | 0.5d | 2005-02-03 | 2005-02-03 | 51 | 2005-02-03 | 2005-02-03 | 0.5d | 80.5d |  | {2F6488CB-30CF-421A-80D2-2073A629A49F} |

Notes:
- 27: Text3: <sync-guid>{95C1E3C6-1AE4-4509-9531-35D9F8A9BCED}</sync-guid><sync-parentguid>{052ABCD0-FD27-4490-B44D-790D5A6B7FFF}</sync-parentguid><sync-checksum>911653957</sync-checksum><sync-rootid>0</sync-rootid><sync-itemtype>0</sync-itemtype><sync-timestamp>12/30 / Text5: 2004 1:12:03 PM</sync-timestamp><sync-itemid>347</sync-itemid><sync-prioritymapping>0:0-0/1:700-1000/2:300-699/3:1-299</sync-prioritymapping>
- 28: Text3: <sync-guid>{961251E7-97D7-4741-803C-C4734D4E1BDB}</sync-guid><sync-parentguid>{95C1E3C6-1AE4-4509-9531-35D9F8A9BCED}</sync-parentguid><sync-checksum>1038117933</sync-checksum><sync-rootid>0</sync-rootid><sync-itemtype>0</sync-itemtype><sync-timestamp>12/3 / Text5: 0/2004 1:12:02 PM</sync-timestamp><sync-itemid>346</sync-itemid><sync-prioritymapping>0:0-0/1:700-1000/2:300-699/3:1-299</sync-prioritymapping>
- 29: Text3: <sync-guid>{00C2F6D4-3110-403C-A659-3BFDBF94E74A}</sync-guid><sync-parentguid>{95C1E3C6-1AE4-4509-9531-35D9F8A9BCED}</sync-parentguid><sync-checksum>1829820425</sync-checksum><sync-rootid>0</sync-rootid><sync-itemtype>0</sync-itemtype><sync-timestamp>12/3 / Text5: 0/2004 1:12:02 PM</sync-timestamp><sync-itemid>345</sync-itemid><sync-prioritymapping>0:0-0/1:700-1000/2:300-699/3:1-299</sync-prioritymapping>
- 30: Text3: <sync-guid>{27C34C0A-26FE-46ED-88C7-A5DAEF59A0D7}</sync-guid><sync-parentguid>{95C1E3C6-1AE4-4509-9531-35D9F8A9BCED}</sync-parentguid><sync-checksum>2027777094</sync-checksum><sync-rootid>0</sync-rootid><sync-itemtype>0</sync-itemtype><sync-timestamp>12/3 / Text5: 0/2004 1:12:02 PM</sync-timestamp><sync-itemid>344</sync-itemid><sync-prioritymapping>0:0-0/1:700-1000/2:300-699/3:1-299</sync-prioritymapping>
- 31: Text3: <sync-guid>{12B531B0-BDAA-4838-85C4-7E0BBE68AABF}</sync-guid><sync-parentguid>{95C1E3C6-1AE4-4509-9531-35D9F8A9BCED}</sync-parentguid><sync-checksum>1160357978</sync-checksum><sync-rootid>0</sync-rootid><sync-itemtype>0</sync-itemtype><sync-timestamp>12/3 / Text5: 0/2004 1:12:02 PM</sync-timestamp><sync-itemid>343</sync-itemid><sync-prioritymapping>0:0-0/1:700-1000/2:300-699/3:1-299</sync-prioritymapping>
- 32: Text3: <sync-guid>{96EAC459-3267-4EE9-A1C1-BFBCB991A8C5}</sync-guid><sync-parentguid>{95C1E3C6-1AE4-4509-9531-35D9F8A9BCED}</sync-parentguid><sync-checksum>-1195950398</sync-checksum><sync-rootid>0</sync-rootid><sync-itemtype>0</sync-itemtype><sync-timestamp>12 / Text5: 30/2004 1:12:02 PM</sync-timestamp><sync-itemid>342</sync-itemid><sync-prioritymapping>0:0-0/1:700-1000/2:300-699/3:1-299</sync-prioritymapping>
- 33: Text3: <sync-guid>{B18F62FE-0FC4-49AD-A062-F80109F0D560}</sync-guid><sync-parentguid>{95C1E3C6-1AE4-4509-9531-35D9F8A9BCED}</sync-parentguid><sync-checksum>1672492120</sync-checksum><sync-rootid>0</sync-rootid><sync-itemtype>0</sync-itemtype><sync-timestamp>12/3 / Text5: 0/2004 1:12:02 PM</sync-timestamp><sync-itemid>341</sync-itemid><sync-prioritymapping>0:0-0/1:700-1000/2:300-699/3:1-299</sync-prioritymapping>
- 34: Text3: <sync-guid>{84DA25AE-A4CE-410E-AE9A-7CA6F0CB20F2}</sync-guid><sync-parentguid>{95C1E3C6-1AE4-4509-9531-35D9F8A9BCED}</sync-parentguid><sync-checksum>-1411237698</sync-checksum><sync-rootid>0</sync-rootid><sync-itemtype>0</sync-itemtype><sync-timestamp>12 / Text5: 30/2004 1:12:03 PM</sync-timestamp><sync-itemid>16</sync-itemid><sync-prioritymapping>0:0-0/1:700-1000/2:300-699/3:1-299</sync-prioritymapping>
- 35: Text3: <sync-guid>{D2076031-AF57-4A8A-B7DC-BA2F0CCC2451}</sync-guid><sync-parentguid>{95C1E3C6-1AE4-4509-9531-35D9F8A9BCED}</sync-parentguid><sync-checksum>1833006047</sync-checksum><sync-rootid>0</sync-rootid><sync-itemtype>0</sync-itemtype><sync-timestamp>12/3 / Text5: 0/2004 1:12:03 PM</sync-timestamp><sync-itemid>15</sync-itemid><sync-prioritymapping>0:0-0/1:700-1000/2:300-699/3:1-299</sync-prioritymapping>
- 36: Text3: <sync-guid>{A91E6A09-5564-42DF-BC94-943042708C6D}</sync-guid><sync-parentguid>{052ABCD0-FD27-4490-B44D-790D5A6B7FFF}</sync-parentguid><sync-checksum>-1866843329</sync-checksum><sync-rootid>0</sync-rootid><sync-itemtype>0</sync-itemtype><sync-timestamp>12 / Text5: 30/2004 1:12:04 PM</sync-timestamp><sync-itemid>35</sync-itemid><sync-prioritymapping>0:0-0/1:700-1000/2:300-699/3:1-299</sync-prioritymapping>
- 37: Text3: <sync-guid>{314B74CF-4CE7-4B2D-86C7-0B83DA99896A}</sync-guid><sync-parentguid>{A91E6A09-5564-42DF-BC94-943042708C6D}</sync-parentguid><sync-checksum>761073508</sync-checksum><sync-rootid>0</sync-rootid><sync-itemtype>0</sync-itemtype><sync-timestamp>12/30 / Text5: 2004 1:12:03 PM</sync-timestamp><sync-itemid>461</sync-itemid><sync-prioritymapping>0:0-0/1:700-1000/2:300-699/3:1-299</sync-prioritymapping>
- 38: Text3: <sync-guid>{3861BF0B-8995-4280-A965-22D5DF576ACC}</sync-guid><sync-parentguid>{A91E6A09-5564-42DF-BC94-943042708C6D}</sync-parentguid><sync-checksum>1281349670</sync-checksum><sync-rootid>0</sync-rootid><sync-itemtype>0</sync-itemtype><sync-timestamp>12/3 / Text5: 0/2004 1:12:03 PM</sync-timestamp><sync-itemid>462</sync-itemid><sync-prioritymapping>0:0-0/1:700-1000/2:300-699/3:1-299</sync-prioritymapping>
- 39: Text3: <sync-guid>{487D1546-CC36-406D-9A55-822C8BB995BF}</sync-guid><sync-parentguid>{A91E6A09-5564-42DF-BC94-943042708C6D}</sync-parentguid><sync-checksum>-1981181422</sync-checksum><sync-rootid>0</sync-rootid><sync-itemtype>0</sync-itemtype><sync-timestamp>12 / Text5: 30/2004 1:12:03 PM</sync-timestamp><sync-itemid>34</sync-itemid><sync-prioritymapping>0:0-0/1:700-1000/2:300-699/3:1-299</sync-prioritymapping>
- 40: Text3: <sync-guid>{4D2A47C0-CA50-4228-BD68-6A927DA72498}</sync-guid><sync-parentguid>{A91E6A09-5564-42DF-BC94-943042708C6D}</sync-parentguid><sync-checksum>-2131394003</sync-checksum><sync-rootid>0</sync-rootid><sync-itemtype>0</sync-itemtype><sync-timestamp>12 / Text5: 30/2004 1:12:03 PM</sync-timestamp><sync-itemid>33</sync-itemid><sync-prioritymapping>0:0-0/1:700-1000/2:300-699/3:1-299</sync-prioritymapping>
- 41: Text3: <sync-guid>{E81F6F39-7CB2-439F-94B1-4DBD5CCF634A}</sync-guid><sync-parentguid>{A91E6A09-5564-42DF-BC94-943042708C6D}</sync-parentguid><sync-checksum>617922058</sync-checksum><sync-rootid>0</sync-rootid><sync-itemtype>0</sync-itemtype><sync-timestamp>12/30 / Text5: 2004 1:12:03 PM</sync-timestamp><sync-itemid>32</sync-itemid><sync-prioritymapping>0:0-0/1:700-1000/2:300-699/3:1-299</sync-prioritymapping>
- 42: Text3: <sync-guid>{A47DD7F5-5F03-4495-A229-6260A08A4297}</sync-guid><sync-parentguid>{A91E6A09-5564-42DF-BC94-943042708C6D}</sync-parentguid><sync-checksum>-1891302314</sync-checksum><sync-rootid>0</sync-rootid><sync-itemtype>0</sync-itemtype><sync-timestamp>12 / Text5: 30/2004 1:12:04 PM</sync-timestamp><sync-itemid>31</sync-itemid><sync-prioritymapping>0:0-0/1:700-1000/2:300-699/3:1-299</sync-prioritymapping>
- 43: Text3: <sync-guid>{700ACF25-2FCC-4F69-B763-419D4AED0598}</sync-guid><sync-parentguid>{A91E6A09-5564-42DF-BC94-943042708C6D}</sync-parentguid><sync-checksum>-118409193</sync-checksum><sync-rootid>0</sync-rootid><sync-itemtype>0</sync-itemtype><sync-timestamp>12/3 / Text5: 0/2004 1:12:04 PM</sync-timestamp><sync-itemid>30</sync-itemid><sync-prioritymapping>0:0-0/1:700-1000/2:300-699/3:1-299</sync-prioritymapping>
- 44: Text3: <sync-guid>{F1B25DDD-DA91-4876-BD05-38758A839B1F}</sync-guid><sync-parentguid>{A91E6A09-5564-42DF-BC94-943042708C6D}</sync-parentguid><sync-checksum>-343519620</sync-checksum><sync-rootid>0</sync-rootid><sync-itemtype>0</sync-itemtype><sync-timestamp>12/3 / Text5: 0/2004 1:12:04 PM</sync-timestamp><sync-itemid>36</sync-itemid><sync-prioritymapping>0:0-0/1:700-1000/2:300-699/3:1-299</sync-prioritymapping>
- 45: Text3: <sync-guid>{9A9724A9-9455-40A1-93B5-1FDCB199CB12}</sync-guid><sync-parentguid>{A91E6A09-5564-42DF-BC94-943042708C6D}</sync-parentguid><sync-checksum>21938478</sync-checksum><sync-rootid>0</sync-rootid><sync-itemtype>0</sync-itemtype><sync-timestamp>12/30 / Text5: 2004 1:12:04 PM</sync-timestamp><sync-itemid>29</sync-itemid><sync-prioritymapping>0:0-0/1:700-1000/2:300-699/3:1-299</sync-prioritymapping>
- 46: Text3: <sync-guid>{D24E5221-86D6-41DF-9C47-73E0F8DC32C0}</sync-guid><sync-parentguid>{A91E6A09-5564-42DF-BC94-943042708C6D}</sync-parentguid><sync-checksum>-189861763</sync-checksum><sync-rootid>0</sync-rootid><sync-itemtype>0</sync-itemtype><sync-timestamp>12/3 / Text5: 0/2004 1:12:04 PM</sync-timestamp><sync-itemid>22</sync-itemid><sync-prioritymapping>0:0-0/1:700-1000/2:300-699/3:1-299</sync-prioritymapping>
- 47: Text3: <sync-guid>{1EA21F57-364A-4A96-AB24-46E7B0D52A6A}</sync-guid><sync-parentguid>{052ABCD0-FD27-4490-B44D-790D5A6B7FFF}</sync-parentguid><sync-checksum>1399667208</sync-checksum><sync-rootid>0</sync-rootid><sync-itemtype>0</sync-itemtype><sync-timestamp>12/3 / Text5: 0/2004 1:12:05 PM</sync-timestamp><sync-itemid>348</sync-itemid><sync-prioritymapping>0:0-0/1:700-1000/2:300-699/3:1-299</sync-prioritymapping>
- 48: Text3: <sync-guid>{408EBB86-EBE3-44FD-8CDA-E4DAEFDB50B4}</sync-guid><sync-parentguid>{1EA21F57-364A-4A96-AB24-46E7B0D52A6A}</sync-parentguid><sync-checksum>-1898398234</sync-checksum><sync-rootid>0</sync-rootid><sync-itemtype>0</sync-itemtype><sync-timestamp>12 / Text5: 30/2004 1:08:59 PM</sync-timestamp><sync-itemid>1061</sync-itemid><sync-prioritymapping>0:0-0/1:700-1000/2:300-699/3:1-299</sync-prioritymapping>
- 49: Text3: <sync-guid>{9C310BE6-A6F5-4ECF-9651-AE1CD1F4D4A0}</sync-guid><sync-parentguid>{1EA21F57-364A-4A96-AB24-46E7B0D52A6A}</sync-parentguid><sync-checksum>-2042509019</sync-checksum><sync-rootid>0</sync-rootid><sync-itemtype>0</sync-itemtype><sync-timestamp>12 / Text5: 30/2004 1:09:00 PM</sync-timestamp><sync-itemid>1060</sync-itemid><sync-prioritymapping>0:0-0/1:700-1000/2:300-699/3:1-299</sync-prioritymapping>
- 50: Text3: <sync-guid>{88EA8770-12DE-448A-B20A-D2C3D2A02DAA}</sync-guid><sync-parentguid>{1EA21F57-364A-4A96-AB24-46E7B0D52A6A}</sync-parentguid><sync-checksum>459962147</sync-checksum><sync-rootid>0</sync-rootid><sync-itemtype>0</sync-itemtype><sync-timestamp>12/30 / Text5: 2004 1:09:00 PM</sync-timestamp><sync-itemid>1059</sync-itemid><sync-prioritymapping>0:0-0/1:700-1000/2:300-699/3:1-299</sync-prioritymapping>
- 51: Text3: <sync-guid>{6DE05BE5-78A0-4275-8CFF-2AE874F15406}</sync-guid><sync-parentguid>{1EA21F57-364A-4A96-AB24-46E7B0D52A6A}</sync-parentguid><sync-checksum>1271277324</sync-checksum><sync-rootid>0</sync-rootid><sync-itemtype>0</sync-itemtype><sync-timestamp>12/3 / Text5: 0/2004 1:09:00 PM</sync-timestamp><sync-itemid>1063</sync-itemid><sync-prioritymapping>0:0-0/1:700-1000/2:300-699/3:1-299</sync-prioritymapping>
- 52: Text3: <sync-guid>{2F6488CB-30CF-421A-80D2-2073A629A49F}</sync-guid><sync-parentguid>{1EA21F57-364A-4A96-AB24-46E7B0D52A6A}</sync-parentguid><sync-checksum>1248326295</sync-checksum><sync-rootid>0</sync-rootid><sync-itemtype>0</sync-itemtype><sync-timestamp>12/3 / Text5: 0/2004 1:09:00 PM</sync-timestamp><sync-itemid>1062</sync-itemid><sync-prioritymapping>0:0-0/1:700-1000/2:300-699/3:1-299</sync-prioritymapping>

| ID | WBS | Task | Duration | Start | Finish | Predecessors | Baseline start | Baseline finish | Baseline duration | Total slack | Text4 |
| --- | --- | --- | --- | --- | --- | --- | --- | --- | --- | --- | --- |
| 53 | 2 | **MEASURE** | 91.5d | 2005-02-01 | 2005-06-08 | 46 | 2005-02-01 | 2005-06-08 | 91.5d | 0d | {BB7CE42F-0C67-46DF-8685-BDA8257FDD3A} |
| 54 | 2.1 | **Define high-level process flows** | 5d | 2005-02-01 | 2005-02-08 |  | 2005-02-01 | 2005-02-08 | 5d | 0d | {E6A46D55-E2CC-4930-B574-AAF319E4A430} |
| 55 | 2.1.1 | Identify process steps | 1d | 2005-02-01 | 2005-02-02 |  | 2005-02-01 | 2005-02-02 | 1d | 0d | {20F9DB9E-5DB8-466B-9D17-DFF9DFFE5F24} |
| 56 | 2.1.2 | Define outputs & controls | 1d | 2005-02-02 | 2005-02-03 | 55 | 2005-02-02 | 2005-02-03 | 1d | 0d | {A948BBC9-51E1-442C-80ED-8A168DF5F593} |
| 57 | 2.1.3 | Develop initial high-level PMAP v0.1 | 1d | 2005-02-03 | 2005-02-04 | 56 | 2005-02-03 | 2005-02-04 | 1d | 0d | {940E2E83-B0F8-46B4-AD3F-326995A78749} |
| 58 | 2.1.4 | Review map with stakeholders | 1d | 2005-02-04 | 2005-02-07 | 57 | 2005-02-04 | 2005-02-07 | 1d | 0d | {B8808D3D-305F-4EAC-AC06-8952D6252267} |
| 59 | 2.1.5 | Revise high-level map from feedback v0.2 | 1d | 2005-02-07 | 2005-02-08 | 58 | 2005-02-07 | 2005-02-08 | 1d | 0d | {CFDDBD89-8674-4A01-B82B-023D512DDA5B} |
| 60 | 2.2 | **Synchronize business & process models** | 5d | 2005-02-08 | 2005-02-15 | 54 | 2005-02-08 | 2005-02-15 | 5d | 0d | {D1F23ABA-45F2-40E4-BA7B-C1BB44A7C2FA} |
| 61 | 2.2.1 | Cross-reference SIPOC & PMAP | 1d | 2005-02-08 | 2005-02-09 |  | 2005-02-08 | 2005-02-09 | 1d | 0d | {7B88D5C6-B952-40DF-8BB8-F75C113D7BEF} |
| 62 | 2.2.2 | Define omitted requirement statements | 1d | 2005-02-09 | 2005-02-10 | 61 | 2005-02-09 | 2005-02-10 | 1d | 0d | {6DEFD159-E412-4573-833F-D86E0572E846} |
| 63 | 2.2.3 | Assure correct divergence/convergence | 1d | 2005-02-10 | 2005-02-11 | 62 | 2005-02-10 | 2005-02-11 | 1d | 0d | {24DF20D5-A487-4A51-9DB3-6E6F0F5FAF8B} |
| 64 | 2.2.4 | Update SIPOC v0.3 | 1d | 2005-02-11 | 2005-02-14 | 63 | 2005-02-11 | 2005-02-14 | 1d | 0d | {4A330B9E-ADE2-438C-B4D6-7961C87A9140} |
| 65 | 2.2.5 | Update High-level PMAP v0.3 | 1d | 2005-02-14 | 2005-02-15 | 64 | 2005-02-14 | 2005-02-15 | 1d | 0d | {F4D75DD0-7C1C-4F4C-A828-53B63792DF37} |
| 66 | 2.2.6 | Review SIPOC & PMAP with stakeholders | 1d | 2005-02-08 | 2005-02-09 |  | 2005-02-08 | 2005-02-09 | 1d | 4d | {AA3E72A9-C0AC-46A7-8BF0-D78D9555A340} |
| 67 | 2.3 | **Map customer reqts to supplier inputs** | 9d | 2005-02-15 | 2005-02-28 | 60 | 2005-02-15 | 2005-02-28 | 9d | 0d | {8E9FAB33-0838-47AA-9F2D-4E91B0D38846} |
| 68 | 2.3.1 | Determine high-level requirements priorities | 1d | 2005-02-15 | 2005-02-16 |  | 2005-02-15 | 2005-02-16 | 1d | 0d | {3CDB2698-1B6C-46AF-ACC4-5E12F2B8D871} |
| 69 | 2.3.2 | Develop initial C&E matrix v0.1 | 1d | 2005-02-16 | 2005-02-17 | 68 | 2005-02-16 | 2005-02-17 | 1d | 0d | {BDB9A91F-0293-4BFC-BE6C-1C9D0C9B056A} |
| 70 | 2.3.3 | Identify common requirements | 1d | 2005-02-17 | 2005-02-18 | 69 | 2005-02-17 | 2005-02-18 | 1d | 0d | {398D1BC2-58B7-43E2-A7F1-046355198E0B} |
| 71 | 2.3.4 | Identify conflicting requirements | 1d | 2005-02-18 | 2005-02-21 | 70 | 2005-02-18 | 2005-02-21 | 1d | 0d | {2349E1B7-C8A8-43B9-9939-4B6A72F01313} |
| 72 | 2.3.5 | Build C&E process-requirement matrix v0.2 | 1d | 2005-02-21 | 2005-02-22 | 71 | 2005-02-21 | 2005-02-22 | 1d | 0d | {293B765F-F341-4E40-B362-8A130352A3D3} |
| 73 | 2.3.6 | Review C&E matrix with stakeholders | 1d | 2005-02-22 | 2005-02-23 | 72 | 2005-02-22 | 2005-02-23 | 1d | 0d | {138BDAD1-0FB8-443E-A263-520BFDE10683} |
| 74 | 2.3.7 | Revise SIPOC v0.4 | 1d | 2005-02-23 | 2005-02-24 | 73 | 2005-02-23 | 2005-02-24 | 1d | 0d | {EE8550F6-2A06-4902-8D8B-F85B349B9822} |
| 75 | 2.3.8 | Revise High-level PMAP v0.4 | 1d | 2005-02-24 | 2005-02-25 | 74 | 2005-02-24 | 2005-02-25 | 1d | 0d | {1B2519B7-630E-4CBE-B6A5-5BCECD0E7EC5} |
| 76 | 2.3.9 | Revise C&E Matrix v0.3 | 1d | 2005-02-25 | 2005-02-28 | 75 | 2005-02-25 | 2005-02-28 | 1d | 0d | {6180C204-54EE-44D6-BAED-3DA3F095107D} |

Notes:
- 53: Text3: <sync-guid>{BB7CE42F-0C67-46DF-8685-BDA8257FDD3A}</sync-guid><sync-parentguid>{69CAB05D-8790-4A69-A093-1D8EDB5A2679}</sync-parentguid><sync-checksum>1933176606</sync-checksum><sync-rootid>0</sync-rootid><sync-itemtype>0</sync-itemtype><sync-timestamp>12/3 / Text5: 0/2004 1:12:12 PM</sync-timestamp><sync-itemid>5</sync-itemid><sync-prioritymapping>0:0-0/1:700-1000/2:300-699/3:1-299</sync-prioritymapping>
- 54: Text3: <sync-guid>{E6A46D55-E2CC-4930-B574-AAF319E4A430}</sync-guid><sync-parentguid>{BB7CE42F-0C67-46DF-8685-BDA8257FDD3A}</sync-parentguid><sync-checksum>-1003818958</sync-checksum><sync-rootid>0</sync-rootid><sync-itemtype>0</sync-itemtype><sync-timestamp>12 / Text5: 30/2004 1:12:05 PM</sync-timestamp><sync-itemid>81</sync-itemid><sync-prioritymapping>0:0-0/1:700-1000/2:300-699/3:1-299</sync-prioritymapping>
- 55: Text3: <sync-guid>{20F9DB9E-5DB8-466B-9D17-DFF9DFFE5F24}</sync-guid><sync-parentguid>{E6A46D55-E2CC-4930-B574-AAF319E4A430}</sync-parentguid><sync-checksum>1947677356</sync-checksum><sync-rootid>0</sync-rootid><sync-itemtype>0</sync-itemtype><sync-timestamp>12/3 / Text5: 0/2004 1:12:05 PM</sync-timestamp><sync-itemid>80</sync-itemid><sync-prioritymapping>0:0-0/1:700-1000/2:300-699/3:1-299</sync-prioritymapping>
- 56: Text3: <sync-guid>{A948BBC9-51E1-442C-80ED-8A168DF5F593}</sync-guid><sync-parentguid>{E6A46D55-E2CC-4930-B574-AAF319E4A430}</sync-parentguid><sync-checksum>-2097481789</sync-checksum><sync-rootid>0</sync-rootid><sync-itemtype>0</sync-itemtype><sync-timestamp>12 / Text5: 30/2004 1:12:05 PM</sync-timestamp><sync-itemid>79</sync-itemid><sync-prioritymapping>0:0-0/1:700-1000/2:300-699/3:1-299</sync-prioritymapping>
- 57: Text3: <sync-guid>{940E2E83-B0F8-46B4-AD3F-326995A78749}</sync-guid><sync-parentguid>{E6A46D55-E2CC-4930-B574-AAF319E4A430}</sync-parentguid><sync-checksum>820647938</sync-checksum><sync-rootid>0</sync-rootid><sync-itemtype>0</sync-itemtype><sync-timestamp>12/30 / Text5: 2004 1:12:05 PM</sync-timestamp><sync-itemid>78</sync-itemid><sync-prioritymapping>0:0-0/1:700-1000/2:300-699/3:1-299</sync-prioritymapping>
- 58: Text3: <sync-guid>{B8808D3D-305F-4EAC-AC06-8952D6252267}</sync-guid><sync-parentguid>{E6A46D55-E2CC-4930-B574-AAF319E4A430}</sync-parentguid><sync-checksum>1928402402</sync-checksum><sync-rootid>0</sync-rootid><sync-itemtype>0</sync-itemtype><sync-timestamp>12/3 / Text5: 0/2004 1:12:05 PM</sync-timestamp><sync-itemid>77</sync-itemid><sync-prioritymapping>0:0-0/1:700-1000/2:300-699/3:1-299</sync-prioritymapping>
- 59: Text3: <sync-guid>{CFDDBD89-8674-4A01-B82B-023D512DDA5B}</sync-guid><sync-parentguid>{E6A46D55-E2CC-4930-B574-AAF319E4A430}</sync-parentguid><sync-checksum>2057741705</sync-checksum><sync-rootid>0</sync-rootid><sync-itemtype>0</sync-itemtype><sync-timestamp>12/3 / Text5: 0/2004 1:12:05 PM</sync-timestamp><sync-itemid>76</sync-itemid><sync-prioritymapping>0:0-0/1:700-1000/2:300-699/3:1-299</sync-prioritymapping>
- 60: Text3: <sync-guid>{D1F23ABA-45F2-40E4-BA7B-C1BB44A7C2FA}</sync-guid><sync-parentguid>{BB7CE42F-0C67-46DF-8685-BDA8257FDD3A}</sync-parentguid><sync-checksum>-2135929029</sync-checksum><sync-rootid>0</sync-rootid><sync-itemtype>0</sync-itemtype><sync-timestamp>12 / Text5: 30/2004 1:12:06 PM</sync-timestamp><sync-itemid>473</sync-itemid><sync-prioritymapping>0:0-0/1:700-1000/2:300-699/3:1-299</sync-prioritymapping>
- 61: Text3: <sync-guid>{7B88D5C6-B952-40DF-8BB8-F75C113D7BEF}</sync-guid><sync-parentguid>{D1F23ABA-45F2-40E4-BA7B-C1BB44A7C2FA}</sync-parentguid><sync-checksum>-107370382</sync-checksum><sync-rootid>0</sync-rootid><sync-itemtype>0</sync-itemtype><sync-timestamp>12/3 / Text5: 0/2004 1:12:05 PM</sync-timestamp><sync-itemid>472</sync-itemid><sync-prioritymapping>0:0-0/1:700-1000/2:300-699/3:1-299</sync-prioritymapping>
- 62: Text3: <sync-guid>{6DEFD159-E412-4573-833F-D86E0572E846}</sync-guid><sync-parentguid>{D1F23ABA-45F2-40E4-BA7B-C1BB44A7C2FA}</sync-parentguid><sync-checksum>-1113321578</sync-checksum><sync-rootid>0</sync-rootid><sync-itemtype>0</sync-itemtype><sync-timestamp>12 / Text5: 30/2004 1:12:06 PM</sync-timestamp><sync-itemid>471</sync-itemid><sync-prioritymapping>0:0-0/1:700-1000/2:300-699/3:1-299</sync-prioritymapping>
- 63: Text3: <sync-guid>{24DF20D5-A487-4A51-9DB3-6E6F0F5FAF8B}</sync-guid><sync-parentguid>{D1F23ABA-45F2-40E4-BA7B-C1BB44A7C2FA}</sync-parentguid><sync-checksum>-867304681</sync-checksum><sync-rootid>0</sync-rootid><sync-itemtype>0</sync-itemtype><sync-timestamp>12/3 / Text5: 0/2004 1:12:06 PM</sync-timestamp><sync-itemid>470</sync-itemid><sync-prioritymapping>0:0-0/1:700-1000/2:300-699/3:1-299</sync-prioritymapping>
- 64: Text3: <sync-guid>{4A330B9E-ADE2-438C-B4D6-7961C87A9140}</sync-guid><sync-parentguid>{D1F23ABA-45F2-40E4-BA7B-C1BB44A7C2FA}</sync-parentguid><sync-checksum>2133852791</sync-checksum><sync-rootid>0</sync-rootid><sync-itemtype>0</sync-itemtype><sync-timestamp>12/3 / Text5: 0/2004 1:12:06 PM</sync-timestamp><sync-itemid>469</sync-itemid><sync-prioritymapping>0:0-0/1:700-1000/2:300-699/3:1-299</sync-prioritymapping>
- 65: Text3: <sync-guid>{F4D75DD0-7C1C-4F4C-A828-53B63792DF37}</sync-guid><sync-parentguid>{D1F23ABA-45F2-40E4-BA7B-C1BB44A7C2FA}</sync-parentguid><sync-checksum>-1021833000</sync-checksum><sync-rootid>0</sync-rootid><sync-itemtype>0</sync-itemtype><sync-timestamp>12 / Text5: 30/2004 1:12:06 PM</sync-timestamp><sync-itemid>477</sync-itemid><sync-prioritymapping>0:0-0/1:700-1000/2:300-699/3:1-299</sync-prioritymapping>
- 66: Text3: <sync-guid>{AA3E72A9-C0AC-46A7-8BF0-D78D9555A340}</sync-guid><sync-parentguid>{D1F23ABA-45F2-40E4-BA7B-C1BB44A7C2FA}</sync-parentguid><sync-checksum>142155247</sync-checksum><sync-rootid>0</sync-rootid><sync-itemtype>0</sync-itemtype><sync-timestamp>12/30 / Text5: 2004 1:12:06 PM</sync-timestamp><sync-itemid>478</sync-itemid><sync-prioritymapping>0:0-0/1:700-1000/2:300-699/3:1-299</sync-prioritymapping>
- 67: Text3: <sync-guid>{8E9FAB33-0838-47AA-9F2D-4E91B0D38846}</sync-guid><sync-parentguid>{BB7CE42F-0C67-46DF-8685-BDA8257FDD3A}</sync-parentguid><sync-checksum>-1542335428</sync-checksum><sync-rootid>0</sync-rootid><sync-itemtype>0</sync-itemtype><sync-timestamp>12 / Text5: 30/2004 1:12:07 PM</sync-timestamp><sync-itemid>75</sync-itemid><sync-prioritymapping>0:0-0/1:700-1000/2:300-699/3:1-299</sync-prioritymapping>
- 68: Text3: <sync-guid>{3CDB2698-1B6C-46AF-ACC4-5E12F2B8D871}</sync-guid><sync-parentguid>{8E9FAB33-0838-47AA-9F2D-4E91B0D38846}</sync-parentguid><sync-checksum>741872694</sync-checksum><sync-rootid>0</sync-rootid><sync-itemtype>0</sync-itemtype><sync-timestamp>12/30 / Text5: 2004 1:12:06 PM</sync-timestamp><sync-itemid>74</sync-itemid><sync-prioritymapping>0:0-0/1:700-1000/2:300-699/3:1-299</sync-prioritymapping>
- 69: Text3: <sync-guid>{BDB9A91F-0293-4BFC-BE6C-1C9D0C9B056A}</sync-guid><sync-parentguid>{8E9FAB33-0838-47AA-9F2D-4E91B0D38846}</sync-parentguid><sync-checksum>-1320415209</sync-checksum><sync-rootid>0</sync-rootid><sync-itemtype>0</sync-itemtype><sync-timestamp>12 / Text5: 30/2004 1:12:06 PM</sync-timestamp><sync-itemid>73</sync-itemid><sync-prioritymapping>0:0-0/1:700-1000/2:300-699/3:1-299</sync-prioritymapping>
- 70: Text3: <sync-guid>{398D1BC2-58B7-43E2-A7F1-046355198E0B}</sync-guid><sync-parentguid>{8E9FAB33-0838-47AA-9F2D-4E91B0D38846}</sync-parentguid><sync-checksum>492705720</sync-checksum><sync-rootid>0</sync-rootid><sync-itemtype>0</sync-itemtype><sync-timestamp>12/30 / Text5: 2004 1:12:06 PM</sync-timestamp><sync-itemid>72</sync-itemid><sync-prioritymapping>0:0-0/1:700-1000/2:300-699/3:1-299</sync-prioritymapping>
- 71: Text3: <sync-guid>{2349E1B7-C8A8-43B9-9939-4B6A72F01313}</sync-guid><sync-parentguid>{8E9FAB33-0838-47AA-9F2D-4E91B0D38846}</sync-parentguid><sync-checksum>859195237</sync-checksum><sync-rootid>0</sync-rootid><sync-itemtype>0</sync-itemtype><sync-timestamp>12/30 / Text5: 2004 1:12:07 PM</sync-timestamp><sync-itemid>71</sync-itemid><sync-prioritymapping>0:0-0/1:700-1000/2:300-699/3:1-299</sync-prioritymapping>
- 72: Text3: <sync-guid>{293B765F-F341-4E40-B362-8A130352A3D3}</sync-guid><sync-parentguid>{8E9FAB33-0838-47AA-9F2D-4E91B0D38846}</sync-parentguid><sync-checksum>-1949908216</sync-checksum><sync-rootid>0</sync-rootid><sync-itemtype>0</sync-itemtype><sync-timestamp>12 / Text5: 30/2004 1:12:07 PM</sync-timestamp><sync-itemid>70</sync-itemid><sync-prioritymapping>0:0-0/1:700-1000/2:300-699/3:1-299</sync-prioritymapping>
- 73: Text3: <sync-guid>{138BDAD1-0FB8-443E-A263-520BFDE10683}</sync-guid><sync-parentguid>{8E9FAB33-0838-47AA-9F2D-4E91B0D38846}</sync-parentguid><sync-checksum>-248399581</sync-checksum><sync-rootid>0</sync-rootid><sync-itemtype>0</sync-itemtype><sync-timestamp>12/3 / Text5: 0/2004 1:12:07 PM</sync-timestamp><sync-itemid>69</sync-itemid><sync-prioritymapping>0:0-0/1:700-1000/2:300-699/3:1-299</sync-prioritymapping>
- 74: Text3: <sync-guid>{EE8550F6-2A06-4902-8D8B-F85B349B9822}</sync-guid><sync-parentguid>{8E9FAB33-0838-47AA-9F2D-4E91B0D38846}</sync-parentguid><sync-checksum>-1456496873</sync-checksum><sync-rootid>0</sync-rootid><sync-itemtype>0</sync-itemtype><sync-timestamp>12 / Text5: 30/2004 1:12:07 PM</sync-timestamp><sync-itemid>480</sync-itemid><sync-prioritymapping>0:0-0/1:700-1000/2:300-699/3:1-299</sync-prioritymapping>
- 75: Text3: <sync-guid>{1B2519B7-630E-4CBE-B6A5-5BCECD0E7EC5}</sync-guid><sync-parentguid>{8E9FAB33-0838-47AA-9F2D-4E91B0D38846}</sync-parentguid><sync-checksum>1111072927</sync-checksum><sync-rootid>0</sync-rootid><sync-itemtype>0</sync-itemtype><sync-timestamp>12/3 / Text5: 0/2004 1:12:07 PM</sync-timestamp><sync-itemid>479</sync-itemid><sync-prioritymapping>0:0-0/1:700-1000/2:300-699/3:1-299</sync-prioritymapping>
- 76: Text3: <sync-guid>{6180C204-54EE-44D6-BAED-3DA3F095107D}</sync-guid><sync-parentguid>{8E9FAB33-0838-47AA-9F2D-4E91B0D38846}</sync-parentguid><sync-checksum>874796507</sync-checksum><sync-rootid>0</sync-rootid><sync-itemtype>0</sync-itemtype><sync-timestamp>12/30 / Text5: 2004 1:12:07 PM</sync-timestamp><sync-itemid>68</sync-itemid><sync-prioritymapping>0:0-0/1:700-1000/2:300-699/3:1-299</sync-prioritymapping>

| ID | WBS | Task | Type | Duration | Start | Finish | Predecessors | Baseline start | Baseline finish | Baseline duration | Total slack | Free slack | Text4 |
| --- | --- | --- | --- | --- | --- | --- | --- | --- | --- | --- | --- | --- | --- |
| 77 | 2.4 | **Validate requirements models** |  | 4d | 2005-02-28 | 2005-03-04 | 67 | 2005-02-28 | 2005-03-04 | 4d | 0d |  | {F9343263-0169-4631-8E62-BB11F3272BD6} |
| 78 | 2.4.1 | Consolidate SIPOC, PMAP, C&E Matrix |  | 1d | 2005-02-28 | 2005-03-01 |  | 2005-02-28 | 2005-03-01 | 1d | 0d |  | {064F47B1-EAA4-4279-AC51-F05E757B4634} |
| 79 | 2.4.2 | Conduct consolidated peer review |  | 1d | 2005-03-01 | 2005-03-02 | 78 | 2005-03-01 | 2005-03-02 | 1d | 0d |  | {A7814ABD-269E-4758-BD83-577E6DA9DC6E} |
| 80 | 2.4.3 | Update SIPOC v0.5 |  | 1d | 2005-03-02 | 2005-03-03 | 79 | 2005-03-02 | 2005-03-03 | 1d | 0d |  | {72EC72D5-6A49-4FED-B439-3A1531D8951F} |
| 81 | 2.4.4 | Update High-Level PMAP v0.5 |  | 1d | 2005-03-02 | 2005-03-03 | 79 | 2005-03-02 | 2005-03-03 | 1d | 0d |  | {8169AF62-FBEE-4364-8BE8-6F64E13A86B1} |
| 82 | 2.4.5 | Update C&E Matrix v0.4 |  | 1d | 2005-03-02 | 2005-03-03 | 79 | 2005-03-02 | 2005-03-03 | 1d | 0d |  | {23925AFC-CCBB-4F6A-9377-4CCC06DACB4F} |
| 83 | 2.4.6 | Initialize QFD1 requirements-process matrix |  | 1d | 2005-03-03 | 2005-03-04 | 80, 81, 82 | 2005-03-03 | 2005-03-04 | 1d | 0d |  | {7F2DF3C4-2736-429C-883A-E2C494B4DD2C} |
| 84 | 2.4.7 | Approve consolidated requirements models | milestone | 0d | 2005-03-04 | 2005-03-04 | 83 | 2005-03-04 | 2005-03-04 | 0d | 0d |  | {3D268C25-5413-4037-83D7-8D63DD4F7C46} |
| 85 | 2.5 | **Define measurement plan** |  | 13.5d | 2005-02-15 | 2005-03-04 | 60 | 2005-02-15 | 2005-03-04 | 13.5d | 54d | 0d | {C4A1E8CA-89D6-4E66-9925-8A1BF6589051} |
| 86 | 2.5.1 | Review estimated Sigma Score model |  | 0.5d | 2005-02-15 | 2005-02-15 |  | 2005-02-15 | 2005-02-15 | 0.5d | 61.5d | 0d | {8D611B9B-E780-48CF-AE16-A654E93759F5} |
| 87 | 2.5.2 | Define requirements measures |  | 1d | 2005-02-16 | 2005-02-16 | 86 | 2005-02-16 | 2005-02-16 | 1d | 61.5d | 0d | {33B9ABDD-29E5-4670-A8B6-335844DE5901} |
| 88 | 2.5.3 | Identify sampling scenarios |  | 1d | 2005-02-17 | 2005-02-17 | 87 | 2005-02-17 | 2005-02-17 | 1d | 61.5d | 0d | {8204D3EF-8CDE-4D84-8633-FEE681D83940} |
| 89 | 2.5.4 | Build measurement procedures |  | 1d | 2005-02-18 | 2005-02-18 | 88 | 2005-02-18 | 2005-02-18 | 1d | 61.5d | 0d | {6444DFD6-8502-4837-BF63-8B82AD6753F8} |
| 90 | 2.5.5 | Review measurement plan with stakeholders |  | 1d | 2005-02-21 | 2005-02-21 | 89 | 2005-02-21 | 2005-02-21 | 1d | 61.5d | 0d | {F233452E-2C97-438B-8555-08A637AC645B} |
| 91 | 2.5.6 | Revise procedures using feedback |  | 1d | 2005-02-22 | 2005-02-22 | 90 | 2005-02-22 | 2005-02-22 | 1d | 61.5d | 7.5d | {01FAB342-70ED-41DF-8EC1-3DE19924F602} |
| 92 | 2.5.7 | Prioritize measurement dimensions |  | 0.5d | 2005-03-04 | 2005-03-04 | 91, 84 | 2005-03-04 | 2005-03-04 | 0.5d | 54d |  | {E48E4EE2-5DD2-467E-A01A-4DC09391AA1D} |
| 93 | 2.6 | **Collect initial process-quality data** |  | 8d | 2005-03-07 | 2005-03-16 | 85 | 2005-03-07 | 2005-03-16 | 8d | 54d | 0d | {FD824FF2-D4DB-45F6-B498-704B021C022B} |
| 94 | 2.6.1 | Establish sensing touchpoints |  | 1d | 2005-03-07 | 2005-03-07 |  | 2005-03-07 | 2005-03-07 | 1d | 54d | 0d | {A0CC5738-90ED-4DEE-B33A-812E87712F1F} |
| 95 | 2.6.2 | Log data points |  | 5d | 2005-03-08 | 2005-03-14 | 94 | 2005-03-08 | 2005-03-14 | 5d | 54d | 0d | {7900CD65-1335-4AB1-9131-C923EC9165F0} |
| 96 | 2.6.3 | Consolidate collected data |  | 1d | 2005-03-15 | 2005-03-15 | 95 | 2005-03-15 | 2005-03-15 | 1d | 54d | 0d | {C932C1FC-F437-45B7-9281-0798B54B0532} |
| 97 | 2.6.4 | Rationalize DPU & DPMO metrics |  | 1d | 2005-03-16 | 2005-03-16 | 96 | 2005-03-16 | 2005-03-16 | 1d | 54d | 0d | {859738AC-860C-4A0B-A28D-104279F24B4C} |
| 98 | 2.6.5 | Produce intial Sigma Score snapshot | milestone | 0d | 2005-03-16 | 2005-03-16 | 97 | 2005-03-16 | 2005-03-16 | 0d | 54d |  | {500A4C30-655E-4802-B68F-465B530A1C4E} |
| 99 | 2.7 | **Collect voice-of-the-customer data** |  | 59d | 2005-03-07 | 2005-05-26 | 85 | 2005-03-07 | 2005-05-26 | 59d | 63d |  | {C869DD90-8F31-4C08-9A36-F9086CC4A9F6} |
| 100 | 2.7.1 | Plan collection activities |  | 1d | 2005-03-07 | 2005-03-07 |  | 2005-03-07 | 2005-03-07 | 1d | 63d | 0d | {B2330575-3E10-412F-8B2D-904C440C4F21} |
| 101 | 2.7.2 | Build collection instruments |  | 1d | 2005-03-08 | 2005-03-08 | 100 | 2005-03-08 | 2005-03-08 | 1d | 63d | 0d | {C346CB4A-29B3-4FDA-B7BE-9C6215956ACE} |
| 102 | 2.7.3 | Review collection instruments |  | 1d | 2005-03-09 | 2005-03-09 | 101 | 2005-03-09 | 2005-03-09 | 1d | 63d | 0d | {926FD985-7F99-49FB-A5D5-7D108E29B363} |
| 103 | 2.7.4 | Revise collection instruments |  | 1d | 2005-03-10 | 2005-03-10 | 102 | 2005-03-10 | 2005-03-10 | 1d | 63d | 0d | {94BC0D1E-C5B1-4F43-A8D7-20AC60D3C9C4} |
| 104 | 2.7.5 | Test collection instruments |  | 3d | 2005-03-11 | 2005-03-15 | 103 | 2005-03-11 | 2005-03-15 | 3d | 63d | 0d | {ACEBA1EB-FEE6-4742-805A-677DC8404C38} |
| 105 | 2.7.6 | Conduct instrument peer review |  | 1d | 2005-03-16 | 2005-03-16 | 104 | 2005-03-16 | 2005-03-16 | 1d | 63d | 0d | {044B9A68-7A9E-422B-8513-1DA621CEFB9A} |
| 106 | 2.7.7 | Finalize collection instruments |  | 1d | 2005-03-17 | 2005-03-17 | 105 | 2005-03-17 | 2005-03-17 | 1d | 63d | 0d | {495F7E73-DAA4-4863-A4DD-19C8533EFEEC} |
| 107 | 2.7.8 | Conduct collection activities |  | 50d | 2005-03-18 | 2005-05-26 | 106 | 2005-03-18 | 2005-05-26 | 50d | 63d | 0d | {EADE7F8A-7008-4476-BCD5-B05174487B05} |
| 108 | 2.7.9 | Consolidate collect information |  | 40d | 2005-04-01 | 2005-05-26 | 107FF | 2005-04-01 | 2005-05-26 | 40d | 63d | 0d | {780B3AD3-6C0F-4EAC-ABA1-467ED1CF6237} |
| 109 | 2.7.10 | Review voice-of-the-customer data |  | 30d | 2005-04-15 | 2005-05-26 | 108FF | 2005-04-15 | 2005-05-26 | 30d | 63d |  | {368F0B3F-6350-46A9-B427-AABFED99894C} |

Notes:
- 77: Text3: <sync-guid>{F9343263-0169-4631-8E62-BB11F3272BD6}</sync-guid><sync-parentguid>{BB7CE42F-0C67-46DF-8685-BDA8257FDD3A}</sync-parentguid><sync-checksum>-1973387466</sync-checksum><sync-rootid>0</sync-rootid><sync-itemtype>0</sync-itemtype><sync-timestamp>12 / Text5: 30/2004 1:12:08 PM</sync-timestamp><sync-itemid>487</sync-itemid><sync-prioritymapping>0:0-0/1:700-1000/2:300-699/3:1-299</sync-prioritymapping>
- 78: Text3: <sync-guid>{064F47B1-EAA4-4279-AC51-F05E757B4634}</sync-guid><sync-parentguid>{F9343263-0169-4631-8E62-BB11F3272BD6}</sync-parentguid><sync-checksum>1697479466</sync-checksum><sync-rootid>0</sync-rootid><sync-itemtype>0</sync-itemtype><sync-timestamp>12/3 / Text5: 0/2004 1:12:07 PM</sync-timestamp><sync-itemid>483</sync-itemid><sync-prioritymapping>0:0-0/1:700-1000/2:300-699/3:1-299</sync-prioritymapping>
- 79: Text3: <sync-guid>{A7814ABD-269E-4758-BD83-577E6DA9DC6E}</sync-guid><sync-parentguid>{F9343263-0169-4631-8E62-BB11F3272BD6}</sync-parentguid><sync-checksum>-739390356</sync-checksum><sync-rootid>0</sync-rootid><sync-itemtype>0</sync-itemtype><sync-timestamp>12/3 / Text5: 0/2004 1:12:08 PM</sync-timestamp><sync-itemid>482</sync-itemid><sync-prioritymapping>0:0-0/1:700-1000/2:300-699/3:1-299</sync-prioritymapping>
- 80: Text3: <sync-guid>{72EC72D5-6A49-4FED-B439-3A1531D8951F}</sync-guid><sync-parentguid>{F9343263-0169-4631-8E62-BB11F3272BD6}</sync-parentguid><sync-checksum>-1809024138</sync-checksum><sync-rootid>0</sync-rootid><sync-itemtype>0</sync-itemtype><sync-timestamp>12 / Text5: 30/2004 1:12:08 PM</sync-timestamp><sync-itemid>486</sync-itemid><sync-prioritymapping>0:0-0/1:700-1000/2:300-699/3:1-299</sync-prioritymapping>
- 81: Text3: <sync-guid>{8169AF62-FBEE-4364-8BE8-6F64E13A86B1}</sync-guid><sync-parentguid>{F9343263-0169-4631-8E62-BB11F3272BD6}</sync-parentguid><sync-checksum>-2116536496</sync-checksum><sync-rootid>0</sync-rootid><sync-itemtype>0</sync-itemtype><sync-timestamp>12 / Text5: 30/2004 1:12:08 PM</sync-timestamp><sync-itemid>485</sync-itemid><sync-prioritymapping>0:0-0/1:700-1000/2:300-699/3:1-299</sync-prioritymapping>
- 82: Text3: <sync-guid>{23925AFC-CCBB-4F6A-9377-4CCC06DACB4F}</sync-guid><sync-parentguid>{F9343263-0169-4631-8E62-BB11F3272BD6}</sync-parentguid><sync-checksum>155293774</sync-checksum><sync-rootid>0</sync-rootid><sync-itemtype>0</sync-itemtype><sync-timestamp>12/30 / Text5: 2004 1:12:08 PM</sync-timestamp><sync-itemid>484</sync-itemid><sync-prioritymapping>0:0-0/1:700-1000/2:300-699/3:1-299</sync-prioritymapping>
- 83: Text3: <sync-guid>{7F2DF3C4-2736-429C-883A-E2C494B4DD2C}</sync-guid><sync-parentguid>{F9343263-0169-4631-8E62-BB11F3272BD6}</sync-parentguid><sync-checksum>1631609078</sync-checksum><sync-rootid>0</sync-rootid><sync-itemtype>0</sync-itemtype><sync-timestamp>12/3 / Text5: 0/2004 1:12:08 PM</sync-timestamp><sync-itemid>510</sync-itemid><sync-prioritymapping>0:0-0/1:700-1000/2:300-699/3:1-299</sync-prioritymapping>
- 84: Text3: <sync-guid>{3D268C25-5413-4037-83D7-8D63DD4F7C46}</sync-guid><sync-parentguid>{F9343263-0169-4631-8E62-BB11F3272BD6}</sync-parentguid><sync-checksum>-535018278</sync-checksum><sync-rootid>0</sync-rootid><sync-itemtype>0</sync-itemtype><sync-timestamp>12/3 / Text5: 0/2004 1:12:08 PM</sync-timestamp><sync-itemid>481</sync-itemid><sync-prioritymapping>0:0-0/1:700-1000/2:300-699/3:1-299</sync-prioritymapping>
- 85: Text3: <sync-guid>{C4A1E8CA-89D6-4E66-9925-8A1BF6589051}</sync-guid><sync-parentguid>{BB7CE42F-0C67-46DF-8685-BDA8257FDD3A}</sync-parentguid><sync-checksum>-678808596</sync-checksum><sync-rootid>0</sync-rootid><sync-itemtype>0</sync-itemtype><sync-timestamp>12/3 / Text5: 0/2004 1:12:09 PM</sync-timestamp><sync-itemid>491</sync-itemid><sync-prioritymapping>0:0-0/1:700-1000/2:300-699/3:1-299</sync-prioritymapping>
- 86: Text3: <sync-guid>{8D611B9B-E780-48CF-AE16-A654E93759F5}</sync-guid><sync-parentguid>{C4A1E8CA-89D6-4E66-9925-8A1BF6589051}</sync-parentguid><sync-checksum>280658788</sync-checksum><sync-rootid>0</sync-rootid><sync-itemtype>0</sync-itemtype><sync-timestamp>12/30 / Text5: 2004 1:12:08 PM</sync-timestamp><sync-itemid>490</sync-itemid><sync-prioritymapping>0:0-0/1:700-1000/2:300-699/3:1-299</sync-prioritymapping>
- 87: Text3: <sync-guid>{33B9ABDD-29E5-4670-A8B6-335844DE5901}</sync-guid><sync-parentguid>{C4A1E8CA-89D6-4E66-9925-8A1BF6589051}</sync-parentguid><sync-checksum>1304550328</sync-checksum><sync-rootid>0</sync-rootid><sync-itemtype>0</sync-itemtype><sync-timestamp>12/3 / Text5: 0/2004 1:12:09 PM</sync-timestamp><sync-itemid>489</sync-itemid><sync-prioritymapping>0:0-0/1:700-1000/2:300-699/3:1-299</sync-prioritymapping>
- 88: Text3: <sync-guid>{8204D3EF-8CDE-4D84-8633-FEE681D83940}</sync-guid><sync-parentguid>{C4A1E8CA-89D6-4E66-9925-8A1BF6589051}</sync-parentguid><sync-checksum>-1655029323</sync-checksum><sync-rootid>0</sync-rootid><sync-itemtype>0</sync-itemtype><sync-timestamp>12 / Text5: 30/2004 1:12:09 PM</sync-timestamp><sync-itemid>494</sync-itemid><sync-prioritymapping>0:0-0/1:700-1000/2:300-699/3:1-299</sync-prioritymapping>
- 89: Text3: <sync-guid>{6444DFD6-8502-4837-BF63-8B82AD6753F8}</sync-guid><sync-parentguid>{C4A1E8CA-89D6-4E66-9925-8A1BF6589051}</sync-parentguid><sync-checksum>-855964953</sync-checksum><sync-rootid>0</sync-rootid><sync-itemtype>0</sync-itemtype><sync-timestamp>12/3 / Text5: 0/2004 1:12:09 PM</sync-timestamp><sync-itemid>493</sync-itemid><sync-prioritymapping>0:0-0/1:700-1000/2:300-699/3:1-299</sync-prioritymapping>
- 90: Text3: <sync-guid>{F233452E-2C97-438B-8555-08A637AC645B}</sync-guid><sync-parentguid>{C4A1E8CA-89D6-4E66-9925-8A1BF6589051}</sync-parentguid><sync-checksum>-1119911918</sync-checksum><sync-rootid>0</sync-rootid><sync-itemtype>0</sync-itemtype><sync-timestamp>12 / Text5: 30/2004 1:12:09 PM</sync-timestamp><sync-itemid>492</sync-itemid><sync-prioritymapping>0:0-0/1:700-1000/2:300-699/3:1-299</sync-prioritymapping>
- 91: Text3: <sync-guid>{01FAB342-70ED-41DF-8EC1-3DE19924F602}</sync-guid><sync-parentguid>{C4A1E8CA-89D6-4E66-9925-8A1BF6589051}</sync-parentguid><sync-checksum>583382037</sync-checksum><sync-rootid>0</sync-rootid><sync-itemtype>0</sync-itemtype><sync-timestamp>12/30 / Text5: 2004 1:12:09 PM</sync-timestamp><sync-itemid>488</sync-itemid><sync-prioritymapping>0:0-0/1:700-1000/2:300-699/3:1-299</sync-prioritymapping>
- 92: Text3: <sync-guid>{E48E4EE2-5DD2-467E-A01A-4DC09391AA1D}</sync-guid><sync-parentguid>{C4A1E8CA-89D6-4E66-9925-8A1BF6589051}</sync-parentguid><sync-checksum>-964732349</sync-checksum><sync-rootid>0</sync-rootid><sync-itemtype>0</sync-itemtype><sync-timestamp>12/3 / Text5: 0/2004 1:12:09 PM</sync-timestamp><sync-itemid>495</sync-itemid><sync-prioritymapping>0:0-0/1:700-1000/2:300-699/3:1-299</sync-prioritymapping>
- 93: Text3: <sync-guid>{FD824FF2-D4DB-45F6-B498-704B021C022B}</sync-guid><sync-parentguid>{BB7CE42F-0C67-46DF-8685-BDA8257FDD3A}</sync-parentguid><sync-checksum>-730638458</sync-checksum><sync-rootid>0</sync-rootid><sync-itemtype>0</sync-itemtype><sync-timestamp>12/3 / Text5: 0/2004 1:12:10 PM</sync-timestamp><sync-itemid>499</sync-itemid><sync-prioritymapping>0:0-0/1:700-1000/2:300-699/3:1-299</sync-prioritymapping>
- 94: Text3: <sync-guid>{A0CC5738-90ED-4DEE-B33A-812E87712F1F}</sync-guid><sync-parentguid>{FD824FF2-D4DB-45F6-B498-704B021C022B}</sync-parentguid><sync-checksum>-1162846118</sync-checksum><sync-rootid>0</sync-rootid><sync-itemtype>0</sync-itemtype><sync-timestamp>12 / Text5: 30/2004 1:12:09 PM</sync-timestamp><sync-itemid>503</sync-itemid><sync-prioritymapping>0:0-0/1:700-1000/2:300-699/3:1-299</sync-prioritymapping>
- 95: Text3: <sync-guid>{7900CD65-1335-4AB1-9131-C923EC9165F0}</sync-guid><sync-parentguid>{FD824FF2-D4DB-45F6-B498-704B021C022B}</sync-parentguid><sync-checksum>-446511627</sync-checksum><sync-rootid>0</sync-rootid><sync-itemtype>0</sync-itemtype><sync-timestamp>12/3 / Text5: 0/2004 1:12:09 PM</sync-timestamp><sync-itemid>502</sync-itemid><sync-prioritymapping>0:0-0/1:700-1000/2:300-699/3:1-299</sync-prioritymapping>
- 96: Text3: <sync-guid>{C932C1FC-F437-45B7-9281-0798B54B0532}</sync-guid><sync-parentguid>{FD824FF2-D4DB-45F6-B498-704B021C022B}</sync-parentguid><sync-checksum>-1637126459</sync-checksum><sync-rootid>0</sync-rootid><sync-itemtype>0</sync-itemtype><sync-timestamp>12 / Text5: 30/2004 1:12:10 PM</sync-timestamp><sync-itemid>501</sync-itemid><sync-prioritymapping>0:0-0/1:700-1000/2:300-699/3:1-299</sync-prioritymapping>
- 97: Text3: <sync-guid>{859738AC-860C-4A0B-A28D-104279F24B4C}</sync-guid><sync-parentguid>{FD824FF2-D4DB-45F6-B498-704B021C022B}</sync-parentguid><sync-checksum>-156584450</sync-checksum><sync-rootid>0</sync-rootid><sync-itemtype>0</sync-itemtype><sync-timestamp>12/3 / Text5: 0/2004 1:12:10 PM</sync-timestamp><sync-itemid>504</sync-itemid><sync-prioritymapping>0:0-0/1:700-1000/2:300-699/3:1-299</sync-prioritymapping>
- 98: Text3: <sync-guid>{500A4C30-655E-4802-B68F-465B530A1C4E}</sync-guid><sync-parentguid>{FD824FF2-D4DB-45F6-B498-704B021C022B}</sync-parentguid><sync-checksum>1332332143</sync-checksum><sync-rootid>0</sync-rootid><sync-itemtype>0</sync-itemtype><sync-timestamp>12/3 / Text5: 0/2004 1:12:10 PM</sync-timestamp><sync-itemid>500</sync-itemid><sync-prioritymapping>0:0-0/1:700-1000/2:300-699/3:1-299</sync-prioritymapping>
- 99: Text3: <sync-guid>{C869DD90-8F31-4C08-9A36-F9086CC4A9F6}</sync-guid><sync-parentguid>{BB7CE42F-0C67-46DF-8685-BDA8257FDD3A}</sync-parentguid><sync-checksum>-1537021171</sync-checksum><sync-rootid>0</sync-rootid><sync-itemtype>0</sync-itemtype><sync-timestamp>1/1 / Text5: 0/2005 9:26:10 AM</sync-timestamp><sync-itemid>1313</sync-itemid><sync-prioritymapping>0:0-0/1:700-1000/2:300-699/3:1-299</sync-prioritymapping>
- 100: Text3: <sync-guid>{B2330575-3E10-412F-8B2D-904C440C4F21}</sync-guid><sync-parentguid>{C869DD90-8F31-4C08-9A36-F9086CC4A9F6}</sync-parentguid><sync-checksum>1075493481</sync-checksum><sync-rootid>0</sync-rootid><sync-itemtype>0</sync-itemtype><sync-timestamp>1/10 / Text5: 2005 9:26:11 AM</sync-timestamp><sync-itemid>1312</sync-itemid><sync-prioritymapping>0:0-0/1:700-1000/2:300-699/3:1-299</sync-prioritymapping>
- 101: Text3: <sync-guid>{C346CB4A-29B3-4FDA-B7BE-9C6215956ACE}</sync-guid><sync-parentguid>{C869DD90-8F31-4C08-9A36-F9086CC4A9F6}</sync-parentguid><sync-checksum>-1340337786</sync-checksum><sync-rootid>0</sync-rootid><sync-itemtype>0</sync-itemtype><sync-timestamp>1/1 / Text5: 0/2005 9:26:11 AM</sync-timestamp><sync-itemid>1311</sync-itemid><sync-prioritymapping>0:0-0/1:700-1000/2:300-699/3:1-299</sync-prioritymapping>
- 102: Text3: <sync-guid>{926FD985-7F99-49FB-A5D5-7D108E29B363}</sync-guid><sync-parentguid>{C869DD90-8F31-4C08-9A36-F9086CC4A9F6}</sync-parentguid><sync-checksum>-1047033672</sync-checksum><sync-rootid>0</sync-rootid><sync-itemtype>0</sync-itemtype><sync-timestamp>1/1 / Text5: 0/2005 9:26:11 AM</sync-timestamp><sync-itemid>1310</sync-itemid><sync-prioritymapping>0:0-0/1:700-1000/2:300-699/3:1-299</sync-prioritymapping>
- 103: Text3: <sync-guid>{94BC0D1E-C5B1-4F43-A8D7-20AC60D3C9C4}</sync-guid><sync-parentguid>{C869DD90-8F31-4C08-9A36-F9086CC4A9F6}</sync-parentguid><sync-checksum>163974990</sync-checksum><sync-rootid>0</sync-rootid><sync-itemtype>0</sync-itemtype><sync-timestamp>1/10 / Text5: 2005 9:26:11 AM</sync-timestamp><sync-itemid>1309</sync-itemid><sync-prioritymapping>0:0-0/1:700-1000/2:300-699/3:1-299</sync-prioritymapping>
- 104: Text3: <sync-guid>{ACEBA1EB-FEE6-4742-805A-677DC8404C38}</sync-guid><sync-parentguid>{C869DD90-8F31-4C08-9A36-F9086CC4A9F6}</sync-parentguid><sync-checksum>1248119034</sync-checksum><sync-rootid>0</sync-rootid><sync-itemtype>0</sync-itemtype><sync-timestamp>1/10 / Text5: 2005 9:26:11 AM</sync-timestamp><sync-itemid>1308</sync-itemid><sync-prioritymapping>0:0-0/1:700-1000/2:300-699/3:1-299</sync-prioritymapping>
- 105: Text3: <sync-guid>{044B9A68-7A9E-422B-8513-1DA621CEFB9A}</sync-guid><sync-parentguid>{C869DD90-8F31-4C08-9A36-F9086CC4A9F6}</sync-parentguid><sync-checksum>-1159653197</sync-checksum><sync-rootid>0</sync-rootid><sync-itemtype>0</sync-itemtype><sync-timestamp>1/1 / Text5: 0/2005 9:26:12 AM</sync-timestamp><sync-itemid>1307</sync-itemid><sync-prioritymapping>0:0-0/1:700-1000/2:300-699/3:1-299</sync-prioritymapping>
- 106: Text3: <sync-guid>{495F7E73-DAA4-4863-A4DD-19C8533EFEEC}</sync-guid><sync-parentguid>{C869DD90-8F31-4C08-9A36-F9086CC4A9F6}</sync-parentguid><sync-checksum>-1430531296</sync-checksum><sync-rootid>0</sync-rootid><sync-itemtype>0</sync-itemtype><sync-timestamp>1/1 / Text5: 0/2005 9:26:12 AM</sync-timestamp><sync-itemid>1306</sync-itemid><sync-prioritymapping>0:0-0/1:700-1000/2:300-699/3:1-299</sync-prioritymapping>
- 107: Text3: <sync-guid>{EADE7F8A-7008-4476-BCD5-B05174487B05}</sync-guid><sync-parentguid>{C869DD90-8F31-4C08-9A36-F9086CC4A9F6}</sync-parentguid><sync-checksum>1312513149</sync-checksum><sync-rootid>0</sync-rootid><sync-itemtype>0</sync-itemtype><sync-timestamp>1/10 / Text5: 2005 9:26:12 AM</sync-timestamp><sync-itemid>1305</sync-itemid><sync-prioritymapping>0:0-0/1:700-1000/2:300-699/3:1-299</sync-prioritymapping>
- 108: Text3: <sync-guid>{780B3AD3-6C0F-4EAC-ABA1-467ED1CF6237}</sync-guid><sync-parentguid>{C869DD90-8F31-4C08-9A36-F9086CC4A9F6}</sync-parentguid><sync-checksum>-1807034227</sync-checksum><sync-rootid>0</sync-rootid><sync-itemtype>0</sync-itemtype><sync-timestamp>1/1 / Text5: 0/2005 9:26:12 AM</sync-timestamp><sync-itemid>1304</sync-itemid><sync-prioritymapping>0:0-0/1:700-1000/2:300-699/3:1-299</sync-prioritymapping>
- 109: Text3: <sync-guid>{368F0B3F-6350-46A9-B427-AABFED99894C}</sync-guid><sync-parentguid>{C869DD90-8F31-4C08-9A36-F9086CC4A9F6}</sync-parentguid><sync-checksum>593910098</sync-checksum><sync-rootid>0</sync-rootid><sync-itemtype>0</sync-itemtype><sync-timestamp>1/10 / Text5: 2005 9:26:12 AM</sync-timestamp><sync-itemid>1303</sync-itemid><sync-prioritymapping>0:0-0/1:700-1000/2:300-699/3:1-299</sync-prioritymapping>

| ID | WBS | Task | Type | Duration | Start | Finish | Predecessors | Baseline start | Baseline finish | Baseline duration | Total slack | Free slack | Text4 |
| --- | --- | --- | --- | --- | --- | --- | --- | --- | --- | --- | --- | --- | --- |
| 110 | 2.8 | **Collect on-going data (continuing)** |  | 60d | 2005-03-17 | 2005-06-08 | 93 | 2005-03-17 | 2005-06-08 | 60d | 54d |  | {506996CE-D86E-4936-90E8-A56E2E654675} |
| 111 | 2.8.1 | Log continuing data points |  | 60d | 2005-03-17 | 2005-06-08 |  | 2005-03-17 | 2005-06-08 | 60d | 54d | 0d | {672ABD8B-14F6-480C-B553-49F6FB869994} |
| 112 | 2.8.2 | **Maintain Sigma Score model** |  | 60d | 2005-03-17 | 2005-06-08 | 111SS | 2005-03-17 | 2005-06-08 | 60d | 54d |  | {D0222277-CD4A-4809-8DE9-0314CF0912F2} |
| 113 | 2.8.2.1 | Consolidate collected data |  | 60d | 2005-03-17 | 2005-06-08 |  | 2005-03-17 | 2005-06-08 | 60d | 54d |  | {A3D21837-A18F-4B97-97A3-67E789D17F33} |
| 114 | 2.8.2.2 | Rationalize DPU & DPMO metrics |  | 60d | 2005-03-17 | 2005-06-08 |  | 2005-03-17 | 2005-06-08 | 60d | 54d |  | {3FCC9AD5-480E-4F41-A1F0-633D898B0491} |
| 115 | 2.8.2.3 | Maintain Sigma Score calculations |  | 60d | 2005-03-17 | 2005-06-08 |  | 2005-03-17 | 2005-06-08 | 60d | 54d |  | {C5A5FEEC-39C2-4D0B-8467-E4013E0039F9} |
| 116 | 2.9 | **Update project charter & plan** |  | 4d | 2005-03-17 | 2005-03-22 | 93 | 2005-03-17 | 2005-03-22 | 4d | 108d | 0d | {98DC83A3-E19C-4D75-884B-96FE2568261D} |
| 117 | 2.9.1 | Review project status and milestones |  | 1d | 2005-03-17 | 2005-03-17 |  | 2005-03-17 | 2005-03-17 | 1d | 108d | 0d | {A5A2659F-7ACD-4A07-85BF-B3CF9A1EE01E} |
| 118 | 2.9.2 | Revise Project Charter & Plan |  | 1d | 2005-03-18 | 2005-03-18 | 117 | 2005-03-18 | 2005-03-18 | 1d | 108d | 0d | {4B6E9F57-1A87-427B-90E4-9532B3E9C885} |
| 119 | 2.9.3 | Review charter & plan with stakeholders |  | 1d | 2005-03-21 | 2005-03-21 | 118 | 2005-03-21 | 2005-03-21 | 1d | 108d | 0d | {BECD30B2-E806-4D06-8895-3210CF60E86A} |
| 120 | 2.9.4 | Finalize charter & plan revisions |  | 1d | 2005-03-22 | 2005-03-22 | 119 | 2005-03-22 | 2005-03-22 | 1d | 108d | 0d | {BA998AAA-9951-478E-A581-7218F5A412FF} |
| 121 | 2.9.5 | Approve revised charter & plan | milestone | 0d | 2005-03-22 | 2005-03-22 | 120 | 2005-03-22 | 2005-03-22 | 0d | 108d |  | {EC2D5108-85BA-46DA-ABDB-30E7CDCD3958} |
| 122 | 2.10 | **Conduct phase QA assessment** |  | 2d | 2005-03-23 | 2005-03-24 | 116 | 2005-03-23 | 2005-03-24 | 2d | 108d |  | {467D50EE-3483-442D-846F-3BB5D2E08319} |
| 123 | 2.10.1 | Consolidate phase results |  | 0.5d | 2005-03-23 | 2005-03-23 |  | 2005-03-23 | 2005-03-23 | 0.5d | 108d | 0d | {B80A37BE-A602-4C74-A59F-A11F1F1326E0} |
| 124 | 2.10.2 | Conduct phase self-assessment |  | 0.25d | 2005-03-23 | 2005-03-23 | 123 | 2005-03-23 | 2005-03-23 | 0.25d | 108d | 0d | {92DC062C-B777-4D66-8462-1335D054366C} |
| 125 | 2.10.3 | Conduct QA assessment |  | 0.5d | 2005-03-23 | 2005-03-24 | 124 | 2005-03-23 | 2005-03-24 | 0.5d | 108d | 0d | {4E9C9466-D2BB-43E6-AEF4-728EC321E15F} |
| 126 | 2.10.4 | Review assessment feedback |  | 0.25d | 2005-03-24 | 2005-03-24 | 125 | 2005-03-24 | 2005-03-24 | 0.25d | 108d | 0d | {249BA57D-FD07-45D1-AA4F-180E1068D4FC} |
| 127 | 2.10.5 | Implement QA feedback |  | 0.5d | 2005-03-24 | 2005-03-24 | 126 | 2005-03-24 | 2005-03-24 | 0.5d | 108d |  | {A70A0996-BBF2-4FE1-A04C-A63675DF74D2} |
| 128 | 3 | **ANALYZE** |  | 24d | 2005-03-04 | 2005-04-07 | 77 | 2005-03-04 | 2005-04-07 | 24d | 0d |  | {3BB6EDFE-B7C6-4273-B4A8-9796E66EA13B} |
| 129 | 3.1 | **Develop process details** |  | 6d | 2005-03-04 | 2005-03-14 |  | 2005-03-04 | 2005-03-14 | 6d | 0d |  | {982A1160-C03C-44A1-B3E5-98834DDE924E} |
| 130 | 3.1.1 | Build QFD Process-Failure Matrix |  | 1d | 2005-03-04 | 2005-03-07 |  | 2005-03-04 | 2005-03-07 | 1d | 0d |  | {4A2FDC62-358A-4599-97BB-6CE3DDC9F595} |
| 131 | 3.1.2 | Define Detail Process Map |  | 1d | 2005-03-07 | 2005-03-08 | 130 | 2005-03-07 | 2005-03-08 | 1d | 0d |  | {A7AC1FE3-08F4-4889-91E1-83FEDFEE0C06} |
| 132 | 3.1.3 | Develop project process changes |  | 1d | 2005-03-08 | 2005-03-09 | 131 | 2005-03-08 | 2005-03-09 | 1d | 0d |  | {07A3DC83-F2E5-443B-B137-22EFBCB6BDA4} |
| 133 | 3.1.4 | Circulate process maps for review |  | 1d | 2005-03-09 | 2005-03-10 | 132 | 2005-03-09 | 2005-03-10 | 1d | 12d | 0d | {1A43E3BB-D238-410E-BA17-0538D90C9432} |
| 134 | 3.1.5 | Review process changes with stakholders |  | 1d | 2005-03-10 | 2005-03-11 | 133 | 2005-03-10 | 2005-03-11 | 1d | 12d | 0d | {73950484-C2B5-464B-89DB-3A46B6449B99} |
| 135 | 3.1.6 | Revise process maps from feedback |  | 1d | 2005-03-11 | 2005-03-14 | 134 | 2005-03-11 | 2005-03-14 | 1d | 12d |  | {854E6301-4110-4EAA-B759-96F85DD7BA19} |

Notes:
- 110: Text3: <sync-guid>{506996CE-D86E-4936-90E8-A56E2E654675}</sync-guid><sync-parentguid>{BB7CE42F-0C67-46DF-8685-BDA8257FDD3A}</sync-parentguid><sync-checksum>-1937594348</sync-checksum><sync-rootid>0</sync-rootid><sync-itemtype>0</sync-itemtype><sync-timestamp>12 / Text5: 30/2004 1:12:11 PM</sync-timestamp><sync-itemid>498</sync-itemid><sync-prioritymapping>0:0-0/1:700-1000/2:300-699/3:1-299</sync-prioritymapping>
- 111: Text3: <sync-guid>{672ABD8B-14F6-480C-B553-49F6FB869994}</sync-guid><sync-parentguid>{506996CE-D86E-4936-90E8-A56E2E654675}</sync-parentguid><sync-checksum>-2072599360</sync-checksum><sync-rootid>0</sync-rootid><sync-itemtype>0</sync-itemtype><sync-timestamp>12 / Text5: 30/2004 1:12:10 PM</sync-timestamp><sync-itemid>497</sync-itemid><sync-prioritymapping>0:0-0/1:700-1000/2:300-699/3:1-299</sync-prioritymapping>
- 112: Text3: <sync-guid>{D0222277-CD4A-4809-8DE9-0314CF0912F2}</sync-guid><sync-parentguid>{506996CE-D86E-4936-90E8-A56E2E654675}</sync-parentguid><sync-checksum>190803969</sync-checksum><sync-rootid>0</sync-rootid><sync-itemtype>0</sync-itemtype><sync-timestamp>12/30 / Text5: 2004 1:12:10 PM</sync-timestamp><sync-itemid>509</sync-itemid><sync-prioritymapping>0:0-0/1:700-1000/2:300-699/3:1-299</sync-prioritymapping>
- 113: Text3: <sync-guid>{A3D21837-A18F-4B97-97A3-67E789D17F33}</sync-guid><sync-parentguid>{D0222277-CD4A-4809-8DE9-0314CF0912F2}</sync-parentguid><sync-checksum>-1575404795</sync-checksum><sync-rootid>0</sync-rootid><sync-itemtype>0</sync-itemtype><sync-timestamp>12 / Text5: 30/2004 1:12:10 PM</sync-timestamp><sync-itemid>508</sync-itemid><sync-prioritymapping>0:0-0/1:700-1000/2:300-699/3:1-299</sync-prioritymapping>
- 114: Text3: <sync-guid>{3FCC9AD5-480E-4F41-A1F0-633D898B0491}</sync-guid><sync-parentguid>{D0222277-CD4A-4809-8DE9-0314CF0912F2}</sync-parentguid><sync-checksum>-894222533</sync-checksum><sync-rootid>0</sync-rootid><sync-itemtype>0</sync-itemtype><sync-timestamp>12/3 / Text5: 0/2004 1:12:10 PM</sync-timestamp><sync-itemid>507</sync-itemid><sync-prioritymapping>0:0-0/1:700-1000/2:300-699/3:1-299</sync-prioritymapping>
- 115: Text3: <sync-guid>{C5A5FEEC-39C2-4D0B-8467-E4013E0039F9}</sync-guid><sync-parentguid>{D0222277-CD4A-4809-8DE9-0314CF0912F2}</sync-parentguid><sync-checksum>1770764145</sync-checksum><sync-rootid>0</sync-rootid><sync-itemtype>0</sync-itemtype><sync-timestamp>12/3 / Text5: 0/2004 1:12:10 PM</sync-timestamp><sync-itemid>506</sync-itemid><sync-prioritymapping>0:0-0/1:700-1000/2:300-699/3:1-299</sync-prioritymapping>
- 116: Text3: <sync-guid>{98DC83A3-E19C-4D75-884B-96FE2568261D}</sync-guid><sync-parentguid>{BB7CE42F-0C67-46DF-8685-BDA8257FDD3A}</sync-parentguid><sync-checksum>92634953</sync-checksum><sync-rootid>0</sync-rootid><sync-itemtype>0</sync-itemtype><sync-timestamp>12/30 / Text5: 2004 1:12:11 PM</sync-timestamp><sync-itemid>43</sync-itemid><sync-prioritymapping>0:0-0/1:700-1000/2:300-699/3:1-299</sync-prioritymapping>
- 117: Text3: <sync-guid>{A5A2659F-7ACD-4A07-85BF-B3CF9A1EE01E}</sync-guid><sync-parentguid>{98DC83A3-E19C-4D75-884B-96FE2568261D}</sync-parentguid><sync-checksum>2033738820</sync-checksum><sync-rootid>0</sync-rootid><sync-itemtype>0</sync-itemtype><sync-timestamp>12/3 / Text5: 0/2004 1:12:11 PM</sync-timestamp><sync-itemid>42</sync-itemid><sync-prioritymapping>0:0-0/1:700-1000/2:300-699/3:1-299</sync-prioritymapping>
- 118: Text3: <sync-guid>{4B6E9F57-1A87-427B-90E4-9532B3E9C885}</sync-guid><sync-parentguid>{98DC83A3-E19C-4D75-884B-96FE2568261D}</sync-parentguid><sync-checksum>-1095354319</sync-checksum><sync-rootid>0</sync-rootid><sync-itemtype>0</sync-itemtype><sync-timestamp>12 / Text5: 30/2004 1:12:11 PM</sync-timestamp><sync-itemid>41</sync-itemid><sync-prioritymapping>0:0-0/1:700-1000/2:300-699/3:1-299</sync-prioritymapping>
- 119: Text3: <sync-guid>{BECD30B2-E806-4D06-8895-3210CF60E86A}</sync-guid><sync-parentguid>{98DC83A3-E19C-4D75-884B-96FE2568261D}</sync-parentguid><sync-checksum>-947897023</sync-checksum><sync-rootid>0</sync-rootid><sync-itemtype>0</sync-itemtype><sync-timestamp>12/3 / Text5: 0/2004 1:12:11 PM</sync-timestamp><sync-itemid>40</sync-itemid><sync-prioritymapping>0:0-0/1:700-1000/2:300-699/3:1-299</sync-prioritymapping>
- 120: Text3: <sync-guid>{BA998AAA-9951-478E-A581-7218F5A412FF}</sync-guid><sync-parentguid>{98DC83A3-E19C-4D75-884B-96FE2568261D}</sync-parentguid><sync-checksum>-901358334</sync-checksum><sync-rootid>0</sync-rootid><sync-itemtype>0</sync-itemtype><sync-timestamp>12/3 / Text5: 0/2004 1:12:11 PM</sync-timestamp><sync-itemid>39</sync-itemid><sync-prioritymapping>0:0-0/1:700-1000/2:300-699/3:1-299</sync-prioritymapping>
- 121: Text3: <sync-guid>{EC2D5108-85BA-46DA-ABDB-30E7CDCD3958}</sync-guid><sync-parentguid>{98DC83A3-E19C-4D75-884B-96FE2568261D}</sync-parentguid><sync-checksum>576878871</sync-checksum><sync-rootid>0</sync-rootid><sync-itemtype>0</sync-itemtype><sync-timestamp>12/30 / Text5: 2004 1:12:11 PM</sync-timestamp><sync-itemid>38</sync-itemid><sync-prioritymapping>0:0-0/1:700-1000/2:300-699/3:1-299</sync-prioritymapping>
- 122: Text3: <sync-guid>{467D50EE-3483-442D-846F-3BB5D2E08319}</sync-guid><sync-parentguid>{BB7CE42F-0C67-46DF-8685-BDA8257FDD3A}</sync-parentguid><sync-checksum>1765002466</sync-checksum><sync-rootid>0</sync-rootid><sync-itemtype>0</sync-itemtype><sync-timestamp>12/3 / Text5: 0/2004 1:12:12 PM</sync-timestamp><sync-itemid>349</sync-itemid><sync-prioritymapping>0:0-0/1:700-1000/2:300-699/3:1-299</sync-prioritymapping>
- 123: Text3: <sync-guid>{B80A37BE-A602-4C74-A59F-A11F1F1326E0}</sync-guid><sync-parentguid>{467D50EE-3483-442D-846F-3BB5D2E08319}</sync-parentguid><sync-checksum>740637724</sync-checksum><sync-rootid>0</sync-rootid><sync-itemtype>0</sync-itemtype><sync-timestamp>12/30 / Text5: 2004 1:09:03 PM</sync-timestamp><sync-itemid>1068</sync-itemid><sync-prioritymapping>0:0-0/1:700-1000/2:300-699/3:1-299</sync-prioritymapping>
- 124: Text3: <sync-guid>{92DC062C-B777-4D66-8462-1335D054366C}</sync-guid><sync-parentguid>{467D50EE-3483-442D-846F-3BB5D2E08319}</sync-parentguid><sync-checksum>-57944091</sync-checksum><sync-rootid>0</sync-rootid><sync-itemtype>0</sync-itemtype><sync-timestamp>12/30 / Text5: 2004 1:09:03 PM</sync-timestamp><sync-itemid>1067</sync-itemid><sync-prioritymapping>0:0-0/1:700-1000/2:300-699/3:1-299</sync-prioritymapping>
- 125: Text3: <sync-guid>{4E9C9466-D2BB-43E6-AEF4-728EC321E15F}</sync-guid><sync-parentguid>{467D50EE-3483-442D-846F-3BB5D2E08319}</sync-parentguid><sync-checksum>356024428</sync-checksum><sync-rootid>0</sync-rootid><sync-itemtype>0</sync-itemtype><sync-timestamp>12/30 / Text5: 2004 1:09:03 PM</sync-timestamp><sync-itemid>1066</sync-itemid><sync-prioritymapping>0:0-0/1:700-1000/2:300-699/3:1-299</sync-prioritymapping>
- 126: Text3: <sync-guid>{249BA57D-FD07-45D1-AA4F-180E1068D4FC}</sync-guid><sync-parentguid>{467D50EE-3483-442D-846F-3BB5D2E08319}</sync-parentguid><sync-checksum>-1529841968</sync-checksum><sync-rootid>0</sync-rootid><sync-itemtype>0</sync-itemtype><sync-timestamp>12 / Text5: 30/2004 1:09:03 PM</sync-timestamp><sync-itemid>1065</sync-itemid><sync-prioritymapping>0:0-0/1:700-1000/2:300-699/3:1-299</sync-prioritymapping>
- 127: Text3: <sync-guid>{A70A0996-BBF2-4FE1-A04C-A63675DF74D2}</sync-guid><sync-parentguid>{467D50EE-3483-442D-846F-3BB5D2E08319}</sync-parentguid><sync-checksum>1538511970</sync-checksum><sync-rootid>0</sync-rootid><sync-itemtype>0</sync-itemtype><sync-timestamp>12/3 / Text5: 0/2004 1:09:03 PM</sync-timestamp><sync-itemid>1064</sync-itemid><sync-prioritymapping>0:0-0/1:700-1000/2:300-699/3:1-299</sync-prioritymapping>
- 128: Text3: <sync-guid>{3BB6EDFE-B7C6-4273-B4A8-9796E66EA13B}</sync-guid><sync-parentguid>{69CAB05D-8790-4A69-A093-1D8EDB5A2679}</sync-parentguid><sync-checksum>-88103165</sync-checksum><sync-rootid>0</sync-rootid><sync-itemtype>0</sync-itemtype><sync-timestamp>12/30 / Text5: 2004 1:12:18 PM</sync-timestamp><sync-itemid>8</sync-itemid><sync-prioritymapping>0:0-0/1:700-1000/2:300-699/3:1-299</sync-prioritymapping>
- 129: Text3: <sync-guid>{982A1160-C03C-44A1-B3E5-98834DDE924E}</sync-guid><sync-parentguid>{3BB6EDFE-B7C6-4273-B4A8-9796E66EA13B}</sync-parentguid><sync-checksum>322198641</sync-checksum><sync-rootid>0</sync-rootid><sync-itemtype>0</sync-itemtype><sync-timestamp>12/30 / Text5: 2004 1:12:12 PM</sync-timestamp><sync-itemid>122</sync-itemid><sync-prioritymapping>0:0-0/1:700-1000/2:300-699/3:1-299</sync-prioritymapping>
- 130: Text3: <sync-guid>{4A2FDC62-358A-4599-97BB-6CE3DDC9F595}</sync-guid><sync-parentguid>{982A1160-C03C-44A1-B3E5-98834DDE924E}</sync-parentguid><sync-checksum>-1312740353</sync-checksum><sync-rootid>0</sync-rootid><sync-itemtype>0</sync-itemtype><sync-timestamp>12 / Text5: 30/2004 1:12:12 PM</sync-timestamp><sync-itemid>121</sync-itemid><sync-prioritymapping>0:0-0/1:700-1000/2:300-699/3:1-299</sync-prioritymapping>
- 131: Text3: <sync-guid>{A7AC1FE3-08F4-4889-91E1-83FEDFEE0C06}</sync-guid><sync-parentguid>{982A1160-C03C-44A1-B3E5-98834DDE924E}</sync-parentguid><sync-checksum>-1631606674</sync-checksum><sync-rootid>0</sync-rootid><sync-itemtype>0</sync-itemtype><sync-timestamp>12 / Text5: 30/2004 1:12:12 PM</sync-timestamp><sync-itemid>120</sync-itemid><sync-prioritymapping>0:0-0/1:700-1000/2:300-699/3:1-299</sync-prioritymapping>
- 132: Text3: <sync-guid>{07A3DC83-F2E5-443B-B137-22EFBCB6BDA4}</sync-guid><sync-parentguid>{982A1160-C03C-44A1-B3E5-98834DDE924E}</sync-parentguid><sync-checksum>-661642526</sync-checksum><sync-rootid>0</sync-rootid><sync-itemtype>0</sync-itemtype><sync-timestamp>12/3 / Text5: 0/2004 1:12:12 PM</sync-timestamp><sync-itemid>118</sync-itemid><sync-prioritymapping>0:0-0/1:700-1000/2:300-699/3:1-299</sync-prioritymapping>
- 133: Text3: <sync-guid>{1A43E3BB-D238-410E-BA17-0538D90C9432}</sync-guid><sync-parentguid>{982A1160-C03C-44A1-B3E5-98834DDE924E}</sync-parentguid><sync-checksum>-996499685</sync-checksum><sync-rootid>0</sync-rootid><sync-itemtype>0</sync-itemtype><sync-timestamp>12/3 / Text5: 0/2004 1:12:12 PM</sync-timestamp><sync-itemid>117</sync-itemid><sync-prioritymapping>0:0-0/1:700-1000/2:300-699/3:1-299</sync-prioritymapping>
- 134: Text3: <sync-guid>{73950484-C2B5-464B-89DB-3A46B6449B99}</sync-guid><sync-parentguid>{982A1160-C03C-44A1-B3E5-98834DDE924E}</sync-parentguid><sync-checksum>-773031539</sync-checksum><sync-rootid>0</sync-rootid><sync-itemtype>0</sync-itemtype><sync-timestamp>12/3 / Text5: 0/2004 1:12:12 PM</sync-timestamp><sync-itemid>116</sync-itemid><sync-prioritymapping>0:0-0/1:700-1000/2:300-699/3:1-299</sync-prioritymapping>
- 135: Text3: <sync-guid>{854E6301-4110-4EAA-B759-96F85DD7BA19}</sync-guid><sync-parentguid>{982A1160-C03C-44A1-B3E5-98834DDE924E}</sync-parentguid><sync-checksum>123290827</sync-checksum><sync-rootid>0</sync-rootid><sync-itemtype>0</sync-itemtype><sync-timestamp>12/30 / Text5: 2004 1:12:12 PM</sync-timestamp><sync-itemid>115</sync-itemid><sync-prioritymapping>0:0-0/1:700-1000/2:300-699/3:1-299</sync-prioritymapping>

| ID | WBS | Task | Duration | Start | Finish | Predecessors | Baseline start | Baseline finish | Baseline duration | Total slack | Free slack | Text4 |
| --- | --- | --- | --- | --- | --- | --- | --- | --- | --- | --- | --- | --- |
| 136 | 3.2 | **Develop functional models** | 4d | 2005-03-09 | 2005-03-15 | 132 | 2005-03-09 | 2005-03-15 | 4d | 0d |  | {A351580D-D002-44B8-B50D-E5527A9FEB89} |
| 137 | 3.2.1 | Identify process component interactions | 1d | 2005-03-09 | 2005-03-10 |  | 2005-03-09 | 2005-03-10 | 1d | 0d |  | {7FC72F4E-4676-4565-9D74-F2C5A3377131} |
| 138 | 3.2.2 | Define initial Function Maps v0.1 | 1d | 2005-03-10 | 2005-03-11 | 137 | 2005-03-10 | 2005-03-11 | 1d | 0d |  | {D080B397-E16D-4A45-81EC-D44986B90C5C} |
| 139 | 3.2.3 | Review maps with stakeholders | 1d | 2005-03-11 | 2005-03-14 | 138 | 2005-03-11 | 2005-03-14 | 1d | 0d |  | {B5E315FA-7040-40E9-95EC-6E8EF17CFC89} |
| 140 | 3.2.4 | Revise function maps from feedback | 1d | 2005-03-14 | 2005-03-15 | 139 | 2005-03-14 | 2005-03-15 | 1d | 17d |  | {CF22311E-20C8-47FB-AEC4-5E462FB56A87} |
| 141 | 3.3 | **Anlayze process failures** | 6d | 2005-03-09 | 2005-03-17 | 132 | 2005-03-09 | 2005-03-17 | 6d | 3d |  | {92D90DED-FBCF-48A3-A01E-183B09E5092F} |
| 142 | 3.3.1 | Review project process flows | 1d | 2005-03-09 | 2005-03-10 |  | 2005-03-09 | 2005-03-10 | 1d | 3d | 0d | {CDB91886-53A1-42F8-9EC0-F6A47CF49D8E} |
| 143 | 3.3.2 | Review process failure modes | 1d | 2005-03-10 | 2005-03-11 | 142 | 2005-03-10 | 2005-03-11 | 1d | 3d | 0d | {4DA04239-D9FF-448D-A526-39CD4B0CF39C} |
| 144 | 3.3.3 | Conduct causal analysis | 1d | 2005-03-11 | 2005-03-14 | 143 | 2005-03-11 | 2005-03-14 | 1d | 3d | 0d | {CD5045D8-F609-4618-8584-7483DF2F0CDA} |
| 145 | 3.3.4 | Build Process FMEA v0.1 | 1d | 2005-03-14 | 2005-03-15 | 144 | 2005-03-14 | 2005-03-15 | 1d | 3d | 0d | {B653D61C-F87B-41E9-A768-88C61734ABF7} |
| 146 | 3.3.5 | Circulate FMEAs for review | 1d | 2005-03-15 | 2005-03-16 | 145 | 2005-03-15 | 2005-03-16 | 1d | 3d | 0d | {01D6B3D1-63B7-4125-8A3F-C32921AAB5E6} |
| 147 | 3.3.6 | Revise FMEAs from feedback | 1d | 2005-03-16 | 2005-03-17 | 146 | 2005-03-16 | 2005-03-17 | 1d | 3d |  | {D92FFAD0-32B3-4E7E-B6EE-A35C74B8D269} |
| 148 | 3.4 | **Analyze functional failures** | 6d | 2005-03-14 | 2005-03-22 | 139 | 2005-03-14 | 2005-03-22 | 6d | 0d |  | {3C69F133-EE62-4FD3-803D-1A9958AB19B0} |
| 149 | 3.4.1 | Review functional flows & interactioins | 1d | 2005-03-14 | 2005-03-15 |  | 2005-03-14 | 2005-03-15 | 1d | 0d |  | {77832B34-8C39-4AA5-949B-3965DDA885F9} |
| 150 | 3.4.2 | Review functional failure modes | 1d | 2005-03-15 | 2005-03-16 | 149 | 2005-03-15 | 2005-03-16 | 1d | 0d |  | {85DF0C28-EA1F-4981-973F-1D8DD1CD3C6D} |
| 151 | 3.4.3 | Conduct causal analysis | 1d | 2005-03-16 | 2005-03-17 | 150 | 2005-03-16 | 2005-03-17 | 1d | 0d |  | {246430C4-426F-49F0-B359-9CC80B86F751} |
| 152 | 3.4.4 | Build Design FMEA v0.1 | 1d | 2005-03-17 | 2005-03-18 | 151 | 2005-03-17 | 2005-03-18 | 1d | 0d |  | {CAA76066-4F42-4CDA-9087-984FE1D48942} |
| 153 | 3.4.5 | Circulate FMEAs for review | 1d | 2005-03-18 | 2005-03-21 | 152 | 2005-03-18 | 2005-03-21 | 1d | 0d |  | {5D676BAF-05B9-43DE-8C2C-120AC8B1DA46} |
| 154 | 3.4.6 | Revise FMEAs from feedback | 1d | 2005-03-21 | 2005-03-22 | 153 | 2005-03-21 | 2005-03-22 | 1d | 0d |  | {FBD90BE4-03E5-4229-A4E8-08446BBB8008} |
| 155 | 3.5 | **Consolidate functional analysis** | 7d | 2005-03-22 | 2005-03-31 | 141, 148 | 2005-03-22 | 2005-03-31 | 7d | 0d |  | {2E35A6F0-2095-4258-9787-CF6AE9ACFF5D} |
| 156 | 3.5.1 | Finalize detail process Maps | 1d | 2005-03-22 | 2005-03-23 |  | 2005-03-22 | 2005-03-23 | 1d | 0d |  | {CF981FCD-9E09-4663-87E3-411ABDDBA2B7} |
| 157 | 3.5.2 | Finalize Function Maps | 1d | 2005-03-23 | 2005-03-24 | 156 | 2005-03-23 | 2005-03-24 | 1d | 0d |  | {156DCC1D-BBB2-46BA-94B9-3E9E0E5B2F4A} |
| 158 | 3.5.3 | Verify controls above RPN threshold | 1d | 2005-03-24 | 2005-03-25 | 157 | 2005-03-24 | 2005-03-25 | 1d | 0d |  | {2AC69CFB-2551-4DA7-8E33-45032B0DE06C} |
| 159 | 3.5.4 | Update QFD1 v0.2 | 1d | 2005-03-25 | 2005-03-28 | 158 | 2005-03-25 | 2005-03-28 | 1d | 0d |  | {1924EF74-7B69-4AF5-BF6A-7689652EE75B} |
| 160 | 3.5.5 | Initialize QFD2 v0.1 | 1d | 2005-03-28 | 2005-03-29 | 159 | 2005-03-28 | 2005-03-29 | 1d | 0d |  | {79E31455-6FC7-465B-88B1-C05123B75077} |
| 161 | 3.5.6 | Review analysis model with stakeholders | 1d | 2005-03-29 | 2005-03-30 | 160 | 2005-03-29 | 2005-03-30 | 1d | 0d |  | {F56BDB7B-2691-4F67-9286-BA9E2CD421FE} |
| 162 | 3.5.7 | Revise models using feedback | 1d | 2005-03-30 | 2005-03-31 | 161 | 2005-03-30 | 2005-03-31 | 1d | 0d |  | {9682B79C-1EE6-4C6D-8B07-977581E9D474} |

Notes:
- 136: Text3: <sync-guid>{A351580D-D002-44B8-B50D-E5527A9FEB89}</sync-guid><sync-parentguid>{3BB6EDFE-B7C6-4273-B4A8-9796E66EA13B}</sync-parentguid><sync-checksum>1199816238</sync-checksum><sync-rootid>0</sync-rootid><sync-itemtype>0</sync-itemtype><sync-timestamp>12/3 / Text5: 0/2004 1:12:13 PM</sync-timestamp><sync-itemid>522</sync-itemid><sync-prioritymapping>0:0-0/1:700-1000/2:300-699/3:1-299</sync-prioritymapping>
- 137: Text3: <sync-guid>{7FC72F4E-4676-4565-9D74-F2C5A3377131}</sync-guid><sync-parentguid>{A351580D-D002-44B8-B50D-E5527A9FEB89}</sync-parentguid><sync-checksum>2092840648</sync-checksum><sync-rootid>0</sync-rootid><sync-itemtype>0</sync-itemtype><sync-timestamp>12/3 / Text5: 0/2004 1:12:13 PM</sync-timestamp><sync-itemid>525</sync-itemid><sync-prioritymapping>0:0-0/1:700-1000/2:300-699/3:1-299</sync-prioritymapping>
- 138: Text3: <sync-guid>{D080B397-E16D-4A45-81EC-D44986B90C5C}</sync-guid><sync-parentguid>{A351580D-D002-44B8-B50D-E5527A9FEB89}</sync-parentguid><sync-checksum>-960932093</sync-checksum><sync-rootid>0</sync-rootid><sync-itemtype>0</sync-itemtype><sync-timestamp>12/3 / Text5: 0/2004 1:12:13 PM</sync-timestamp><sync-itemid>524</sync-itemid><sync-prioritymapping>0:0-0/1:700-1000/2:300-699/3:1-299</sync-prioritymapping>
- 139: Text3: <sync-guid>{B5E315FA-7040-40E9-95EC-6E8EF17CFC89}</sync-guid><sync-parentguid>{A351580D-D002-44B8-B50D-E5527A9FEB89}</sync-parentguid><sync-checksum>203500446</sync-checksum><sync-rootid>0</sync-rootid><sync-itemtype>0</sync-itemtype><sync-timestamp>12/30 / Text5: 2004 1:12:13 PM</sync-timestamp><sync-itemid>528</sync-itemid><sync-prioritymapping>0:0-0/1:700-1000/2:300-699/3:1-299</sync-prioritymapping>
- 140: Text3: <sync-guid>{CF22311E-20C8-47FB-AEC4-5E462FB56A87}</sync-guid><sync-parentguid>{A351580D-D002-44B8-B50D-E5527A9FEB89}</sync-parentguid><sync-checksum>-1566603778</sync-checksum><sync-rootid>0</sync-rootid><sync-itemtype>0</sync-itemtype><sync-timestamp>12 / Text5: 30/2004 1:12:13 PM</sync-timestamp><sync-itemid>527</sync-itemid><sync-prioritymapping>0:0-0/1:700-1000/2:300-699/3:1-299</sync-prioritymapping>
- 141: Text3: <sync-guid>{92D90DED-FBCF-48A3-A01E-183B09E5092F}</sync-guid><sync-parentguid>{3BB6EDFE-B7C6-4273-B4A8-9796E66EA13B}</sync-parentguid><sync-checksum>-1723801632</sync-checksum><sync-rootid>0</sync-rootid><sync-itemtype>0</sync-itemtype><sync-timestamp>12 / Text5: 30/2004 1:12:14 PM</sync-timestamp><sync-itemid>537</sync-itemid><sync-prioritymapping>0:0-0/1:700-1000/2:300-699/3:1-299</sync-prioritymapping>
- 142: Text3: <sync-guid>{CDB91886-53A1-42F8-9EC0-F6A47CF49D8E}</sync-guid><sync-parentguid>{92D90DED-FBCF-48A3-A01E-183B09E5092F}</sync-parentguid><sync-checksum>-1227739265</sync-checksum><sync-rootid>0</sync-rootid><sync-itemtype>0</sync-itemtype><sync-timestamp>12 / Text5: 30/2004 1:12:13 PM</sync-timestamp><sync-itemid>534</sync-itemid><sync-prioritymapping>0:0-0/1:700-1000/2:300-699/3:1-299</sync-prioritymapping>
- 143: Text3: <sync-guid>{4DA04239-D9FF-448D-A526-39CD4B0CF39C}</sync-guid><sync-parentguid>{92D90DED-FBCF-48A3-A01E-183B09E5092F}</sync-parentguid><sync-checksum>-1341971424</sync-checksum><sync-rootid>0</sync-rootid><sync-itemtype>0</sync-itemtype><sync-timestamp>12 / Text5: 30/2004 1:12:13 PM</sync-timestamp><sync-itemid>533</sync-itemid><sync-prioritymapping>0:0-0/1:700-1000/2:300-699/3:1-299</sync-prioritymapping>
- 144: Text3: <sync-guid>{CD5045D8-F609-4618-8584-7483DF2F0CDA}</sync-guid><sync-parentguid>{92D90DED-FBCF-48A3-A01E-183B09E5092F}</sync-parentguid><sync-checksum>138415993</sync-checksum><sync-rootid>0</sync-rootid><sync-itemtype>0</sync-itemtype><sync-timestamp>12/30 / Text5: 2004 1:12:13 PM</sync-timestamp><sync-itemid>532</sync-itemid><sync-prioritymapping>0:0-0/1:700-1000/2:300-699/3:1-299</sync-prioritymapping>
- 145: Text3: <sync-guid>{B653D61C-F87B-41E9-A768-88C61734ABF7}</sync-guid><sync-parentguid>{92D90DED-FBCF-48A3-A01E-183B09E5092F}</sync-parentguid><sync-checksum>2092575402</sync-checksum><sync-rootid>0</sync-rootid><sync-itemtype>0</sync-itemtype><sync-timestamp>12/3 / Text5: 0/2004 1:12:13 PM</sync-timestamp><sync-itemid>531</sync-itemid><sync-prioritymapping>0:0-0/1:700-1000/2:300-699/3:1-299</sync-prioritymapping>
- 146: Text3: <sync-guid>{01D6B3D1-63B7-4125-8A3F-C32921AAB5E6}</sync-guid><sync-parentguid>{92D90DED-FBCF-48A3-A01E-183B09E5092F}</sync-parentguid><sync-checksum>828507655</sync-checksum><sync-rootid>0</sync-rootid><sync-itemtype>0</sync-itemtype><sync-timestamp>12/30 / Text5: 2004 1:12:14 PM</sync-timestamp><sync-itemid>530</sync-itemid><sync-prioritymapping>0:0-0/1:700-1000/2:300-699/3:1-299</sync-prioritymapping>
- 147: Text3: <sync-guid>{D92FFAD0-32B3-4E7E-B6EE-A35C74B8D269}</sync-guid><sync-parentguid>{92D90DED-FBCF-48A3-A01E-183B09E5092F}</sync-parentguid><sync-checksum>1369124358</sync-checksum><sync-rootid>0</sync-rootid><sync-itemtype>0</sync-itemtype><sync-timestamp>12/3 / Text5: 0/2004 1:12:14 PM</sync-timestamp><sync-itemid>529</sync-itemid><sync-prioritymapping>0:0-0/1:700-1000/2:300-699/3:1-299</sync-prioritymapping>
- 148: Text3: <sync-guid>{3C69F133-EE62-4FD3-803D-1A9958AB19B0}</sync-guid><sync-parentguid>{3BB6EDFE-B7C6-4273-B4A8-9796E66EA13B}</sync-parentguid><sync-checksum>-1609988616</sync-checksum><sync-rootid>0</sync-rootid><sync-itemtype>0</sync-itemtype><sync-timestamp>12 / Text5: 30/2004 1:12:15 PM</sync-timestamp><sync-itemid>526</sync-itemid><sync-prioritymapping>0:0-0/1:700-1000/2:300-699/3:1-299</sync-prioritymapping>
- 149: Text3: <sync-guid>{77832B34-8C39-4AA5-949B-3965DDA885F9}</sync-guid><sync-parentguid>{3C69F133-EE62-4FD3-803D-1A9958AB19B0}</sync-parentguid><sync-checksum>-1823745697</sync-checksum><sync-rootid>0</sync-rootid><sync-itemtype>0</sync-itemtype><sync-timestamp>12 / Text5: 30/2004 1:12:14 PM</sync-timestamp><sync-itemid>544</sync-itemid><sync-prioritymapping>0:0-0/1:700-1000/2:300-699/3:1-299</sync-prioritymapping>
- 150: Text3: <sync-guid>{85DF0C28-EA1F-4981-973F-1D8DD1CD3C6D}</sync-guid><sync-parentguid>{3C69F133-EE62-4FD3-803D-1A9958AB19B0}</sync-parentguid><sync-checksum>605684041</sync-checksum><sync-rootid>0</sync-rootid><sync-itemtype>0</sync-itemtype><sync-timestamp>12/30 / Text5: 2004 1:12:14 PM</sync-timestamp><sync-itemid>543</sync-itemid><sync-prioritymapping>0:0-0/1:700-1000/2:300-699/3:1-299</sync-prioritymapping>
- 151: Text3: <sync-guid>{246430C4-426F-49F0-B359-9CC80B86F751}</sync-guid><sync-parentguid>{3C69F133-EE62-4FD3-803D-1A9958AB19B0}</sync-parentguid><sync-checksum>-1634043110</sync-checksum><sync-rootid>0</sync-rootid><sync-itemtype>0</sync-itemtype><sync-timestamp>12 / Text5: 30/2004 1:12:14 PM</sync-timestamp><sync-itemid>542</sync-itemid><sync-prioritymapping>0:0-0/1:700-1000/2:300-699/3:1-299</sync-prioritymapping>
- 152: Text3: <sync-guid>{CAA76066-4F42-4CDA-9087-984FE1D48942}</sync-guid><sync-parentguid>{3C69F133-EE62-4FD3-803D-1A9958AB19B0}</sync-parentguid><sync-checksum>-386204041</sync-checksum><sync-rootid>0</sync-rootid><sync-itemtype>0</sync-itemtype><sync-timestamp>12/3 / Text5: 0/2004 1:12:14 PM</sync-timestamp><sync-itemid>541</sync-itemid><sync-prioritymapping>0:0-0/1:700-1000/2:300-699/3:1-299</sync-prioritymapping>
- 153: Text3: <sync-guid>{5D676BAF-05B9-43DE-8C2C-120AC8B1DA46}</sync-guid><sync-parentguid>{3C69F133-EE62-4FD3-803D-1A9958AB19B0}</sync-parentguid><sync-checksum>1315014123</sync-checksum><sync-rootid>0</sync-rootid><sync-itemtype>0</sync-itemtype><sync-timestamp>12/3 / Text5: 0/2004 1:12:14 PM</sync-timestamp><sync-itemid>540</sync-itemid><sync-prioritymapping>0:0-0/1:700-1000/2:300-699/3:1-299</sync-prioritymapping>
- 154: Text3: <sync-guid>{FBD90BE4-03E5-4229-A4E8-08446BBB8008}</sync-guid><sync-parentguid>{3C69F133-EE62-4FD3-803D-1A9958AB19B0}</sync-parentguid><sync-checksum>-290975320</sync-checksum><sync-rootid>0</sync-rootid><sync-itemtype>0</sync-itemtype><sync-timestamp>12/3 / Text5: 0/2004 1:12:15 PM</sync-timestamp><sync-itemid>539</sync-itemid><sync-prioritymapping>0:0-0/1:700-1000/2:300-699/3:1-299</sync-prioritymapping>
- 155: Text3: <sync-guid>{2E35A6F0-2095-4258-9787-CF6AE9ACFF5D}</sync-guid><sync-parentguid>{3BB6EDFE-B7C6-4273-B4A8-9796E66EA13B}</sync-parentguid><sync-checksum>1711039808</sync-checksum><sync-rootid>0</sync-rootid><sync-itemtype>0</sync-itemtype><sync-timestamp>12/3 / Text5: 0/2004 1:12:16 PM</sync-timestamp><sync-itemid>538</sync-itemid><sync-prioritymapping>0:0-0/1:700-1000/2:300-699/3:1-299</sync-prioritymapping>
- 156: Text3: <sync-guid>{CF981FCD-9E09-4663-87E3-411ABDDBA2B7}</sync-guid><sync-parentguid>{2E35A6F0-2095-4258-9787-CF6AE9ACFF5D}</sync-parentguid><sync-checksum>-90087319</sync-checksum><sync-rootid>0</sync-rootid><sync-itemtype>0</sync-itemtype><sync-timestamp>12/30 / Text5: 2004 1:12:15 PM</sync-timestamp><sync-itemid>551</sync-itemid><sync-prioritymapping>0:0-0/1:700-1000/2:300-699/3:1-299</sync-prioritymapping>
- 157: Text3: <sync-guid>{156DCC1D-BBB2-46BA-94B9-3E9E0E5B2F4A}</sync-guid><sync-parentguid>{2E35A6F0-2095-4258-9787-CF6AE9ACFF5D}</sync-parentguid><sync-checksum>-332463722</sync-checksum><sync-rootid>0</sync-rootid><sync-itemtype>0</sync-itemtype><sync-timestamp>12/3 / Text5: 0/2004 1:12:15 PM</sync-timestamp><sync-itemid>550</sync-itemid><sync-prioritymapping>0:0-0/1:700-1000/2:300-699/3:1-299</sync-prioritymapping>
- 158: Text3: <sync-guid>{2AC69CFB-2551-4DA7-8E33-45032B0DE06C}</sync-guid><sync-parentguid>{2E35A6F0-2095-4258-9787-CF6AE9ACFF5D}</sync-parentguid><sync-checksum>-1090339001</sync-checksum><sync-rootid>0</sync-rootid><sync-itemtype>0</sync-itemtype><sync-timestamp>12 / Text5: 30/2004 1:12:15 PM</sync-timestamp><sync-itemid>549</sync-itemid><sync-prioritymapping>0:0-0/1:700-1000/2:300-699/3:1-299</sync-prioritymapping>
- 159: Text3: <sync-guid>{1924EF74-7B69-4AF5-BF6A-7689652EE75B}</sync-guid><sync-parentguid>{2E35A6F0-2095-4258-9787-CF6AE9ACFF5D}</sync-parentguid><sync-checksum>-2078736814</sync-checksum><sync-rootid>0</sync-rootid><sync-itemtype>0</sync-itemtype><sync-timestamp>12 / Text5: 30/2004 1:12:15 PM</sync-timestamp><sync-itemid>548</sync-itemid><sync-prioritymapping>0:0-0/1:700-1000/2:300-699/3:1-299</sync-prioritymapping>
- 160: Text3: <sync-guid>{79E31455-6FC7-465B-88B1-C05123B75077}</sync-guid><sync-parentguid>{2E35A6F0-2095-4258-9787-CF6AE9ACFF5D}</sync-parentguid><sync-checksum>-259378899</sync-checksum><sync-rootid>0</sync-rootid><sync-itemtype>0</sync-itemtype><sync-timestamp>12/3 / Text5: 0/2004 1:12:15 PM</sync-timestamp><sync-itemid>547</sync-itemid><sync-prioritymapping>0:0-0/1:700-1000/2:300-699/3:1-299</sync-prioritymapping>
- 161: Text3: <sync-guid>{F56BDB7B-2691-4F67-9286-BA9E2CD421FE}</sync-guid><sync-parentguid>{2E35A6F0-2095-4258-9787-CF6AE9ACFF5D}</sync-parentguid><sync-checksum>1660460517</sync-checksum><sync-rootid>0</sync-rootid><sync-itemtype>0</sync-itemtype><sync-timestamp>12/3 / Text5: 0/2004 1:12:15 PM</sync-timestamp><sync-itemid>546</sync-itemid><sync-prioritymapping>0:0-0/1:700-1000/2:300-699/3:1-299</sync-prioritymapping>
- 162: Text3: <sync-guid>{9682B79C-1EE6-4C6D-8B07-977581E9D474}</sync-guid><sync-parentguid>{2E35A6F0-2095-4258-9787-CF6AE9ACFF5D}</sync-parentguid><sync-checksum>1359699060</sync-checksum><sync-rootid>0</sync-rootid><sync-itemtype>0</sync-itemtype><sync-timestamp>12/3 / Text5: 0/2004 1:12:15 PM</sync-timestamp><sync-itemid>545</sync-itemid><sync-prioritymapping>0:0-0/1:700-1000/2:300-699/3:1-299</sync-prioritymapping>

| ID | WBS | Task | Type | Duration | Start | Finish | Predecessors | Baseline start | Baseline finish | Baseline duration | Total slack | Free slack | Text4 |
| --- | --- | --- | --- | --- | --- | --- | --- | --- | --- | --- | --- | --- | --- |
| 163 | 3.6 | **Validate analysis results** |  | 5d | 2005-03-31 | 2005-04-07 | 155 | 2005-03-31 | 2005-04-07 | 5d | 0d |  | {858CC886-3019-4364-9E69-E0E2EA55DE94} |
| 164 | 3.6.1 | Consolidate QFD1 & QFD2 with supporting models |  | 1d | 2005-03-31 | 2005-04-01 |  | 2005-03-31 | 2005-04-01 | 1d | 0d |  | {3B68F25E-51F0-45F3-908A-B087B426035F} |
| 165 | 3.6.2 | Conduct consolidated peer review |  | 1d | 2005-04-01 | 2005-04-04 | 164 | 2005-04-01 | 2005-04-04 | 1d | 0d |  | {29D8DB13-3840-4514-808F-DF184096714E} |
| 166 | 3.6.3 | Update SIPOC v0.6 |  | 1d | 2005-04-04 | 2005-04-05 | 165 | 2005-04-04 | 2005-04-05 | 1d | 1d | 0d | {2CD5F61E-12B7-4BA3-875C-5CB71E07180B} |
| 167 | 3.6.4 | Update High-Level PMAP v0.6 |  | 1d | 2005-04-04 | 2005-04-05 | 165 | 2005-04-04 | 2005-04-05 | 1d | 0d |  | {D8B17AE6-7ABF-4C0B-B0E3-09C6385CDAA6} |
| 168 | 3.6.5 | Update C&E Matrix v0.5 |  | 1d | 2005-04-05 | 2005-04-06 | 166, 167 | 2005-04-05 | 2005-04-06 | 1d | 1d |  | {C97A83BA-F6AF-4906-917C-C98F1A8B115D} |
| 169 | 3.6.6 | Update Function Maps |  | 1d | 2005-04-04 | 2005-04-05 | 167SS | 2005-04-04 | 2005-04-05 | 1d | 0d |  | {4B3E8CC7-D91C-43BF-B5D0-B8BAF7A3F302} |
| 170 | 3.6.7 | Update QFD1 v0.3 |  | 1d | 2005-04-04 | 2005-04-05 | 169FF | 2005-04-04 | 2005-04-05 | 1d | 0d |  | {82BF809F-917C-49BB-B269-1E22020C2EF9} |
| 171 | 3.6.8 | Update QFD2 v0.2 |  | 1d | 2005-04-04 | 2005-04-05 | 170FF | 2005-04-04 | 2005-04-05 | 1d | 0d |  | {46813288-BDA2-44A5-963B-3FE803DA2338} |
| 172 | 3.6.9 | Conduct peer review of consolidated models |  | 1d | 2005-04-05 | 2005-04-06 | 170, 171 | 2005-04-05 | 2005-04-06 | 1d | 0d |  | {A16E9BDC-F229-4A3D-8995-33221BDB3453} |
| 173 | 3.6.10 | Apply recommended improvements |  | 1d | 2005-04-06 | 2005-04-07 | 172 | 2005-04-06 | 2005-04-07 | 1d | 0d |  | {1C23AED6-228D-46AC-9471-9C69411025D1} |
| 174 | 3.6.11 | Approve consolidated requirements models | milestone | 0d | 2005-04-07 | 2005-04-07 | 173 | 2005-04-07 | 2005-04-07 | 0d | 0d |  | {83131B67-1A75-4445-86AA-B120EBF138CB} |
| 175 | 3.7 | **Update project charter & plan** |  | 4d | 2005-03-14 | 2005-03-18 | 129 | 2005-03-14 | 2005-03-18 | 4d | 12d | 0d | {2F98B4AE-1466-40A6-AD35-A0C555355B02} |
| 176 | 3.7.1 | Review project status and milestones |  | 1d | 2005-03-14 | 2005-03-15 |  | 2005-03-14 | 2005-03-15 | 1d | 12d | 0d | {E8CF175D-6D7C-40A6-A02C-9461B30D3058} |
| 177 | 3.7.2 | Revise Project Charter & Plan |  | 1d | 2005-03-15 | 2005-03-16 | 176 | 2005-03-15 | 2005-03-16 | 1d | 12d | 0d | {3501C111-BF98-4772-9289-0B0ED747D8C8} |
| 178 | 3.7.3 | Review charter & plan with stakeholders |  | 1d | 2005-03-16 | 2005-03-17 | 177 | 2005-03-16 | 2005-03-17 | 1d | 12d | 0d | {9879BD70-C986-4911-8062-A41C6698B9F9} |
| 179 | 3.7.4 | Finalize charter & plan revisions |  | 1d | 2005-03-17 | 2005-03-18 | 178 | 2005-03-17 | 2005-03-18 | 1d | 12d | 0d | {3257CB08-3C45-462B-A23D-6A282C9FEE56} |
| 180 | 3.7.5 | Approve revised charter & plan | milestone | 0d | 2005-03-18 | 2005-03-18 | 179 | 2005-03-18 | 2005-03-18 | 0d | 12d |  | {6CCA26BF-463A-44E2-A9C1-4BFA6771A561} |
| 181 | 3.8 | **Conduct phase QA assessment** |  | 2d | 2005-03-18 | 2005-03-22 | 175 | 2005-03-18 | 2005-03-22 | 2d | 12d |  | {BCCC0160-F2EF-47D9-9717-D3E74ABD5B4A} |
| 182 | 3.8.1 | Consolidate phase results |  | 0.5d | 2005-03-18 | 2005-03-18 |  | 2005-03-18 | 2005-03-18 | 0.5d | 12d | 0d | {1761717D-2784-47E5-B6DD-1523CC06555C} |
| 183 | 3.8.2 | Conduct phase self-assessment |  | 0.25d | 2005-03-21 | 2005-03-21 | 182 | 2005-03-21 | 2005-03-21 | 0.25d | 12d | 0d | {A3502E2B-5A40-4C63-95EF-5CD1AFA3224F} |
| 184 | 3.8.3 | Conduct QA assessment |  | 0.5d | 2005-03-21 | 2005-03-21 | 183 | 2005-03-21 | 2005-03-21 | 0.5d | 12d | 0d | {222172BC-BF7E-4294-A1DF-7A5F74D2F37B} |
| 185 | 3.8.4 | Review assessment feedback |  | 0.25d | 2005-03-21 | 2005-03-21 | 184 | 2005-03-21 | 2005-03-21 | 0.25d | 12d | 0d | {72FE556C-622E-4CC2-AEE8-B486F8F41255} |
| 186 | 3.8.5 | Implement QA feedback |  | 0.5d | 2005-03-22 | 2005-03-22 | 185 | 2005-03-22 | 2005-03-22 | 0.5d | 12d |  | {5DE755FB-377F-4486-A722-3C3799D11AF9} |

Notes:
- 163: Text3: <sync-guid>{858CC886-3019-4364-9E69-E0E2EA55DE94}</sync-guid><sync-parentguid>{3BB6EDFE-B7C6-4273-B4A8-9796E66EA13B}</sync-parentguid><sync-checksum>1641612861</sync-checksum><sync-rootid>0</sync-rootid><sync-itemtype>0</sync-itemtype><sync-timestamp>12/3 / Text5: 0/2004 1:12:17 PM</sync-timestamp><sync-itemid>512</sync-itemid><sync-prioritymapping>0:0-0/1:700-1000/2:300-699/3:1-299</sync-prioritymapping>
- 164: Text3: <sync-guid>{3B68F25E-51F0-45F3-908A-B087B426035F}</sync-guid><sync-parentguid>{858CC886-3019-4364-9E69-E0E2EA55DE94}</sync-parentguid><sync-checksum>-1347818895</sync-checksum><sync-rootid>0</sync-rootid><sync-itemtype>0</sync-itemtype><sync-timestamp>12 / Text5: 30/2004 1:12:16 PM</sync-timestamp><sync-itemid>521</sync-itemid><sync-prioritymapping>0:0-0/1:700-1000/2:300-699/3:1-299</sync-prioritymapping>
- 165: Text3: <sync-guid>{29D8DB13-3840-4514-808F-DF184096714E}</sync-guid><sync-parentguid>{858CC886-3019-4364-9E69-E0E2EA55DE94}</sync-parentguid><sync-checksum>1059223697</sync-checksum><sync-rootid>0</sync-rootid><sync-itemtype>0</sync-itemtype><sync-timestamp>12/3 / Text5: 0/2004 1:12:16 PM</sync-timestamp><sync-itemid>520</sync-itemid><sync-prioritymapping>0:0-0/1:700-1000/2:300-699/3:1-299</sync-prioritymapping>
- 166: Text3: <sync-guid>{2CD5F61E-12B7-4BA3-875C-5CB71E07180B}</sync-guid><sync-parentguid>{858CC886-3019-4364-9E69-E0E2EA55DE94}</sync-parentguid><sync-checksum>-977731810</sync-checksum><sync-rootid>0</sync-rootid><sync-itemtype>0</sync-itemtype><sync-timestamp>12/3 / Text5: 0/2004 1:12:16 PM</sync-timestamp><sync-itemid>519</sync-itemid><sync-prioritymapping>0:0-0/1:700-1000/2:300-699/3:1-299</sync-prioritymapping>
- 167: Text3: <sync-guid>{D8B17AE6-7ABF-4C0B-B0E3-09C6385CDAA6}</sync-guid><sync-parentguid>{858CC886-3019-4364-9E69-E0E2EA55DE94}</sync-parentguid><sync-checksum>-800279752</sync-checksum><sync-rootid>0</sync-rootid><sync-itemtype>0</sync-itemtype><sync-timestamp>12/3 / Text5: 0/2004 1:12:16 PM</sync-timestamp><sync-itemid>518</sync-itemid><sync-prioritymapping>0:0-0/1:700-1000/2:300-699/3:1-299</sync-prioritymapping>
- 168: Text3: <sync-guid>{C97A83BA-F6AF-4906-917C-C98F1A8B115D}</sync-guid><sync-parentguid>{858CC886-3019-4364-9E69-E0E2EA55DE94}</sync-parentguid><sync-checksum>1685863440</sync-checksum><sync-rootid>0</sync-rootid><sync-itemtype>0</sync-itemtype><sync-timestamp>12/3 / Text5: 0/2004 1:12:16 PM</sync-timestamp><sync-itemid>517</sync-itemid><sync-prioritymapping>0:0-0/1:700-1000/2:300-699/3:1-299</sync-prioritymapping>
- 169: Text3: <sync-guid>{4B3E8CC7-D91C-43BF-B5D0-B8BAF7A3F302}</sync-guid><sync-parentguid>{858CC886-3019-4364-9E69-E0E2EA55DE94}</sync-parentguid><sync-checksum>1963457595</sync-checksum><sync-rootid>0</sync-rootid><sync-itemtype>0</sync-itemtype><sync-timestamp>12/3 / Text5: 0/2004 1:12:16 PM</sync-timestamp><sync-itemid>563</sync-itemid><sync-prioritymapping>0:0-0/1:700-1000/2:300-699/3:1-299</sync-prioritymapping>
- 170: Text3: <sync-guid>{82BF809F-917C-49BB-B269-1E22020C2EF9}</sync-guid><sync-parentguid>{858CC886-3019-4364-9E69-E0E2EA55DE94}</sync-parentguid><sync-checksum>-275643119</sync-checksum><sync-rootid>0</sync-rootid><sync-itemtype>0</sync-itemtype><sync-timestamp>12/3 / Text5: 0/2004 1:12:16 PM</sync-timestamp><sync-itemid>516</sync-itemid><sync-prioritymapping>0:0-0/1:700-1000/2:300-699/3:1-299</sync-prioritymapping>
- 171: Text3: <sync-guid>{46813288-BDA2-44A5-963B-3FE803DA2338}</sync-guid><sync-parentguid>{858CC886-3019-4364-9E69-E0E2EA55DE94}</sync-parentguid><sync-checksum>1261325330</sync-checksum><sync-rootid>0</sync-rootid><sync-itemtype>0</sync-itemtype><sync-timestamp>12/3 / Text5: 0/2004 1:12:17 PM</sync-timestamp><sync-itemid>565</sync-itemid><sync-prioritymapping>0:0-0/1:700-1000/2:300-699/3:1-299</sync-prioritymapping>
- 172: Text3: <sync-guid>{A16E9BDC-F229-4A3D-8995-33221BDB3453}</sync-guid><sync-parentguid>{858CC886-3019-4364-9E69-E0E2EA55DE94}</sync-parentguid><sync-checksum>-1639049884</sync-checksum><sync-rootid>0</sync-rootid><sync-itemtype>0</sync-itemtype><sync-timestamp>12 / Text5: 30/2004 1:12:17 PM</sync-timestamp><sync-itemid>567</sync-itemid><sync-prioritymapping>0:0-0/1:700-1000/2:300-699/3:1-299</sync-prioritymapping>
- 173: Text3: <sync-guid>{1C23AED6-228D-46AC-9471-9C69411025D1}</sync-guid><sync-parentguid>{858CC886-3019-4364-9E69-E0E2EA55DE94}</sync-parentguid><sync-checksum>1558170839</sync-checksum><sync-rootid>0</sync-rootid><sync-itemtype>0</sync-itemtype><sync-timestamp>12/3 / Text5: 0/2004 1:12:17 PM</sync-timestamp><sync-itemid>566</sync-itemid><sync-prioritymapping>0:0-0/1:700-1000/2:300-699/3:1-299</sync-prioritymapping>
- 174: Text3: <sync-guid>{83131B67-1A75-4445-86AA-B120EBF138CB}</sync-guid><sync-parentguid>{858CC886-3019-4364-9E69-E0E2EA55DE94}</sync-parentguid><sync-checksum>378655703</sync-checksum><sync-rootid>0</sync-rootid><sync-itemtype>0</sync-itemtype><sync-timestamp>12/30 / Text5: 2004 1:12:17 PM</sync-timestamp><sync-itemid>515</sync-itemid><sync-prioritymapping>0:0-0/1:700-1000/2:300-699/3:1-299</sync-prioritymapping>
- 175: Text3: <sync-guid>{2F98B4AE-1466-40A6-AD35-A0C555355B02}</sync-guid><sync-parentguid>{3BB6EDFE-B7C6-4273-B4A8-9796E66EA13B}</sync-parentguid><sync-checksum>950386263</sync-checksum><sync-rootid>0</sync-rootid><sync-itemtype>0</sync-itemtype><sync-timestamp>12/30 / Text5: 2004 1:12:18 PM</sync-timestamp><sync-itemid>114</sync-itemid><sync-prioritymapping>0:0-0/1:700-1000/2:300-699/3:1-299</sync-prioritymapping>
- 176: Text3: <sync-guid>{E8CF175D-6D7C-40A6-A02C-9461B30D3058}</sync-guid><sync-parentguid>{2F98B4AE-1466-40A6-AD35-A0C555355B02}</sync-parentguid><sync-checksum>984266513</sync-checksum><sync-rootid>0</sync-rootid><sync-itemtype>0</sync-itemtype><sync-timestamp>12/30 / Text5: 2004 1:12:17 PM</sync-timestamp><sync-itemid>113</sync-itemid><sync-prioritymapping>0:0-0/1:700-1000/2:300-699/3:1-299</sync-prioritymapping>
- 177: Text3: <sync-guid>{3501C111-BF98-4772-9289-0B0ED747D8C8}</sync-guid><sync-parentguid>{2F98B4AE-1466-40A6-AD35-A0C555355B02}</sync-parentguid><sync-checksum>-506008190</sync-checksum><sync-rootid>0</sync-rootid><sync-itemtype>0</sync-itemtype><sync-timestamp>12/3 / Text5: 0/2004 1:12:17 PM</sync-timestamp><sync-itemid>112</sync-itemid><sync-prioritymapping>0:0-0/1:700-1000/2:300-699/3:1-299</sync-prioritymapping>
- 178: Text3: <sync-guid>{9879BD70-C986-4911-8062-A41C6698B9F9}</sync-guid><sync-parentguid>{2F98B4AE-1466-40A6-AD35-A0C555355B02}</sync-parentguid><sync-checksum>254660639</sync-checksum><sync-rootid>0</sync-rootid><sync-itemtype>0</sync-itemtype><sync-timestamp>12/30 / Text5: 2004 1:12:18 PM</sync-timestamp><sync-itemid>111</sync-itemid><sync-prioritymapping>0:0-0/1:700-1000/2:300-699/3:1-299</sync-prioritymapping>
- 179: Text3: <sync-guid>{3257CB08-3C45-462B-A23D-6A282C9FEE56}</sync-guid><sync-parentguid>{2F98B4AE-1466-40A6-AD35-A0C555355B02}</sync-parentguid><sync-checksum>-852522159</sync-checksum><sync-rootid>0</sync-rootid><sync-itemtype>0</sync-itemtype><sync-timestamp>12/3 / Text5: 0/2004 1:12:18 PM</sync-timestamp><sync-itemid>110</sync-itemid><sync-prioritymapping>0:0-0/1:700-1000/2:300-699/3:1-299</sync-prioritymapping>
- 180: Text3: <sync-guid>{6CCA26BF-463A-44E2-A9C1-4BFA6771A561}</sync-guid><sync-parentguid>{2F98B4AE-1466-40A6-AD35-A0C555355B02}</sync-parentguid><sync-checksum>493997305</sync-checksum><sync-rootid>0</sync-rootid><sync-itemtype>0</sync-itemtype><sync-timestamp>12/30 / Text5: 2004 1:12:18 PM</sync-timestamp><sync-itemid>109</sync-itemid><sync-prioritymapping>0:0-0/1:700-1000/2:300-699/3:1-299</sync-prioritymapping>
- 181: Text3: <sync-guid>{BCCC0160-F2EF-47D9-9717-D3E74ABD5B4A}</sync-guid><sync-parentguid>{3BB6EDFE-B7C6-4273-B4A8-9796E66EA13B}</sync-parentguid><sync-checksum>-815632231</sync-checksum><sync-rootid>0</sync-rootid><sync-itemtype>0</sync-itemtype><sync-timestamp>12/3 / Text5: 0/2004 1:12:18 PM</sync-timestamp><sync-itemid>350</sync-itemid><sync-prioritymapping>0:0-0/1:700-1000/2:300-699/3:1-299</sync-prioritymapping>
- 182: Text3: <sync-guid>{1761717D-2784-47E5-B6DD-1523CC06555C}</sync-guid><sync-parentguid>{BCCC0160-F2EF-47D9-9717-D3E74ABD5B4A}</sync-parentguid><sync-checksum>-1458442937</sync-checksum><sync-rootid>0</sync-rootid><sync-itemtype>0</sync-itemtype><sync-timestamp>12 / Text5: 30/2004 1:09:07 PM</sync-timestamp><sync-itemid>1073</sync-itemid><sync-prioritymapping>0:0-0/1:700-1000/2:300-699/3:1-299</sync-prioritymapping>
- 183: Text3: <sync-guid>{A3502E2B-5A40-4C63-95EF-5CD1AFA3224F}</sync-guid><sync-parentguid>{BCCC0160-F2EF-47D9-9717-D3E74ABD5B4A}</sync-parentguid><sync-checksum>-629260298</sync-checksum><sync-rootid>0</sync-rootid><sync-itemtype>0</sync-itemtype><sync-timestamp>12/3 / Text5: 0/2004 1:09:07 PM</sync-timestamp><sync-itemid>1072</sync-itemid><sync-prioritymapping>0:0-0/1:700-1000/2:300-699/3:1-299</sync-prioritymapping>
- 184: Text3: <sync-guid>{222172BC-BF7E-4294-A1DF-7A5F74D2F37B}</sync-guid><sync-parentguid>{BCCC0160-F2EF-47D9-9717-D3E74ABD5B4A}</sync-parentguid><sync-checksum>1196786160</sync-checksum><sync-rootid>0</sync-rootid><sync-itemtype>0</sync-itemtype><sync-timestamp>12/3 / Text5: 0/2004 1:09:07 PM</sync-timestamp><sync-itemid>1071</sync-itemid><sync-prioritymapping>0:0-0/1:700-1000/2:300-699/3:1-299</sync-prioritymapping>
- 185: Text3: <sync-guid>{72FE556C-622E-4CC2-AEE8-B486F8F41255}</sync-guid><sync-parentguid>{BCCC0160-F2EF-47D9-9717-D3E74ABD5B4A}</sync-parentguid><sync-checksum>402248159</sync-checksum><sync-rootid>0</sync-rootid><sync-itemtype>0</sync-itemtype><sync-timestamp>12/30 / Text5: 2004 1:09:07 PM</sync-timestamp><sync-itemid>1070</sync-itemid><sync-prioritymapping>0:0-0/1:700-1000/2:300-699/3:1-299</sync-prioritymapping>
- 186: Text3: <sync-guid>{5DE755FB-377F-4486-A722-3C3799D11AF9}</sync-guid><sync-parentguid>{BCCC0160-F2EF-47D9-9717-D3E74ABD5B4A}</sync-parentguid><sync-checksum>816704599</sync-checksum><sync-rootid>0</sync-rootid><sync-itemtype>0</sync-itemtype><sync-timestamp>12/30 / Text5: 2004 1:09:08 PM</sync-timestamp><sync-itemid>1069</sync-itemid><sync-prioritymapping>0:0-0/1:700-1000/2:300-699/3:1-299</sync-prioritymapping>

| ID | WBS | Task | Type | Duration | Start | Finish | Predecessors | Baseline start | Baseline finish | Baseline duration | Total slack | Free slack | Text4 |
| --- | --- | --- | --- | --- | --- | --- | --- | --- | --- | --- | --- | --- | --- |
| 187 | 4 | **IMPROVE** |  | 67.5d | 2005-04-07 | 2005-07-11 | 128 | 2005-04-07 | 2005-07-11 | 67.5d | 0d |  | {E3661073-A1C8-4E27-B414-D3FD14E50F9A} |
| 188 | 4.1 | **Define final workflows** |  | 6d | 2005-04-07 | 2005-04-15 |  | 2005-04-07 | 2005-04-15 | 6d | 0d |  | {9A3815CB-A629-4F2A-9165-68DCEEFF783B} |
| 189 | 4.1.1 | Map function maps into flows |  | 1d | 2005-04-07 | 2005-04-08 |  | 2005-04-07 | 2005-04-08 | 1d | 0d |  | {03216936-B27E-4CCA-A20E-F9D0AFCF962E} |
| 190 | 4.1.2 | Document workflows by function |  | 3d | 2005-04-08 | 2005-04-13 | 189 | 2005-04-08 | 2005-04-13 | 3d | 0d |  | {6224A4FD-B5CA-4DEC-B0E4-17CACDA85A32} |
| 191 | 4.1.3 | Review workflows with stakeholders |  | 1d | 2005-04-13 | 2005-04-14 | 190 | 2005-04-13 | 2005-04-14 | 1d | 0d |  | {6429E248-A9AF-41F1-933F-584DDA535D71} |
| 192 | 4.1.4 | Revise workflows based on feedback |  | 1d | 2005-04-14 | 2005-04-15 | 191 | 2005-04-14 | 2005-04-15 | 1d | 0d |  | {1A1657FC-4EC0-4CA7-8B06-6960C857CE2F} |
| 193 | 4.2 | **Develop procedures** |  | 12d | 2005-04-15 | 2005-05-03 | 188 | 2005-04-15 | 2005-05-03 | 12d | 0d |  | {EB89A9D0-29CC-4A64-87A3-FA1066C0E670} |
| 194 | 4.2.1 | Define procedures for each workflow step |  | 3d | 2005-04-15 | 2005-04-20 |  | 2005-04-15 | 2005-04-20 | 3d | 0d |  | {2FA3C2A8-6AED-4F85-A601-C86785183623} |
| 195 | 4.2.2 | Document procedures by function |  | 5d | 2005-04-20 | 2005-04-27 | 194 | 2005-04-20 | 2005-04-27 | 5d | 0d |  | {1027595D-1EF8-4D0B-95D7-7A1E0463861E} |
| 196 | 4.2.3 | Conduct peer review of procedures |  | 1d | 2005-04-27 | 2005-04-28 | 195 | 2005-04-27 | 2005-04-28 | 1d | 0d |  | {89D08DCF-755C-4672-A3EB-1E020AF71304} |
| 197 | 4.2.4 | Revise procedures based on peer input |  | 1d | 2005-04-28 | 2005-04-29 | 196 | 2005-04-28 | 2005-04-29 | 1d | 0d |  | {A872C89E-F241-412E-BAFE-926234A12F28} |
| 198 | 4.2.5 | Review procedures with stakeholders |  | 1d | 2005-04-29 | 2005-05-02 | 197 | 2005-04-29 | 2005-05-02 | 1d | 0d |  | {1985C7AF-4EED-443F-BC03-9D9CC66A6DF4} |
| 199 | 4.2.6 | Revise procedures based on feedback |  | 1d | 2005-05-02 | 2005-05-03 | 198 | 2005-05-02 | 2005-05-03 | 1d | 0d |  | {1F750FFC-A944-46B5-A719-A3CDA3A5644F} |
| 200 | 4.2.7 | Obtain approval of procedures | milestone | 0d | 2005-05-03 | 2005-05-03 | 199 | 2005-05-03 | 2005-05-03 | 0d | 6.5d |  | {3AA923AB-134B-4B31-992B-9579A2E38B0D} |
| 201 | 4.3 | **Provide cutover training** |  | 49.5d | 2005-05-03 | 2005-07-11 | 199 | 2005-05-03 | 2005-07-11 | 49.5d | 0d |  | {30AC7D22-4B56-47F1-8BB3-0B5207154E24} |
| 202 | 4.3.1 | Finalize training setup |  | 1d | 2005-05-03 | 2005-05-04 |  | 2005-05-03 | 2005-05-04 | 1d | 0d |  | {AD6890A1-9F8B-4EED-8266-B5F3A11A5335} |
| 203 | 4.3.2 | Conduct training encounters |  | 3d | 2005-05-04 | 2005-05-09 | 202 | 2005-05-04 | 2005-05-09 | 3d | 0d |  | {92B1603E-811F-4FDA-A70E-D4E5D784BAE2} |
| 204 | 4.3.3 | Evaluate training effectiveness |  | 0.5d | 2005-05-09 | 2005-05-09 | 203 | 2005-05-09 | 2005-05-09 | 0.5d | 0d |  | {C3F2B54A-5538-4B31-81CE-63D8DD0EC1FB} |
| 205 | 4.3.4 | Provide transitional support |  | 45d | 2005-05-10 | 2005-07-11 | 204 | 2005-05-10 | 2005-07-11 | 45d | 0d |  | {58A37CFB-26C4-449F-8F6E-82ADD027E194} |
| 206 | 4.4 | **Convert process controls & data** |  | 43d | 2005-05-03 | 2005-07-01 | 193 | 2005-05-03 | 2005-07-01 | 43d | 6.5d |  | {60052436-1561-4669-AEED-32D1E824BF0C} |
| 207 | 4.4.1 | Finalize conversion procedures |  | 1d | 2005-05-03 | 2005-05-04 |  | 2005-05-03 | 2005-05-04 | 1d | 6.5d | 0d | {08819B18-94C9-4B1D-9C3E-B1526AEF9D02} |
| 208 | 4.4.2 | Execute conversion procedures |  | 1d | 2005-05-04 | 2005-05-05 | 207 | 2005-05-04 | 2005-05-05 | 1d | 6.5d | 0d | {348D206F-1CC9-408A-9DB3-06076922750D} |
| 209 | 4.4.3 | Test converted status |  | 1d | 2005-05-05 | 2005-05-06 | 208 | 2005-05-05 | 2005-05-06 | 1d | 6.5d | 0d | {BA7B8D7E-8DEC-4AE6-9C75-73CE2D0A4408} |
| 210 | 4.4.4 | Monitor process controls |  | 40d | 2005-05-06 | 2005-07-01 | 209 | 2005-05-06 | 2005-07-01 | 40d | 6.5d |  | {1E7D6459-8C6C-4D1F-8FA9-DC8859E4EF00} |

Notes:
- 187: Text3: <sync-guid>{E3661073-A1C8-4E27-B414-D3FD14E50F9A}</sync-guid><sync-parentguid>{69CAB05D-8790-4A69-A093-1D8EDB5A2679}</sync-parentguid><sync-checksum>-120761837</sync-checksum><sync-rootid>0</sync-rootid><sync-itemtype>0</sync-itemtype><sync-timestamp>12/3 / Text5: 0/2004 1:12:23 PM</sync-timestamp><sync-itemid>11</sync-itemid><sync-prioritymapping>0:0-0/1:700-1000/2:300-699/3:1-299</sync-prioritymapping>
- 188: Text3: <sync-guid>{9A3815CB-A629-4F2A-9165-68DCEEFF783B}</sync-guid><sync-parentguid>{E3661073-A1C8-4E27-B414-D3FD14E50F9A}</sync-parentguid><sync-checksum>75624215</sync-checksum><sync-rootid>0</sync-rootid><sync-itemtype>0</sync-itemtype><sync-timestamp>12/30 / Text5: 2004 1:12:19 PM</sync-timestamp><sync-itemid>679</sync-itemid><sync-prioritymapping>0:0-0/1:700-1000/2:300-699/3:1-299</sync-prioritymapping>
- 189: Text3: <sync-guid>{03216936-B27E-4CCA-A20E-F9D0AFCF962E}</sync-guid><sync-parentguid>{9A3815CB-A629-4F2A-9165-68DCEEFF783B}</sync-parentguid><sync-checksum>1609539183</sync-checksum><sync-rootid>0</sync-rootid><sync-itemtype>0</sync-itemtype><sync-timestamp>12/3 / Text5: 0/2004 1:12:18 PM</sync-timestamp><sync-itemid>688</sync-itemid><sync-prioritymapping>0:0-0/1:700-1000/2:300-699/3:1-299</sync-prioritymapping>
- 190: Text3: <sync-guid>{6224A4FD-B5CA-4DEC-B0E4-17CACDA85A32}</sync-guid><sync-parentguid>{9A3815CB-A629-4F2A-9165-68DCEEFF783B}</sync-parentguid><sync-checksum>-1174846904</sync-checksum><sync-rootid>0</sync-rootid><sync-itemtype>0</sync-itemtype><sync-timestamp>12 / Text5: 30/2004 1:12:19 PM</sync-timestamp><sync-itemid>687</sync-itemid><sync-prioritymapping>0:0-0/1:700-1000/2:300-699/3:1-299</sync-prioritymapping>
- 191: Text3: <sync-guid>{6429E248-A9AF-41F1-933F-584DDA535D71}</sync-guid><sync-parentguid>{9A3815CB-A629-4F2A-9165-68DCEEFF783B}</sync-parentguid><sync-checksum>1897108441</sync-checksum><sync-rootid>0</sync-rootid><sync-itemtype>0</sync-itemtype><sync-timestamp>12/3 / Text5: 0/2004 1:12:19 PM</sync-timestamp><sync-itemid>686</sync-itemid><sync-prioritymapping>0:0-0/1:700-1000/2:300-699/3:1-299</sync-prioritymapping>
- 192: Text3: <sync-guid>{1A1657FC-4EC0-4CA7-8B06-6960C857CE2F}</sync-guid><sync-parentguid>{9A3815CB-A629-4F2A-9165-68DCEEFF783B}</sync-parentguid><sync-checksum>1793073176</sync-checksum><sync-rootid>0</sync-rootid><sync-itemtype>0</sync-itemtype><sync-timestamp>12/3 / Text5: 0/2004 1:12:19 PM</sync-timestamp><sync-itemid>685</sync-itemid><sync-prioritymapping>0:0-0/1:700-1000/2:300-699/3:1-299</sync-prioritymapping>
- 193: Text3: <sync-guid>{EB89A9D0-29CC-4A64-87A3-FA1066C0E670}</sync-guid><sync-parentguid>{E3661073-A1C8-4E27-B414-D3FD14E50F9A}</sync-parentguid><sync-checksum>-760130745</sync-checksum><sync-rootid>0</sync-rootid><sync-itemtype>0</sync-itemtype><sync-timestamp>12/3 / Text5: 0/2004 1:12:20 PM</sync-timestamp><sync-itemid>678</sync-itemid><sync-prioritymapping>0:0-0/1:700-1000/2:300-699/3:1-299</sync-prioritymapping>
- 194: Text3: <sync-guid>{2FA3C2A8-6AED-4F85-A601-C86785183623}</sync-guid><sync-parentguid>{EB89A9D0-29CC-4A64-87A3-FA1066C0E670}</sync-parentguid><sync-checksum>1707637501</sync-checksum><sync-rootid>0</sync-rootid><sync-itemtype>0</sync-itemtype><sync-timestamp>12/3 / Text5: 0/2004 1:12:19 PM</sync-timestamp><sync-itemid>702</sync-itemid><sync-prioritymapping>0:0-0/1:700-1000/2:300-699/3:1-299</sync-prioritymapping>
- 195: Text3: <sync-guid>{1027595D-1EF8-4D0B-95D7-7A1E0463861E}</sync-guid><sync-parentguid>{EB89A9D0-29CC-4A64-87A3-FA1066C0E670}</sync-parentguid><sync-checksum>702087911</sync-checksum><sync-rootid>0</sync-rootid><sync-itemtype>0</sync-itemtype><sync-timestamp>12/30 / Text5: 2004 1:12:19 PM</sync-timestamp><sync-itemid>701</sync-itemid><sync-prioritymapping>0:0-0/1:700-1000/2:300-699/3:1-299</sync-prioritymapping>
- 196: Text3: <sync-guid>{89D08DCF-755C-4672-A3EB-1E020AF71304}</sync-guid><sync-parentguid>{EB89A9D0-29CC-4A64-87A3-FA1066C0E670}</sync-parentguid><sync-checksum>1791504716</sync-checksum><sync-rootid>0</sync-rootid><sync-itemtype>0</sync-itemtype><sync-timestamp>12/3 / Text5: 0/2004 1:12:19 PM</sync-timestamp><sync-itemid>704</sync-itemid><sync-prioritymapping>0:0-0/1:700-1000/2:300-699/3:1-299</sync-prioritymapping>
- 197: Text3: <sync-guid>{A872C89E-F241-412E-BAFE-926234A12F28}</sync-guid><sync-parentguid>{EB89A9D0-29CC-4A64-87A3-FA1066C0E670}</sync-parentguid><sync-checksum>1767838085</sync-checksum><sync-rootid>0</sync-rootid><sync-itemtype>0</sync-itemtype><sync-timestamp>12/3 / Text5: 0/2004 1:12:19 PM</sync-timestamp><sync-itemid>703</sync-itemid><sync-prioritymapping>0:0-0/1:700-1000/2:300-699/3:1-299</sync-prioritymapping>
- 198: Text3: <sync-guid>{1985C7AF-4EED-443F-BC03-9D9CC66A6DF4}</sync-guid><sync-parentguid>{EB89A9D0-29CC-4A64-87A3-FA1066C0E670}</sync-parentguid><sync-checksum>1825681517</sync-checksum><sync-rootid>0</sync-rootid><sync-itemtype>0</sync-itemtype><sync-timestamp>12/3 / Text5: 0/2004 1:12:19 PM</sync-timestamp><sync-itemid>700</sync-itemid><sync-prioritymapping>0:0-0/1:700-1000/2:300-699/3:1-299</sync-prioritymapping>
- 199: Text3: <sync-guid>{1F750FFC-A944-46B5-A719-A3CDA3A5644F}</sync-guid><sync-parentguid>{EB89A9D0-29CC-4A64-87A3-FA1066C0E670}</sync-parentguid><sync-checksum>1225071889</sync-checksum><sync-rootid>0</sync-rootid><sync-itemtype>0</sync-itemtype><sync-timestamp>12/3 / Text5: 0/2004 1:12:20 PM</sync-timestamp><sync-itemid>699</sync-itemid><sync-prioritymapping>0:0-0/1:700-1000/2:300-699/3:1-299</sync-prioritymapping>
- 200: Text3: <sync-guid>{3AA923AB-134B-4B31-992B-9579A2E38B0D}</sync-guid><sync-parentguid>{EB89A9D0-29CC-4A64-87A3-FA1066C0E670}</sync-parentguid><sync-checksum>-1139842376</sync-checksum><sync-rootid>0</sync-rootid><sync-itemtype>0</sync-itemtype><sync-timestamp>12 / Text5: 30/2004 1:12:20 PM</sync-timestamp><sync-itemid>705</sync-itemid><sync-prioritymapping>0:0-0/1:700-1000/2:300-699/3:1-299</sync-prioritymapping>
- 201: Text3: <sync-guid>{30AC7D22-4B56-47F1-8BB3-0B5207154E24}</sync-guid><sync-parentguid>{E3661073-A1C8-4E27-B414-D3FD14E50F9A}</sync-parentguid><sync-checksum>-338071856</sync-checksum><sync-rootid>0</sync-rootid><sync-itemtype>0</sync-itemtype><sync-timestamp>12/3 / Text5: 0/2004 1:12:20 PM</sync-timestamp><sync-itemid>698</sync-itemid><sync-prioritymapping>0:0-0/1:700-1000/2:300-699/3:1-299</sync-prioritymapping>
- 202: Text3: <sync-guid>{AD6890A1-9F8B-4EED-8266-B5F3A11A5335}</sync-guid><sync-parentguid>{30AC7D22-4B56-47F1-8BB3-0B5207154E24}</sync-parentguid><sync-checksum>1227138581</sync-checksum><sync-rootid>0</sync-rootid><sync-itemtype>0</sync-itemtype><sync-timestamp>12/3 / Text5: 0/2004 1:09:08 PM</sync-timestamp><sync-itemid>1134</sync-itemid><sync-prioritymapping>0:0-0/1:700-1000/2:300-699/3:1-299</sync-prioritymapping>
- 203: Text3: <sync-guid>{92B1603E-811F-4FDA-A70E-D4E5D784BAE2}</sync-guid><sync-parentguid>{30AC7D22-4B56-47F1-8BB3-0B5207154E24}</sync-parentguid><sync-checksum>346552861</sync-checksum><sync-rootid>0</sync-rootid><sync-itemtype>0</sync-itemtype><sync-timestamp>12/30 / Text5: 2004 1:09:08 PM</sync-timestamp><sync-itemid>1133</sync-itemid><sync-prioritymapping>0:0-0/1:700-1000/2:300-699/3:1-299</sync-prioritymapping>
- 204: Text3: <sync-guid>{C3F2B54A-5538-4B31-81CE-63D8DD0EC1FB}</sync-guid><sync-parentguid>{30AC7D22-4B56-47F1-8BB3-0B5207154E24}</sync-parentguid><sync-checksum>-1851935850</sync-checksum><sync-rootid>0</sync-rootid><sync-itemtype>0</sync-itemtype><sync-timestamp>12 / Text5: 30/2004 1:09:09 PM</sync-timestamp><sync-itemid>1132</sync-itemid><sync-prioritymapping>0:0-0/1:700-1000/2:300-699/3:1-299</sync-prioritymapping>
- 205: Text3: <sync-guid>{58A37CFB-26C4-449F-8F6E-82ADD027E194}</sync-guid><sync-parentguid>{30AC7D22-4B56-47F1-8BB3-0B5207154E24}</sync-parentguid><sync-checksum>-836689306</sync-checksum><sync-rootid>0</sync-rootid><sync-itemtype>0</sync-itemtype><sync-timestamp>12/3 / Text5: 0/2004 1:09:09 PM</sync-timestamp><sync-itemid>1131</sync-itemid><sync-prioritymapping>0:0-0/1:700-1000/2:300-699/3:1-299</sync-prioritymapping>
- 206: Text3: <sync-guid>{60052436-1561-4669-AEED-32D1E824BF0C}</sync-guid><sync-parentguid>{E3661073-A1C8-4E27-B414-D3FD14E50F9A}</sync-parentguid><sync-checksum>57174825</sync-checksum><sync-rootid>0</sync-rootid><sync-itemtype>0</sync-itemtype><sync-timestamp>12/30 / Text5: 2004 1:12:20 PM</sync-timestamp><sync-itemid>697</sync-itemid><sync-prioritymapping>0:0-0/1:700-1000/2:300-699/3:1-299</sync-prioritymapping>
- 207: Text3: <sync-guid>{08819B18-94C9-4B1D-9C3E-B1526AEF9D02}</sync-guid><sync-parentguid>{60052436-1561-4669-AEED-32D1E824BF0C}</sync-parentguid><sync-checksum>594504304</sync-checksum><sync-rootid>0</sync-rootid><sync-itemtype>0</sync-itemtype><sync-timestamp>12/30 / Text5: 2004 1:09:09 PM</sync-timestamp><sync-itemid>1139</sync-itemid><sync-prioritymapping>0:0-0/1:700-1000/2:300-699/3:1-299</sync-prioritymapping>
- 208: Text3: <sync-guid>{348D206F-1CC9-408A-9DB3-06076922750D}</sync-guid><sync-parentguid>{60052436-1561-4669-AEED-32D1E824BF0C}</sync-parentguid><sync-checksum>1859390061</sync-checksum><sync-rootid>0</sync-rootid><sync-itemtype>0</sync-itemtype><sync-timestamp>12/3 / Text5: 0/2004 1:09:09 PM</sync-timestamp><sync-itemid>1138</sync-itemid><sync-prioritymapping>0:0-0/1:700-1000/2:300-699/3:1-299</sync-prioritymapping>
- 209: Text3: <sync-guid>{BA7B8D7E-8DEC-4AE6-9C75-73CE2D0A4408}</sync-guid><sync-parentguid>{60052436-1561-4669-AEED-32D1E824BF0C}</sync-parentguid><sync-checksum>1590444860</sync-checksum><sync-rootid>0</sync-rootid><sync-itemtype>0</sync-itemtype><sync-timestamp>12/3 / Text5: 0/2004 1:09:09 PM</sync-timestamp><sync-itemid>1137</sync-itemid><sync-prioritymapping>0:0-0/1:700-1000/2:300-699/3:1-299</sync-prioritymapping>
- 210: Text3: <sync-guid>{1E7D6459-8C6C-4D1F-8FA9-DC8859E4EF00}</sync-guid><sync-parentguid>{60052436-1561-4669-AEED-32D1E824BF0C}</sync-parentguid><sync-checksum>-523535624</sync-checksum><sync-rootid>0</sync-rootid><sync-itemtype>0</sync-itemtype><sync-timestamp>12/3 / Text5: 0/2004 1:09:09 PM</sync-timestamp><sync-itemid>1136</sync-itemid><sync-prioritymapping>0:0-0/1:700-1000/2:300-699/3:1-299</sync-prioritymapping>

| ID | WBS | Task | Type | Duration | Start | Finish | Predecessors | Baseline start | Baseline finish | Baseline duration | Total slack | Free slack | Text4 |
| --- | --- | --- | --- | --- | --- | --- | --- | --- | --- | --- | --- | --- | --- |
| 211 | 4.5 | **Implement procedures** |  | 40.5d | 2005-05-04 | 2005-06-29 | 207 | 2005-05-04 | 2005-06-29 | 40.5d | 8d | 0d | {4DD7FD37-6251-4AA7-B7B5-5B1089CCAF2F} |
| 212 | 4.5.1 | Communicate cut-over occurrence |  | 0.5d | 2005-05-04 | 2005-05-04 |  | 2005-05-04 | 2005-05-04 | 0.5d | 8d | 0d | {144F6B48-7FFA-4343-A633-880894A69AF7} |
| 213 | 4.5.2 | Respond to exceptions |  | 40d | 2005-05-05 | 2005-06-29 | 212 | 2005-05-05 | 2005-06-29 | 40d | 8d |  | {376FA396-A279-4FC2-BD29-8159DBB0A8C0} |
| 214 | 4.6 | **Collect on-going data (continuing)** |  | 40d | 2005-05-04 | 2005-06-29 | 211SS | 2005-05-04 | 2005-06-29 | 40d | 8.5d |  | {3F8111BB-B31C-48D1-8D23-B6BE09446D0D} |
| 215 | 4.6.1 | Log continuing data points |  | 40d | 2005-05-04 | 2005-06-29 |  | 2005-05-04 | 2005-06-29 | 40d | 8.5d | 0d | {383B6944-F3B6-463D-AD28-F6B9F60FF5A5} |
| 216 | 4.6.2 | **Monitor initial "to be" Sigma Score** |  | 40d | 2005-05-04 | 2005-06-29 | 215SS | 2005-05-04 | 2005-06-29 | 40d | 8.5d |  | {1BB3CF7E-883B-4CEA-8173-82C1C2B9379B} |
| 217 | 4.6.2.1 | Consolidate collected data |  | 40d | 2005-05-04 | 2005-06-29 |  | 2005-05-04 | 2005-06-29 | 40d | 8.5d |  | {D4C5BC6E-277E-48F5-8F90-08FCC0456293} |
| 218 | 4.6.2.2 | Rationalize DPU & DPMO metrics |  | 40d | 2005-05-04 | 2005-06-29 |  | 2005-05-04 | 2005-06-29 | 40d | 8.5d |  | {2FB24884-4708-40A0-B51E-D47CC50FC6ED} |
| 219 | 4.6.2.3 | Maintain Sigma Score calculations |  | 40d | 2005-05-04 | 2005-06-29 |  | 2005-05-04 | 2005-06-29 | 40d | 8.5d |  | {019F30C6-7CCB-4AF3-AAB4-45E4F4C31DCC} |
| 220 | 4.7 | **Consolidate control requirements** |  | 8d | 2005-05-05 | 2005-05-16 | 212 | 2005-05-05 | 2005-05-16 | 8d | 34d | 0d | {674C7933-E2F8-4AE7-99FE-6E5C1A98FDEE} |
| 221 | 4.7.1 | Review improvement process maps |  | 1d | 2005-05-05 | 2005-05-05 |  | 2005-05-05 | 2005-05-05 | 1d | 34d | 0d | {B3AD7FF4-F9E3-4AF8-9E01-BC10243BAA83} |
| 222 | 4.7.2 | Assess IT project implementations |  | 1d | 2005-05-06 | 2005-05-06 | 221 | 2005-05-06 | 2005-05-06 | 1d | 34d | 0d | {90E5BF08-C902-43CD-B89B-CCF126FCF17A} |
| 223 | 4.7.3 | identify control requirements |  | 1d | 2005-05-09 | 2005-05-09 | 222 | 2005-05-09 | 2005-05-09 | 1d | 34d | 0d | {EB8EF5AE-3FBD-44B2-BE52-933AC7F354C4} |
| 224 | 4.7.4 | Draft Control Plan v0.1 |  | 1d | 2005-05-10 | 2005-05-10 | 223 | 2005-05-10 | 2005-05-10 | 1d | 34d | 0d | {ED09F753-8778-4794-BD94-C86DDAF16943} |
| 225 | 4.7.5 | Circulate Control Plan for review |  | 1d | 2005-05-11 | 2005-05-11 | 224 | 2005-05-11 | 2005-05-11 | 1d | 34d | 0d | {7A885337-FC32-4B5C-9B8F-B1B9AF8B90A4} |
| 226 | 4.7.6 | Update Control Plan v0.2 using feedback |  | 1d | 2005-05-12 | 2005-05-12 | 225 | 2005-05-12 | 2005-05-12 | 1d | 34d | 0d | {61C06556-21F7-4E4F-A748-F7728FED3D36} |
| 227 | 4.7.7 | Test draft Control Plan |  | 1d | 2005-05-13 | 2005-05-13 | 226 | 2005-05-13 | 2005-05-13 | 1d | 34d | 0d | {CE962323-2B4A-4C89-85A6-3EA5CA4302F5} |
| 228 | 4.7.8 | Review Control Plan test results |  | 1d | 2005-05-16 | 2005-05-16 | 227 | 2005-05-16 | 2005-05-16 | 1d | 34d |  | {EE412D64-E020-4974-85B1-57FFCDB07333} |
| 229 | 4.8 | **Update project charter & plan** |  | 4d | 2005-05-17 | 2005-05-20 | 220 | 2005-05-17 | 2005-05-20 | 4d | 34d | 0d | {86462388-2013-45BD-B015-B639E78477A2} |
| 230 | 4.8.1 | Review project status and milestones |  | 1d | 2005-05-17 | 2005-05-17 |  | 2005-05-17 | 2005-05-17 | 1d | 34d | 0d | {352289E1-3486-453E-8F98-D152AC91EC74} |
| 231 | 4.8.2 | Revise Project Charter & Plan |  | 1d | 2005-05-18 | 2005-05-18 | 230 | 2005-05-18 | 2005-05-18 | 1d | 34d | 0d | {788BA060-A32E-4791-B6C0-97C4038ED976} |
| 232 | 4.8.3 | Review charter & plan with stakeholders |  | 1d | 2005-05-19 | 2005-05-19 | 231 | 2005-05-19 | 2005-05-19 | 1d | 34d | 0d | {4410624D-DD2E-4128-9904-F376D65CCB68} |
| 233 | 4.8.4 | Finalize charter & plan revisions |  | 1d | 2005-05-20 | 2005-05-20 | 232 | 2005-05-20 | 2005-05-20 | 1d | 34d | 0d | {611C4261-3DEA-42F9-8A3B-368450A5CD5E} |
| 234 | 4.8.5 | Approve revised charter & plan | milestone | 0d | 2005-05-20 | 2005-05-20 | 233 | 2005-05-20 | 2005-05-20 | 0d | 34d |  | {F9313E3C-0BB1-4DD3-AE86-D150E10423F9} |

Notes:
- 211: Text3: <sync-guid>{4DD7FD37-6251-4AA7-B7B5-5B1089CCAF2F}</sync-guid><sync-parentguid>{E3661073-A1C8-4E27-B414-D3FD14E50F9A}</sync-parentguid><sync-checksum>1335495054</sync-checksum><sync-rootid>0</sync-rootid><sync-itemtype>0</sync-itemtype><sync-timestamp>12/3 / Text5: 0/2004 1:12:20 PM</sync-timestamp><sync-itemid>682</sync-itemid><sync-prioritymapping>0:0-0/1:700-1000/2:300-699/3:1-299</sync-prioritymapping>
- 212: Text3: <sync-guid>{144F6B48-7FFA-4343-A633-880894A69AF7}</sync-guid><sync-parentguid>{4DD7FD37-6251-4AA7-B7B5-5B1089CCAF2F}</sync-parentguid><sync-checksum>2137851040</sync-checksum><sync-rootid>0</sync-rootid><sync-itemtype>0</sync-itemtype><sync-timestamp>12/3 / Text5: 0/2004 1:09:10 PM</sync-timestamp><sync-itemid>1144</sync-itemid><sync-prioritymapping>0:0-0/1:700-1000/2:300-699/3:1-299</sync-prioritymapping>
- 213: Text3: <sync-guid>{376FA396-A279-4FC2-BD29-8159DBB0A8C0}</sync-guid><sync-parentguid>{4DD7FD37-6251-4AA7-B7B5-5B1089CCAF2F}</sync-parentguid><sync-checksum>432038445</sync-checksum><sync-rootid>0</sync-rootid><sync-itemtype>0</sync-itemtype><sync-timestamp>12/30 / Text5: 2004 1:09:10 PM</sync-timestamp><sync-itemid>1143</sync-itemid><sync-prioritymapping>0:0-0/1:700-1000/2:300-699/3:1-299</sync-prioritymapping>
- 214: Text3: <sync-guid>{3F8111BB-B31C-48D1-8D23-B6BE09446D0D}</sync-guid><sync-parentguid>{E3661073-A1C8-4E27-B414-D3FD14E50F9A}</sync-parentguid><sync-checksum>791147307</sync-checksum><sync-rootid>0</sync-rootid><sync-itemtype>0</sync-itemtype><sync-timestamp>12/30 / Text5: 2004 1:09:11 PM</sync-timestamp><sync-itemid>1158</sync-itemid><sync-prioritymapping>0:0-0/1:700-1000/2:300-699/3:1-299</sync-prioritymapping>
- 215: Text3: <sync-guid>{383B6944-F3B6-463D-AD28-F6B9F60FF5A5}</sync-guid><sync-parentguid>{3F8111BB-B31C-48D1-8D23-B6BE09446D0D}</sync-parentguid><sync-checksum>668205055</sync-checksum><sync-rootid>0</sync-rootid><sync-itemtype>0</sync-itemtype><sync-timestamp>12/30 / Text5: 2004 1:09:12 PM</sync-timestamp><sync-itemid>1157</sync-itemid><sync-prioritymapping>0:0-0/1:700-1000/2:300-699/3:1-299</sync-prioritymapping>
- 216: Text3: <sync-guid>{1BB3CF7E-883B-4CEA-8173-82C1C2B9379B}</sync-guid><sync-parentguid>{3F8111BB-B31C-48D1-8D23-B6BE09446D0D}</sync-parentguid><sync-checksum>2042974233</sync-checksum><sync-rootid>0</sync-rootid><sync-itemtype>0</sync-itemtype><sync-timestamp>12/3 / Text5: 0/2004 1:09:12 PM</sync-timestamp><sync-itemid>1156</sync-itemid><sync-prioritymapping>0:0-0/1:700-1000/2:300-699/3:1-299</sync-prioritymapping>
- 217: Text3: <sync-guid>{D4C5BC6E-277E-48F5-8F90-08FCC0456293}</sync-guid><sync-parentguid>{1BB3CF7E-883B-4CEA-8173-82C1C2B9379B}</sync-parentguid><sync-checksum>29122618</sync-checksum><sync-rootid>0</sync-rootid><sync-itemtype>0</sync-itemtype><sync-timestamp>12/30 / Text5: 2004 1:09:12 PM</sync-timestamp><sync-itemid>1155</sync-itemid><sync-prioritymapping>0:0-0/1:700-1000/2:300-699/3:1-299</sync-prioritymapping>
- 218: Text3: <sync-guid>{2FB24884-4708-40A0-B51E-D47CC50FC6ED}</sync-guid><sync-parentguid>{1BB3CF7E-883B-4CEA-8173-82C1C2B9379B}</sync-parentguid><sync-checksum>1763075076</sync-checksum><sync-rootid>0</sync-rootid><sync-itemtype>0</sync-itemtype><sync-timestamp>12/3 / Text5: 0/2004 1:09:12 PM</sync-timestamp><sync-itemid>1154</sync-itemid><sync-prioritymapping>0:0-0/1:700-1000/2:300-699/3:1-299</sync-prioritymapping>
- 219: Text3: <sync-guid>{019F30C6-7CCB-4AF3-AAB4-45E4F4C31DCC}</sync-guid><sync-parentguid>{1BB3CF7E-883B-4CEA-8173-82C1C2B9379B}</sync-parentguid><sync-checksum>-902894514</sync-checksum><sync-rootid>0</sync-rootid><sync-itemtype>0</sync-itemtype><sync-timestamp>12/3 / Text5: 0/2004 1:09:12 PM</sync-timestamp><sync-itemid>1153</sync-itemid><sync-prioritymapping>0:0-0/1:700-1000/2:300-699/3:1-299</sync-prioritymapping>
- 220: Text3: <sync-guid>{674C7933-E2F8-4AE7-99FE-6E5C1A98FDEE}</sync-guid><sync-parentguid>{E3661073-A1C8-4E27-B414-D3FD14E50F9A}</sync-parentguid><sync-checksum>932527237</sync-checksum><sync-rootid>0</sync-rootid><sync-itemtype>0</sync-itemtype><sync-timestamp>12/30 / Text5: 2004 1:12:22 PM</sync-timestamp><sync-itemid>331</sync-itemid><sync-prioritymapping>0:0-0/1:700-1000/2:300-699/3:1-299</sync-prioritymapping>
- 221: Text3: <sync-guid>{B3AD7FF4-F9E3-4AF8-9E01-BC10243BAA83}</sync-guid><sync-parentguid>{674C7933-E2F8-4AE7-99FE-6E5C1A98FDEE}</sync-parentguid><sync-checksum>-498574452</sync-checksum><sync-rootid>0</sync-rootid><sync-itemtype>0</sync-itemtype><sync-timestamp>12/3 / Text5: 0/2004 1:12:21 PM</sync-timestamp><sync-itemid>330</sync-itemid><sync-prioritymapping>0:0-0/1:700-1000/2:300-699/3:1-299</sync-prioritymapping>
- 222: Text3: <sync-guid>{90E5BF08-C902-43CD-B89B-CCF126FCF17A}</sync-guid><sync-parentguid>{674C7933-E2F8-4AE7-99FE-6E5C1A98FDEE}</sync-parentguid><sync-checksum>-1124970175</sync-checksum><sync-rootid>0</sync-rootid><sync-itemtype>0</sync-itemtype><sync-timestamp>12 / Text5: 30/2004 1:12:21 PM</sync-timestamp><sync-itemid>329</sync-itemid><sync-prioritymapping>0:0-0/1:700-1000/2:300-699/3:1-299</sync-prioritymapping>
- 223: Text3: <sync-guid>{EB8EF5AE-3FBD-44B2-BE52-933AC7F354C4}</sync-guid><sync-parentguid>{674C7933-E2F8-4AE7-99FE-6E5C1A98FDEE}</sync-parentguid><sync-checksum>152919921</sync-checksum><sync-rootid>0</sync-rootid><sync-itemtype>0</sync-itemtype><sync-timestamp>12/30 / Text5: 2004 1:12:21 PM</sync-timestamp><sync-itemid>328</sync-itemid><sync-prioritymapping>0:0-0/1:700-1000/2:300-699/3:1-299</sync-prioritymapping>
- 224: Text3: <sync-guid>{ED09F753-8778-4794-BD94-C86DDAF16943}</sync-guid><sync-parentguid>{674C7933-E2F8-4AE7-99FE-6E5C1A98FDEE}</sync-parentguid><sync-checksum>-754181626</sync-checksum><sync-rootid>0</sync-rootid><sync-itemtype>0</sync-itemtype><sync-timestamp>12/3 / Text5: 0/2004 1:12:21 PM</sync-timestamp><sync-itemid>327</sync-itemid><sync-prioritymapping>0:0-0/1:700-1000/2:300-699/3:1-299</sync-prioritymapping>
- 225: Text3: <sync-guid>{7A885337-FC32-4B5C-9B8F-B1B9AF8B90A4}</sync-guid><sync-parentguid>{674C7933-E2F8-4AE7-99FE-6E5C1A98FDEE}</sync-parentguid><sync-checksum>-78017200</sync-checksum><sync-rootid>0</sync-rootid><sync-itemtype>0</sync-itemtype><sync-timestamp>12/30 / Text5: 2004 1:12:21 PM</sync-timestamp><sync-itemid>326</sync-itemid><sync-prioritymapping>0:0-0/1:700-1000/2:300-699/3:1-299</sync-prioritymapping>
- 226: Text3: <sync-guid>{61C06556-21F7-4E4F-A748-F7728FED3D36}</sync-guid><sync-parentguid>{674C7933-E2F8-4AE7-99FE-6E5C1A98FDEE}</sync-parentguid><sync-checksum>-1881571235</sync-checksum><sync-rootid>0</sync-rootid><sync-itemtype>0</sync-itemtype><sync-timestamp>12 / Text5: 30/2004 1:12:21 PM</sync-timestamp><sync-itemid>325</sync-itemid><sync-prioritymapping>0:0-0/1:700-1000/2:300-699/3:1-299</sync-prioritymapping>
- 227: Text3: <sync-guid>{CE962323-2B4A-4C89-85A6-3EA5CA4302F5}</sync-guid><sync-parentguid>{674C7933-E2F8-4AE7-99FE-6E5C1A98FDEE}</sync-parentguid><sync-checksum>2123466736</sync-checksum><sync-rootid>0</sync-rootid><sync-itemtype>0</sync-itemtype><sync-timestamp>12/3 / Text5: 0/2004 1:12:22 PM</sync-timestamp><sync-itemid>324</sync-itemid><sync-prioritymapping>0:0-0/1:700-1000/2:300-699/3:1-299</sync-prioritymapping>
- 228: Text3: <sync-guid>{EE412D64-E020-4974-85B1-57FFCDB07333}</sync-guid><sync-parentguid>{674C7933-E2F8-4AE7-99FE-6E5C1A98FDEE}</sync-parentguid><sync-checksum>-1358249918</sync-checksum><sync-rootid>0</sync-rootid><sync-itemtype>0</sync-itemtype><sync-timestamp>12 / Text5: 30/2004 1:12:22 PM</sync-timestamp><sync-itemid>323</sync-itemid><sync-prioritymapping>0:0-0/1:700-1000/2:300-699/3:1-299</sync-prioritymapping>
- 229: Text3: <sync-guid>{86462388-2013-45BD-B015-B639E78477A2}</sync-guid><sync-parentguid>{E3661073-A1C8-4E27-B414-D3FD14E50F9A}</sync-parentguid><sync-checksum>279972690</sync-checksum><sync-rootid>0</sync-rootid><sync-itemtype>0</sync-itemtype><sync-timestamp>12/30 / Text5: 2004 1:12:23 PM</sync-timestamp><sync-itemid>360</sync-itemid><sync-prioritymapping>0:0-0/1:700-1000/2:300-699/3:1-299</sync-prioritymapping>
- 230: Text3: <sync-guid>{352289E1-3486-453E-8F98-D152AC91EC74}</sync-guid><sync-parentguid>{86462388-2013-45BD-B015-B639E78477A2}</sync-parentguid><sync-checksum>2052761734</sync-checksum><sync-rootid>0</sync-rootid><sync-itemtype>0</sync-itemtype><sync-timestamp>12/3 / Text5: 0/2004 1:12:22 PM</sync-timestamp><sync-itemid>359</sync-itemid><sync-prioritymapping>0:0-0/1:700-1000/2:300-699/3:1-299</sync-prioritymapping>
- 231: Text3: <sync-guid>{788BA060-A32E-4791-B6C0-97C4038ED976}</sync-guid><sync-parentguid>{86462388-2013-45BD-B015-B639E78477A2}</sync-parentguid><sync-checksum>-1110117133</sync-checksum><sync-rootid>0</sync-rootid><sync-itemtype>0</sync-itemtype><sync-timestamp>12 / Text5: 30/2004 1:12:22 PM</sync-timestamp><sync-itemid>358</sync-itemid><sync-prioritymapping>0:0-0/1:700-1000/2:300-699/3:1-299</sync-prioritymapping>
- 232: Text3: <sync-guid>{4410624D-DD2E-4128-9904-F376D65CCB68}</sync-guid><sync-parentguid>{86462388-2013-45BD-B015-B639E78477A2}</sync-parentguid><sync-checksum>-1713258526</sync-checksum><sync-rootid>0</sync-rootid><sync-itemtype>0</sync-itemtype><sync-timestamp>12 / Text5: 30/2004 1:12:22 PM</sync-timestamp><sync-itemid>357</sync-itemid><sync-prioritymapping>0:0-0/1:700-1000/2:300-699/3:1-299</sync-prioritymapping>
- 233: Text3: <sync-guid>{611C4261-3DEA-42F9-8A3B-368450A5CD5E}</sync-guid><sync-parentguid>{86462388-2013-45BD-B015-B639E78477A2}</sync-parentguid><sync-checksum>-271484461</sync-checksum><sync-rootid>0</sync-rootid><sync-itemtype>0</sync-itemtype><sync-timestamp>12/3 / Text5: 0/2004 1:12:22 PM</sync-timestamp><sync-itemid>356</sync-itemid><sync-prioritymapping>0:0-0/1:700-1000/2:300-699/3:1-299</sync-prioritymapping>
- 234: Text3: <sync-guid>{F9313E3C-0BB1-4DD3-AE86-D150E10423F9}</sync-guid><sync-parentguid>{86462388-2013-45BD-B015-B639E78477A2}</sync-parentguid><sync-checksum>-1229086006</sync-checksum><sync-rootid>0</sync-rootid><sync-itemtype>0</sync-itemtype><sync-timestamp>12 / Text5: 30/2004 1:12:22 PM</sync-timestamp><sync-itemid>355</sync-itemid><sync-prioritymapping>0:0-0/1:700-1000/2:300-699/3:1-299</sync-prioritymapping>

| ID | WBS | Task | Type | Duration | Start | Finish | Predecessors | Baseline start | Baseline finish | Baseline duration | Total slack | Free slack | Text4 |
| --- | --- | --- | --- | --- | --- | --- | --- | --- | --- | --- | --- | --- | --- |
| 235 | 4.9 | **Conduct phase QA assessment** |  | 2d | 2005-05-23 | 2005-05-24 | 229 | 2005-05-23 | 2005-05-24 | 2d | 34d |  | {D8A4FE16-92D9-465E-924A-CCB77C23BE4A} |
| 236 | 4.9.1 | Consolidate phase results |  | 0.5d | 2005-05-23 | 2005-05-23 |  | 2005-05-23 | 2005-05-23 | 0.5d | 34d | 0d | {69831459-747E-4B90-9B93-5052EAFC296C} |
| 237 | 4.9.2 | Conduct phase self-assessment |  | 0.25d | 2005-05-23 | 2005-05-23 | 236 | 2005-05-23 | 2005-05-23 | 0.25d | 34d | 0d | {7C5623A9-7797-49B8-8F7E-6E883F0A2824} |
| 238 | 4.9.3 | Conduct QA assessment |  | 0.5d | 2005-05-23 | 2005-05-24 | 237 | 2005-05-23 | 2005-05-24 | 0.5d | 34d | 0d | {431A64C2-0EDC-4EF6-85DE-D4E16C0CCC39} |
| 239 | 4.9.4 | Review assessment feedback |  | 0.25d | 2005-05-24 | 2005-05-24 | 238 | 2005-05-24 | 2005-05-24 | 0.25d | 34d | 0d | {8EFA8FA8-B761-4643-A710-0E0FB7EBB382} |
| 240 | 4.9.5 | Implement QA feedback |  | 0.5d | 2005-05-24 | 2005-05-24 | 239 | 2005-05-24 | 2005-05-24 | 0.5d | 34d |  | {8C9AD8CA-CE76-42DB-97E7-19C1235207A9} |
| 241 | 5 | **CONTROL** |  | 31d | 2005-07-12 | 2005-08-23 | 187, 430 | 2005-07-12 | 2005-08-23 | 31d | 0d |  | {085DC560-8D0C-42FA-9268-81ECF2E5129D} |
| 242 | 5.1 | **Finalize process controls** |  | 6d | 2005-07-12 | 2005-07-19 |  | 2005-07-12 | 2005-07-19 | 6d | 25d |  | {AE094825-4D2A-460B-A2D9-3986CA1B32C3} |
| 243 | 5.1.1 | Evaluate transitional exceptions |  | 5d | 2005-07-12 | 2005-07-18 |  | 2005-07-12 | 2005-07-18 | 5d | 25d | 0d | {7BD2D050-86AB-487B-B55E-F6254DDF0ADA} |
| 244 | 5.1.2 | Finalize control requirements |  | 1d | 2005-07-12 | 2005-07-12 | 243SS | 2005-07-12 | 2005-07-12 | 1d | 25d | 0d | {92D5981E-646E-45B0-BD42-41B92F4D5C7B} |
| 245 | 5.1.3 | Build Control Plan v0.3 |  | 1d | 2005-07-13 | 2005-07-13 | 244 | 2005-07-13 | 2005-07-13 | 1d | 25d | 0d | {8B2811F3-E1DE-4653-80F6-7D93229EA543} |
| 246 | 5.1.4 | Circulate Control Plan for review |  | 1d | 2005-07-14 | 2005-07-14 | 245 | 2005-07-14 | 2005-07-14 | 1d | 25d | 0d | {7B45CC78-A47B-4715-8E2B-95A3094DD1EC} |
| 247 | 5.1.5 | Update Control Plan 0.4 using feedback |  | 1d | 2005-07-15 | 2005-07-15 | 246 | 2005-07-15 | 2005-07-15 | 1d | 25d | 0d | {94376668-11BC-4285-9EA7-99423D053AF4} |
| 248 | 5.1.6 | Conduct Control Plan peer review |  | 1d | 2005-07-18 | 2005-07-18 | 247 | 2005-07-18 | 2005-07-18 | 1d | 25d | 0d | {5A31943F-E7A6-4810-ABE7-7137FD971C98} |
| 249 | 5.1.7 | Finalize Control Plan v0.5 |  | 1d | 2005-07-19 | 2005-07-19 | 248 | 2005-07-19 | 2005-07-19 | 1d | 25d | 0d | {88FE8987-0441-4870-B7E6-C16F76D26E50} |
| 250 | 5.1.8 | Approve Control Plan | milestone | 0d | 2005-07-19 | 2005-07-19 | 249 | 2005-07-19 | 2005-07-19 | 0d | 25d |  | {BA60E6B1-64AD-4D20-A02F-46DB67E5619B} |
| 251 | 5.2 | **Implement process controls** |  | 31d | 2005-07-12 | 2005-08-23 |  | 2005-07-12 | 2005-08-23 | 31d | 0d |  | {4946AE53-177D-4326-8837-F3A0A05D7A18} |
| 252 | 5.2.1 | Commmunicate cut-over occurences |  | 1d | 2005-07-12 | 2005-07-12 |  | 2005-07-12 | 2005-07-12 | 1d | 0d |  | {FAF33198-E10C-4CE4-8D8F-EF7A0A1D69DC} |
| 253 | 5.2.2 | Respond to exceptions |  | 30d | 2005-07-13 | 2005-08-23 | 252 | 2005-07-13 | 2005-08-23 | 30d | 0d |  | {FA33A1B3-295B-4862-864A-63956E70123E} |
| 254 | 5.3 | **Conduct phase QA assessment** |  | 2d | 2005-07-12 | 2005-07-13 | 251SS | 2005-07-12 | 2005-07-13 | 2d | 26d |  | {F5E3C384-E7C6-491B-B3AC-1CF19EB9C1C2} |
| 255 | 5.3.1 | Consolidate phase results |  | 0.5d | 2005-07-12 | 2005-07-12 |  | 2005-07-12 | 2005-07-12 | 0.5d | 26d | 0d | {83F24830-829C-4DCC-B8D9-905BC59BBDA0} |
| 256 | 5.3.2 | Conduct phase self-assessment |  | 0.25d | 2005-07-12 | 2005-07-12 | 255 | 2005-07-12 | 2005-07-12 | 0.25d | 26d | 0d | {439E6C94-B008-4BD2-92C4-7C7C0F60F093} |
| 257 | 5.3.3 | Conduct QA assessment |  | 0.5d | 2005-07-12 | 2005-07-13 | 256 | 2005-07-12 | 2005-07-13 | 0.5d | 26d | 0d | {9821CEC1-E20C-4BD7-8A03-F4D1EC117048} |
| 258 | 5.3.4 | Review assessment feedback |  | 0.25d | 2005-07-13 | 2005-07-13 | 257 | 2005-07-13 | 2005-07-13 | 0.25d | 26d | 0d | {17A02D36-384C-4FE9-ADE4-363DE90C318C} |
| 259 | 5.3.5 | Implement QA feedback |  | 0.5d | 2005-07-13 | 2005-07-13 | 258 | 2005-07-13 | 2005-07-13 | 0.5d | 26d | 0d | {DA630072-DB7D-4810-82FD-20651BB1B128} |

Notes:
- 235: Text3: <sync-guid>{D8A4FE16-92D9-465E-924A-CCB77C23BE4A}</sync-guid><sync-parentguid>{E3661073-A1C8-4E27-B414-D3FD14E50F9A}</sync-parentguid><sync-checksum>1783693344</sync-checksum><sync-rootid>0</sync-rootid><sync-itemtype>0</sync-itemtype><sync-timestamp>12/3 / Text5: 0/2004 1:12:23 PM</sync-timestamp><sync-itemid>322</sync-itemid><sync-prioritymapping>0:0-0/1:700-1000/2:300-699/3:1-299</sync-prioritymapping>
- 236: Text3: <sync-guid>{69831459-747E-4B90-9B93-5052EAFC296C}</sync-guid><sync-parentguid>{D8A4FE16-92D9-465E-924A-CCB77C23BE4A}</sync-parentguid><sync-checksum>793243870</sync-checksum><sync-rootid>0</sync-rootid><sync-itemtype>0</sync-itemtype><sync-timestamp>12/30 / Text5: 2004 1:09:11 PM</sync-timestamp><sync-itemid>1078</sync-itemid><sync-prioritymapping>0:0-0/1:700-1000/2:300-699/3:1-299</sync-prioritymapping>
- 237: Text3: <sync-guid>{7C5623A9-7797-49B8-8F7E-6E883F0A2824}</sync-guid><sync-parentguid>{D8A4FE16-92D9-465E-924A-CCB77C23BE4A}</sync-parentguid><sync-checksum>-1500377</sync-checksum><sync-rootid>0</sync-rootid><sync-itemtype>0</sync-itemtype><sync-timestamp>12/30 / Text5: 2004 1:09:11 PM</sync-timestamp><sync-itemid>1077</sync-itemid><sync-prioritymapping>0:0-0/1:700-1000/2:300-699/3:1-299</sync-prioritymapping>
- 238: Text3: <sync-guid>{431A64C2-0EDC-4EF6-85DE-D4E16C0CCC39}</sync-guid><sync-parentguid>{D8A4FE16-92D9-465E-924A-CCB77C23BE4A}</sync-parentguid><sync-checksum>375016622</sync-checksum><sync-rootid>0</sync-rootid><sync-itemtype>0</sync-itemtype><sync-timestamp>12/30 / Text5: 2004 1:09:11 PM</sync-timestamp><sync-itemid>1076</sync-itemid><sync-prioritymapping>0:0-0/1:700-1000/2:300-699/3:1-299</sync-prioritymapping>
- 239: Text3: <sync-guid>{8EFA8FA8-B761-4643-A710-0E0FB7EBB382}</sync-guid><sync-parentguid>{D8A4FE16-92D9-465E-924A-CCB77C23BE4A}</sync-parentguid><sync-checksum>-1481459182</sync-checksum><sync-rootid>0</sync-rootid><sync-itemtype>0</sync-itemtype><sync-timestamp>12 / Text5: 30/2004 1:09:11 PM</sync-timestamp><sync-itemid>1075</sync-itemid><sync-prioritymapping>0:0-0/1:700-1000/2:300-699/3:1-299</sync-prioritymapping>
- 240: Text3: <sync-guid>{8C9AD8CA-CE76-42DB-97E7-19C1235207A9}</sync-guid><sync-parentguid>{D8A4FE16-92D9-465E-924A-CCB77C23BE4A}</sync-parentguid><sync-checksum>1490098336</sync-checksum><sync-rootid>0</sync-rootid><sync-itemtype>0</sync-itemtype><sync-timestamp>12/3 / Text5: 0/2004 1:09:11 PM</sync-timestamp><sync-itemid>1074</sync-itemid><sync-prioritymapping>0:0-0/1:700-1000/2:300-699/3:1-299</sync-prioritymapping>
- 241: Text3: <sync-guid>{085DC560-8D0C-42FA-9268-81ECF2E5129D}</sync-guid><sync-parentguid>{69CAB05D-8790-4A69-A093-1D8EDB5A2679}</sync-parentguid><sync-checksum>262152455</sync-checksum><sync-rootid>0</sync-rootid><sync-itemtype>0</sync-itemtype><sync-timestamp>12/30 / Text5: 2004 1:12:25 PM</sync-timestamp><sync-itemid>185</sync-itemid><sync-prioritymapping>0:0-0/1:700-1000/2:300-699/3:1-299</sync-prioritymapping>
- 242: Text3: <sync-guid>{AE094825-4D2A-460B-A2D9-3986CA1B32C3}</sync-guid><sync-parentguid>{085DC560-8D0C-42FA-9268-81ECF2E5129D}</sync-parentguid><sync-checksum>154121495</sync-checksum><sync-rootid>0</sync-rootid><sync-itemtype>0</sync-itemtype><sync-timestamp>12/30 / Text5: 2004 1:12:24 PM</sync-timestamp><sync-itemid>186</sync-itemid><sync-prioritymapping>0:0-0/1:700-1000/2:300-699/3:1-299</sync-prioritymapping>
- 243: Text3: <sync-guid>{7BD2D050-86AB-487B-B55E-F6254DDF0ADA}</sync-guid><sync-parentguid>{AE094825-4D2A-460B-A2D9-3986CA1B32C3}</sync-parentguid><sync-checksum>384084594</sync-checksum><sync-rootid>0</sync-rootid><sync-itemtype>0</sync-itemtype><sync-timestamp>12/30 / Text5: 2004 1:09:13 PM</sync-timestamp><sync-itemid>1147</sync-itemid><sync-prioritymapping>0:0-0/1:700-1000/2:300-699/3:1-299</sync-prioritymapping>
- 244: Text3: <sync-guid>{92D5981E-646E-45B0-BD42-41B92F4D5C7B}</sync-guid><sync-parentguid>{AE094825-4D2A-460B-A2D9-3986CA1B32C3}</sync-parentguid><sync-checksum>-1088521152</sync-checksum><sync-rootid>0</sync-rootid><sync-itemtype>0</sync-itemtype><sync-timestamp>12 / Text5: 30/2004 1:12:23 PM</sync-timestamp><sync-itemid>189</sync-itemid><sync-prioritymapping>0:0-0/1:700-1000/2:300-699/3:1-299</sync-prioritymapping>
- 245: Text3: <sync-guid>{8B2811F3-E1DE-4653-80F6-7D93229EA543}</sync-guid><sync-parentguid>{AE094825-4D2A-460B-A2D9-3986CA1B32C3}</sync-parentguid><sync-checksum>233450664</sync-checksum><sync-rootid>0</sync-rootid><sync-itemtype>0</sync-itemtype><sync-timestamp>12/30 / Text5: 2004 1:12:23 PM</sync-timestamp><sync-itemid>190</sync-itemid><sync-prioritymapping>0:0-0/1:700-1000/2:300-699/3:1-299</sync-prioritymapping>
- 246: Text3: <sync-guid>{7B45CC78-A47B-4715-8E2B-95A3094DD1EC}</sync-guid><sync-parentguid>{AE094825-4D2A-460B-A2D9-3986CA1B32C3}</sync-parentguid><sync-checksum>1230082529</sync-checksum><sync-rootid>0</sync-rootid><sync-itemtype>0</sync-itemtype><sync-timestamp>12/3 / Text5: 0/2004 1:12:23 PM</sync-timestamp><sync-itemid>191</sync-itemid><sync-prioritymapping>0:0-0/1:700-1000/2:300-699/3:1-299</sync-prioritymapping>
- 247: Text3: <sync-guid>{94376668-11BC-4285-9EA7-99423D053AF4}</sync-guid><sync-parentguid>{AE094825-4D2A-460B-A2D9-3986CA1B32C3}</sync-parentguid><sync-checksum>348498845</sync-checksum><sync-rootid>0</sync-rootid><sync-itemtype>0</sync-itemtype><sync-timestamp>12/30 / Text5: 2004 1:12:24 PM</sync-timestamp><sync-itemid>192</sync-itemid><sync-prioritymapping>0:0-0/1:700-1000/2:300-699/3:1-299</sync-prioritymapping>
- 248: Text3: <sync-guid>{5A31943F-E7A6-4810-ABE7-7137FD971C98}</sync-guid><sync-parentguid>{AE094825-4D2A-460B-A2D9-3986CA1B32C3}</sync-parentguid><sync-checksum>1186774228</sync-checksum><sync-rootid>0</sync-rootid><sync-itemtype>0</sync-itemtype><sync-timestamp>12/3 / Text5: 0/2004 1:12:24 PM</sync-timestamp><sync-itemid>332</sync-itemid><sync-prioritymapping>0:0-0/1:700-1000/2:300-699/3:1-299</sync-prioritymapping>
- 249: Text3: <sync-guid>{88FE8987-0441-4870-B7E6-C16F76D26E50}</sync-guid><sync-parentguid>{AE094825-4D2A-460B-A2D9-3986CA1B32C3}</sync-parentguid><sync-checksum>-153145502</sync-checksum><sync-rootid>0</sync-rootid><sync-itemtype>0</sync-itemtype><sync-timestamp>12/3 / Text5: 0/2004 1:12:24 PM</sync-timestamp><sync-itemid>193</sync-itemid><sync-prioritymapping>0:0-0/1:700-1000/2:300-699/3:1-299</sync-prioritymapping>
- 250: Text3: <sync-guid>{BA60E6B1-64AD-4D20-A02F-46DB67E5619B}</sync-guid><sync-parentguid>{AE094825-4D2A-460B-A2D9-3986CA1B32C3}</sync-parentguid><sync-checksum>-2060871935</sync-checksum><sync-rootid>0</sync-rootid><sync-itemtype>0</sync-itemtype><sync-timestamp>12 / Text5: 30/2004 1:12:24 PM</sync-timestamp><sync-itemid>194</sync-itemid><sync-prioritymapping>0:0-0/1:700-1000/2:300-699/3:1-299</sync-prioritymapping>
- 251: Text3: <sync-guid>{4946AE53-177D-4326-8837-F3A0A05D7A18}</sync-guid><sync-parentguid>{085DC560-8D0C-42FA-9268-81ECF2E5129D}</sync-parentguid><sync-checksum>-353165557</sync-checksum><sync-rootid>0</sync-rootid><sync-itemtype>0</sync-itemtype><sync-timestamp>12/3 / Text5: 0/2004 1:12:24 PM</sync-timestamp><sync-itemid>196</sync-itemid><sync-prioritymapping>0:0-0/1:700-1000/2:300-699/3:1-299</sync-prioritymapping>
- 252: Text3: <sync-guid>{FAF33198-E10C-4CE4-8D8F-EF7A0A1D69DC}</sync-guid><sync-parentguid>{4946AE53-177D-4326-8837-F3A0A05D7A18}</sync-parentguid><sync-checksum>1348576723</sync-checksum><sync-rootid>0</sync-rootid><sync-itemtype>0</sync-itemtype><sync-timestamp>12/3 / Text5: 0/2004 1:12:24 PM</sync-timestamp><sync-itemid>197</sync-itemid><sync-prioritymapping>0:0-0/1:700-1000/2:300-699/3:1-299</sync-prioritymapping>
- 253: Text3: <sync-guid>{FA33A1B3-295B-4862-864A-63956E70123E}</sync-guid><sync-parentguid>{4946AE53-177D-4326-8837-F3A0A05D7A18}</sync-parentguid><sync-checksum>844385038</sync-checksum><sync-rootid>0</sync-rootid><sync-itemtype>0</sync-itemtype><sync-timestamp>12/30 / Text5: 2004 1:09:13 PM</sync-timestamp><sync-itemid>1146</sync-itemid><sync-prioritymapping>0:0-0/1:700-1000/2:300-699/3:1-299</sync-prioritymapping>
- 254: Text3: <sync-guid>{F5E3C384-E7C6-491B-B3AC-1CF19EB9C1C2}</sync-guid><sync-parentguid>{085DC560-8D0C-42FA-9268-81ECF2E5129D}</sync-parentguid><sync-checksum>-1134852230</sync-checksum><sync-rootid>0</sync-rootid><sync-itemtype>0</sync-itemtype><sync-timestamp>12 / Text5: 30/2004 1:12:25 PM</sync-timestamp><sync-itemid>361</sync-itemid><sync-prioritymapping>0:0-0/1:700-1000/2:300-699/3:1-299</sync-prioritymapping>
- 255: Text3: <sync-guid>{83F24830-829C-4DCC-B8D9-905BC59BBDA0}</sync-guid><sync-parentguid>{F5E3C384-E7C6-491B-B3AC-1CF19EB9C1C2}</sync-parentguid><sync-checksum>376492644</sync-checksum><sync-rootid>0</sync-rootid><sync-itemtype>0</sync-itemtype><sync-timestamp>12/30 / Text5: 2004 1:09:13 PM</sync-timestamp><sync-itemid>1083</sync-itemid><sync-prioritymapping>0:0-0/1:700-1000/2:300-699/3:1-299</sync-prioritymapping>
- 256: Text3: <sync-guid>{439E6C94-B008-4BD2-92C4-7C7C0F60F093}</sync-guid><sync-parentguid>{F5E3C384-E7C6-491B-B3AC-1CF19EB9C1C2}</sync-parentguid><sync-checksum>-958514787</sync-checksum><sync-rootid>0</sync-rootid><sync-itemtype>0</sync-itemtype><sync-timestamp>12/3 / Text5: 0/2004 1:09:14 PM</sync-timestamp><sync-itemid>1082</sync-itemid><sync-prioritymapping>0:0-0/1:700-1000/2:300-699/3:1-299</sync-prioritymapping>
- 257: Text3: <sync-guid>{9821CEC1-E20C-4BD7-8A03-F4D1EC117048}</sync-guid><sync-parentguid>{F5E3C384-E7C6-491B-B3AC-1CF19EB9C1C2}</sync-parentguid><sync-checksum>-1068446732</sync-checksum><sync-rootid>0</sync-rootid><sync-itemtype>0</sync-itemtype><sync-timestamp>12 / Text5: 30/2004 1:09:14 PM</sync-timestamp><sync-itemid>1081</sync-itemid><sync-prioritymapping>0:0-0/1:700-1000/2:300-699/3:1-299</sync-prioritymapping>
- 258: Text3: <sync-guid>{17A02D36-384C-4FE9-ADE4-363DE90C318C}</sync-guid><sync-parentguid>{F5E3C384-E7C6-491B-B3AC-1CF19EB9C1C2}</sync-parentguid><sync-checksum>-174350179</sync-checksum><sync-rootid>0</sync-rootid><sync-itemtype>0</sync-itemtype><sync-timestamp>12/3 / Text5: 0/2004 1:09:14 PM</sync-timestamp><sync-itemid>1080</sync-itemid><sync-prioritymapping>0:0-0/1:700-1000/2:300-699/3:1-299</sync-prioritymapping>
- 259: Text3: <sync-guid>{DA630072-DB7D-4810-82FD-20651BB1B128}</sync-guid><sync-parentguid>{F5E3C384-E7C6-491B-B3AC-1CF19EB9C1C2}</sync-parentguid><sync-checksum>184025647</sync-checksum><sync-rootid>0</sync-rootid><sync-itemtype>0</sync-itemtype><sync-timestamp>12/30 / Text5: 2004 1:09:14 PM</sync-timestamp><sync-itemid>1079</sync-itemid><sync-prioritymapping>0:0-0/1:700-1000/2:300-699/3:1-299</sync-prioritymapping>

| ID | WBS | Task | Type | Duration | Start | Finish | Predecessors | Baseline start | Baseline finish | Baseline duration | Total slack | Free slack | Text4 |
| --- | --- | --- | --- | --- | --- | --- | --- | --- | --- | --- | --- | --- | --- |
| 260 | 5.4 | **Project shutdown** |  | 3d | 2005-07-14 | 2005-07-18 | 575, 259 | 2005-07-14 | 2005-07-18 | 3d | 26d |  | {251D006B-CE12-4B1E-B7B2-31F926C90698} |
| 261 | 5.4.1 | Lessons learned |  | 1d | 2005-07-14 | 2005-07-14 |  | 2005-07-14 | 2005-07-14 | 1d | 26d | 0d | {013EC5BE-592A-48AC-B32A-5D6AC65EFCAA} |
| 262 | 5.4.2 | Follow-on planning |  | 1d | 2005-07-15 | 2005-07-15 | 261 | 2005-07-15 | 2005-07-15 | 1d | 26d | 0d | {45F40DAD-9916-4C7B-8133-7A2D8AC1C156} |
| 263 | 5.4.3 | Recognize team members |  | 1d | 2005-07-14 | 2005-07-14 |  | 2005-07-14 | 2005-07-14 | 1d | 28d | 2d | {CC7A1991-EB34-465F-8192-70057BF3A218} |
| 264 | 5.4.4 | Archive project records |  | 1d | 2005-07-18 | 2005-07-18 | 262 | 2005-07-18 | 2005-07-18 | 1d | 26d | 0d | {8DC27076-759D-4C40-A965-27D53E06A4C3} |
| 265 | 5.4.5 | Project shut-down | milestone | 0d | 2005-07-18 | 2005-07-18 | 264, 263 | 2005-07-18 | 2005-07-18 | 0d | 26d |  | {3998F45B-D004-45B0-86F4-4FF2FF6E80E3} |
| 266 | 6 | **IT SUBPROJECT** |  | 104d? | 2005-02-03 | 2005-06-29 | 1 | 2005-02-03 | 2005-06-29 | 104d? | 39.5d |  | {2B2817F9-76F5-4CDD-8182-CF152760D6BB} |
| 267 | 6.1 | **INITIATION** |  | 11d | 2005-02-03 | 2005-02-18 |  | 2005-02-03 | 2005-02-18 | 11d | 132.5d |  | {3F24235F-9AD8-4ADA-8120-06887728D4F4} |
| 268 | 6.1.1 | **Kick-off subproject** |  | 4d | 2005-02-03 | 2005-02-09 |  | 2005-02-03 | 2005-02-09 | 4d | 133.5d |  | {CC640DD0-C597-42B1-BF01-20D92DF70E20} |
| 269 | 6.1.1.1 | Collect relevant documentation |  | 1d | 2005-02-03 | 2005-02-04 |  | 2005-02-03 | 2005-02-04 | 1d | 141.5d | 0d | {901769CC-57E4-40CC-8F92-D341AE6A4438} |
| 270 | 6.1.1.2 | **Secure intergroup support** |  | 1d | 2005-02-04 | 2005-02-07 | 269 | 2005-02-04 | 2005-02-07 | 1d | 141.5d | 0d | {4956EE52-FE7F-4769-AFBE-74E66F75BAE1} |
| 271 | 6.1.1.2.1 | Secure management support |  | 1d | 2005-02-04 | 2005-02-07 |  | 2005-02-04 | 2005-02-07 | 1d | 141.5d |  | {90B51A0D-2007-4A4A-8955-6395655F6ABA} |
| 272 | 6.1.1.2.2 | Secure QA support |  | 1d | 2005-02-04 | 2005-02-07 |  | 2005-02-04 | 2005-02-07 | 1d | 141.5d |  | {EF5D3E0C-D920-4885-AD09-F5B0EDEC6DC3} |
| 273 | 6.1.1.2.3 | Secure architecture support |  | 1d | 2005-02-04 | 2005-02-07 |  | 2005-02-04 | 2005-02-07 | 1d | 141.5d |  | {F16B63D2-97D4-4B9C-8BF5-63DC4267DD18} |
| 274 | 6.1.1.2.4 | Secure infrastructure support |  | 1d | 2005-02-04 | 2005-02-07 |  | 2005-02-04 | 2005-02-07 | 1d | 141.5d |  | {079556ED-5CA8-42D1-9D9E-4680EF79E285} |
| 275 | 6.1.1.3 | Organize project framework v0.1 |  | 2d | 2005-02-04 | 2005-02-08 | 270SS | 2005-02-04 | 2005-02-08 | 2d | 132.5d | 0d | {A18CD4F7-3240-4CF2-8449-D4269D9EA87A} |
| 276 | 6.1.1.4 | Circulate v0.1 for feedback |  | 1d | 2005-02-08 | 2005-02-09 | 275 | 2005-02-08 | 2005-02-09 | 1d | 132.5d | 0d | {BBD826A4-7285-4AF5-B760-397F6A253D0E} |
| 277 | 6.1.2 | **Define project direction** |  | 5d | 2005-02-09 | 2005-02-16 | 276 | 2005-02-09 | 2005-02-16 | 5d | 132.5d | 0d | {C2B2A734-E259-416D-BFFF-45C42B1AB76E} |
| 278 | 6.1.2.1 | Identify architectural framework |  | 1d | 2005-02-09 | 2005-02-10 |  | 2005-02-09 | 2005-02-10 | 1d | 132.5d | 0d | {210A7C0E-85AA-4EE0-948D-5847B54E2E86} |
| 279 | 6.1.2.2 | Produce briefing paper for discussion |  | 1d | 2005-02-10 | 2005-02-11 | 278 | 2005-02-10 | 2005-02-11 | 1d | 132.5d | 0d | {B254C7FC-9A71-4985-AE92-45697F09B09F} |
| 280 | 6.1.2.3 | Circulate briefing paper for comments |  | 1d | 2005-02-11 | 2005-02-14 | 279 | 2005-02-11 | 2005-02-14 | 1d | 132.5d | 0d | {A9CB1594-D072-453C-BE86-A80CF9B818E0} |
| 281 | 6.1.2.4 | Explore architectural options |  | 1d | 2005-02-14 | 2005-02-15 | 280 | 2005-02-14 | 2005-02-15 | 1d | 132.5d | 0d | {5CCC1765-1E76-4766-BF39-036E4B69BC73} |
| 282 | 6.1.2.5 | Plan integration with Six Sigma direction |  | 1d | 2005-02-15 | 2005-02-16 | 281 | 2005-02-15 | 2005-02-16 | 1d | 132.5d |  | {FEADA928-86DB-4C04-9ACF-A1185B5DEB51} |
| 283 | 6.1.3 | **Update subproject plan** |  | 4d | 2005-02-03 | 2005-02-09 |  | 2005-02-03 | 2005-02-09 | 4d | 139.5d |  | {E6CC990F-723C-4A62-88F3-D29DDF2A3247} |
| 284 | 6.1.3.1 | Review project status and milestones |  | 1d | 2005-02-03 | 2005-02-04 |  | 2005-02-03 | 2005-02-04 | 1d | 139.5d | 0d | {707CCA79-E316-404D-ADEA-D111D934604F} |
| 285 | 6.1.3.2 | Revise plan schedule & assignments |  | 1d | 2005-02-04 | 2005-02-07 | 284 | 2005-02-04 | 2005-02-07 | 1d | 139.5d | 0d | {E8949D23-2682-4D44-9386-2C42EF72B989} |
| 286 | 6.1.3.3 | Review charter & plan with stakeholders |  | 1d | 2005-02-07 | 2005-02-08 | 285 | 2005-02-07 | 2005-02-08 | 1d | 139.5d | 0d | {C563C028-5C7C-42AA-8BD2-703F44FB84CF} |
| 287 | 6.1.3.4 | Finalize plan revisions |  | 1d | 2005-02-08 | 2005-02-09 | 286 | 2005-02-08 | 2005-02-09 | 1d | 139.5d | 0d | {FB9B89A1-63DD-42DA-8DBE-9B45902A3DF3} |
| 288 | 6.1.3.5 | Approve revised subproject plan | milestone | 0d | 2005-02-09 | 2005-02-09 | 287 | 2005-02-09 | 2005-02-09 | 0d | 139.5d |  | {0083DF27-85EF-48A3-83FC-F5AAF48361EC} |

Notes:
- 260: Text3: <sync-guid>{251D006B-CE12-4B1E-B7B2-31F926C90698}</sync-guid><sync-parentguid>{085DC560-8D0C-42FA-9268-81ECF2E5129D}</sync-parentguid><sync-checksum>519084521</sync-checksum><sync-rootid>0</sync-rootid><sync-itemtype>0</sync-itemtype><sync-timestamp>12/30 / Text5: 2004 1:12:25 PM</sync-timestamp><sync-itemid>198</sync-itemid><sync-prioritymapping>0:0-0/1:700-1000/2:300-699/3:1-299</sync-prioritymapping>
- 261: Text3: <sync-guid>{013EC5BE-592A-48AC-B32A-5D6AC65EFCAA}</sync-guid><sync-parentguid>{251D006B-CE12-4B1E-B7B2-31F926C90698}</sync-parentguid><sync-checksum>671337386</sync-checksum><sync-rootid>0</sync-rootid><sync-itemtype>0</sync-itemtype><sync-timestamp>12/30 / Text5: 2004 1:12:25 PM</sync-timestamp><sync-itemid>368</sync-itemid><sync-prioritymapping>0:0-0/1:700-1000/2:300-699/3:1-299</sync-prioritymapping>
- 262: Text3: <sync-guid>{45F40DAD-9916-4C7B-8133-7A2D8AC1C156}</sync-guid><sync-parentguid>{251D006B-CE12-4B1E-B7B2-31F926C90698}</sync-parentguid><sync-checksum>396295279</sync-checksum><sync-rootid>0</sync-rootid><sync-itemtype>0</sync-itemtype><sync-timestamp>12/30 / Text5: 2004 1:12:25 PM</sync-timestamp><sync-itemid>367</sync-itemid><sync-prioritymapping>0:0-0/1:700-1000/2:300-699/3:1-299</sync-prioritymapping>
- 263: Text3: <sync-guid>{CC7A1991-EB34-465F-8192-70057BF3A218}</sync-guid><sync-parentguid>{251D006B-CE12-4B1E-B7B2-31F926C90698}</sync-parentguid><sync-checksum>43604628</sync-checksum><sync-rootid>0</sync-rootid><sync-itemtype>0</sync-itemtype><sync-timestamp>12/30 / Text5: 2004 1:12:25 PM</sync-timestamp><sync-itemid>366</sync-itemid><sync-prioritymapping>0:0-0/1:700-1000/2:300-699/3:1-299</sync-prioritymapping>
- 264: Text3: <sync-guid>{8DC27076-759D-4C40-A965-27D53E06A4C3}</sync-guid><sync-parentguid>{251D006B-CE12-4B1E-B7B2-31F926C90698}</sync-parentguid><sync-checksum>2061994154</sync-checksum><sync-rootid>0</sync-rootid><sync-itemtype>0</sync-itemtype><sync-timestamp>12/3 / Text5: 0/2004 1:12:25 PM</sync-timestamp><sync-itemid>365</sync-itemid><sync-prioritymapping>0:0-0/1:700-1000/2:300-699/3:1-299</sync-prioritymapping>
- 265: Text3: <sync-guid>{3998F45B-D004-45B0-86F4-4FF2FF6E80E3}</sync-guid><sync-parentguid>{251D006B-CE12-4B1E-B7B2-31F926C90698}</sync-parentguid><sync-checksum>1294169566</sync-checksum><sync-rootid>0</sync-rootid><sync-itemtype>0</sync-itemtype><sync-timestamp>12/3 / Text5: 0/2004 1:12:25 PM</sync-timestamp><sync-itemid>364</sync-itemid><sync-prioritymapping>0:0-0/1:700-1000/2:300-699/3:1-299</sync-prioritymapping>
- 266: Text3: <sync-guid>{2B2817F9-76F5-4CDD-8182-CF152760D6BB}</sync-guid><sync-parentguid>{69CAB05D-8790-4A69-A093-1D8EDB5A2679}</sync-parentguid><sync-checksum>811734976</sync-checksum><sync-rootid>0</sync-rootid><sync-itemtype>0</sync-itemtype><sync-timestamp>12/30 / Text5: 2004 1:13:02 PM</sync-timestamp><sync-itemid>243</sync-itemid><sync-prioritymapping>0:0-0/1:700-1000/2:300-699/3:1-299</sync-prioritymapping>
- 267: Text3: <sync-guid>{3F24235F-9AD8-4ADA-8120-06887728D4F4}</sync-guid><sync-parentguid>{2B2817F9-76F5-4CDD-8182-CF152760D6BB}</sync-parentguid><sync-checksum>-1435854722</sync-checksum><sync-rootid>0</sync-rootid><sync-itemtype>0</sync-itemtype><sync-timestamp>12 / Text5: 30/2004 1:12:27 PM</sync-timestamp><sync-itemid>244</sync-itemid><sync-prioritymapping>0:0-0/1:700-1000/2:300-699/3:1-299</sync-prioritymapping>
- 268: Text3: <sync-guid>{CC640DD0-C597-42B1-BF01-20D92DF70E20}</sync-guid><sync-parentguid>{3F24235F-9AD8-4ADA-8120-06887728D4F4}</sync-parentguid><sync-checksum>1325342027</sync-checksum><sync-rootid>0</sync-rootid><sync-itemtype>0</sync-itemtype><sync-timestamp>12/2 / Text5: 1/2004 9:44:43 AM</sync-timestamp><sync-itemid>981</sync-itemid><sync-prioritymapping>0:0-0/1:700-1000/2:300-699/3:1-299</sync-prioritymapping>
- 269: Text3: <sync-guid>{901769CC-57E4-40CC-8F92-D341AE6A4438}</sync-guid><sync-parentguid>{CC640DD0-C597-42B1-BF01-20D92DF70E20}</sync-parentguid><sync-checksum>387006786</sync-checksum><sync-rootid>0</sync-rootid><sync-itemtype>0</sync-itemtype><sync-timestamp>12/21 / Text5: 2004 9:44:44 AM</sync-timestamp><sync-itemid>245</sync-itemid><sync-prioritymapping>0:0-0/1:700-1000/2:300-699/3:1-299</sync-prioritymapping>
- 270: Text3: <sync-guid>{4956EE52-FE7F-4769-AFBE-74E66F75BAE1}</sync-guid><sync-parentguid>{CC640DD0-C597-42B1-BF01-20D92DF70E20}</sync-parentguid><sync-checksum>271800158</sync-checksum><sync-rootid>0</sync-rootid><sync-itemtype>0</sync-itemtype><sync-timestamp>12/30 / Text5: 2004 1:12:26 PM</sync-timestamp><sync-itemid>1042</sync-itemid><sync-prioritymapping>0:0-0/1:700-1000/2:300-699/3:1-299</sync-prioritymapping>
- 271: Text3: <sync-guid>{90B51A0D-2007-4A4A-8955-6395655F6ABA}</sync-guid><sync-parentguid>{4956EE52-FE7F-4769-AFBE-74E66F75BAE1}</sync-parentguid><sync-checksum>-667521953</sync-checksum><sync-rootid>0</sync-rootid><sync-itemtype>0</sync-itemtype><sync-timestamp>12/2 / Text5: 1/2004 9:44:44 AM</sync-timestamp><sync-itemid>1044</sync-itemid><sync-prioritymapping>0:0-0/1:700-1000/2:300-699/3:1-299</sync-prioritymapping>
- 272: Text3: <sync-guid>{EF5D3E0C-D920-4885-AD09-F5B0EDEC6DC3}</sync-guid><sync-parentguid>{4956EE52-FE7F-4769-AFBE-74E66F75BAE1}</sync-parentguid><sync-checksum>1505592696</sync-checksum><sync-rootid>0</sync-rootid><sync-itemtype>0</sync-itemtype><sync-timestamp>12/2 / Text5: 1/2004 9:44:44 AM</sync-timestamp><sync-itemid>1045</sync-itemid><sync-prioritymapping>0:0-0/1:700-1000/2:300-699/3:1-299</sync-prioritymapping>
- 273: Text3: <sync-guid>{F16B63D2-97D4-4B9C-8BF5-63DC4267DD18}</sync-guid><sync-parentguid>{4956EE52-FE7F-4769-AFBE-74E66F75BAE1}</sync-parentguid><sync-checksum>-1381548439</sync-checksum><sync-rootid>0</sync-rootid><sync-itemtype>0</sync-itemtype><sync-timestamp>12 / Text5: 21/2004 9:44:44 AM</sync-timestamp><sync-itemid>1043</sync-itemid><sync-prioritymapping>0:0-0/1:700-1000/2:300-699/3:1-299</sync-prioritymapping>
- 274: Text3: <sync-guid>{079556ED-5CA8-42D1-9D9E-4680EF79E285}</sync-guid><sync-parentguid>{4956EE52-FE7F-4769-AFBE-74E66F75BAE1}</sync-parentguid><sync-checksum>-1130542981</sync-checksum><sync-rootid>0</sync-rootid><sync-itemtype>0</sync-itemtype><sync-timestamp>12 / Text5: 21/2004 9:44:44 AM</sync-timestamp><sync-itemid>1046</sync-itemid><sync-prioritymapping>0:0-0/1:700-1000/2:300-699/3:1-299</sync-prioritymapping>
- 275: Text3: <sync-guid>{A18CD4F7-3240-4CF2-8449-D4269D9EA87A}</sync-guid><sync-parentguid>{CC640DD0-C597-42B1-BF01-20D92DF70E20}</sync-parentguid><sync-checksum>2079834502</sync-checksum><sync-rootid>0</sync-rootid><sync-itemtype>0</sync-itemtype><sync-timestamp>12/2 / Text5: 1/2004 9:44:44 AM</sync-timestamp><sync-itemid>246</sync-itemid><sync-prioritymapping>0:0-0/1:700-1000/2:300-699/3:1-299</sync-prioritymapping>
- 276: Text3: <sync-guid>{BBD826A4-7285-4AF5-B760-397F6A253D0E}</sync-guid><sync-parentguid>{CC640DD0-C597-42B1-BF01-20D92DF70E20}</sync-parentguid><sync-checksum>-180723632</sync-checksum><sync-rootid>0</sync-rootid><sync-itemtype>0</sync-itemtype><sync-timestamp>12/2 / Text5: 1/2004 9:44:44 AM</sync-timestamp><sync-itemid>247</sync-itemid><sync-prioritymapping>0:0-0/1:700-1000/2:300-699/3:1-299</sync-prioritymapping>
- 277: Text3: <sync-guid>{C2B2A734-E259-416D-BFFF-45C42B1AB76E}</sync-guid><sync-parentguid>{3F24235F-9AD8-4ADA-8120-06887728D4F4}</sync-parentguid><sync-checksum>-1146240636</sync-checksum><sync-rootid>0</sync-rootid><sync-itemtype>0</sync-itemtype><sync-timestamp>12 / Text5: 21/2004 9:44:44 AM</sync-timestamp><sync-itemid>248</sync-itemid><sync-prioritymapping>0:0-0/1:700-1000/2:300-699/3:1-299</sync-prioritymapping>
- 278: Text3: <sync-guid>{210A7C0E-85AA-4EE0-948D-5847B54E2E86}</sync-guid><sync-parentguid>{C2B2A734-E259-416D-BFFF-45C42B1AB76E}</sync-parentguid><sync-checksum>34332667</sync-checksum><sync-rootid>0</sync-rootid><sync-itemtype>0</sync-itemtype><sync-timestamp>12/21 / Text5: 2004 9:44:44 AM</sync-timestamp><sync-itemid>249</sync-itemid><sync-prioritymapping>0:0-0/1:700-1000/2:300-699/3:1-299</sync-prioritymapping>
- 279: Text3: <sync-guid>{B254C7FC-9A71-4985-AE92-45697F09B09F}</sync-guid><sync-parentguid>{C2B2A734-E259-416D-BFFF-45C42B1AB76E}</sync-parentguid><sync-checksum>-534598330</sync-checksum><sync-rootid>0</sync-rootid><sync-itemtype>0</sync-itemtype><sync-timestamp>12/2 / Text5: 1/2004 9:44:44 AM</sync-timestamp><sync-itemid>250</sync-itemid><sync-prioritymapping>0:0-0/1:700-1000/2:300-699/3:1-299</sync-prioritymapping>
- 280: Text3: <sync-guid>{A9CB1594-D072-453C-BE86-A80CF9B818E0}</sync-guid><sync-parentguid>{C2B2A734-E259-416D-BFFF-45C42B1AB76E}</sync-parentguid><sync-checksum>1354200628</sync-checksum><sync-rootid>0</sync-rootid><sync-itemtype>0</sync-itemtype><sync-timestamp>12/2 / Text5: 1/2004 9:44:44 AM</sync-timestamp><sync-itemid>251</sync-itemid><sync-prioritymapping>0:0-0/1:700-1000/2:300-699/3:1-299</sync-prioritymapping>
- 281: Text3: <sync-guid>{5CCC1765-1E76-4766-BF39-036E4B69BC73}</sync-guid><sync-parentguid>{C2B2A734-E259-416D-BFFF-45C42B1AB76E}</sync-parentguid><sync-checksum>469127966</sync-checksum><sync-rootid>0</sync-rootid><sync-itemtype>0</sync-itemtype><sync-timestamp>12/21 / Text5: 2004 9:44:45 AM</sync-timestamp><sync-itemid>252</sync-itemid><sync-prioritymapping>0:0-0/1:700-1000/2:300-699/3:1-299</sync-prioritymapping>
- 282: Text3: <sync-guid>{FEADA928-86DB-4C04-9ACF-A1185B5DEB51}</sync-guid><sync-parentguid>{C2B2A734-E259-416D-BFFF-45C42B1AB76E}</sync-parentguid><sync-checksum>-1092660189</sync-checksum><sync-rootid>0</sync-rootid><sync-itemtype>0</sync-itemtype><sync-timestamp>12 / Text5: 21/2004 9:44:45 AM</sync-timestamp><sync-itemid>253</sync-itemid><sync-prioritymapping>0:0-0/1:700-1000/2:300-699/3:1-299</sync-prioritymapping>
- 283: Text3: <sync-guid>{E6CC990F-723C-4A62-88F3-D29DDF2A3247}</sync-guid><sync-parentguid>{3F24235F-9AD8-4ADA-8120-06887728D4F4}</sync-parentguid><sync-checksum>992316374</sync-checksum><sync-rootid>0</sync-rootid><sync-itemtype>0</sync-itemtype><sync-timestamp>12/21 / Text5: 2004 9:44:45 AM</sync-timestamp><sync-itemid>651</sync-itemid><sync-prioritymapping>0:0-0/1:700-1000/2:300-699/3:1-299</sync-prioritymapping>
- 284: Text3: <sync-guid>{707CCA79-E316-404D-ADEA-D111D934604F}</sync-guid><sync-parentguid>{E6CC990F-723C-4A62-88F3-D29DDF2A3247}</sync-parentguid><sync-checksum>43506217</sync-checksum><sync-rootid>0</sync-rootid><sync-itemtype>0</sync-itemtype><sync-timestamp>12/21 / Text5: 2004 9:44:45 AM</sync-timestamp><sync-itemid>650</sync-itemid><sync-prioritymapping>0:0-0/1:700-1000/2:300-699/3:1-299</sync-prioritymapping>
- 285: Text3: <sync-guid>{E8949D23-2682-4D44-9386-2C42EF72B989}</sync-guid><sync-parentguid>{E6CC990F-723C-4A62-88F3-D29DDF2A3247}</sync-parentguid><sync-checksum>-806061485</sync-checksum><sync-rootid>0</sync-rootid><sync-itemtype>0</sync-itemtype><sync-timestamp>12/2 / Text5: 1/2004 9:44:45 AM</sync-timestamp><sync-itemid>649</sync-itemid><sync-prioritymapping>0:0-0/1:700-1000/2:300-699/3:1-299</sync-prioritymapping>
- 286: Text3: <sync-guid>{C563C028-5C7C-42AA-8BD2-703F44FB84CF}</sync-guid><sync-parentguid>{E6CC990F-723C-4A62-88F3-D29DDF2A3247}</sync-parentguid><sync-checksum>1510142956</sync-checksum><sync-rootid>0</sync-rootid><sync-itemtype>0</sync-itemtype><sync-timestamp>12/2 / Text5: 1/2004 9:44:45 AM</sync-timestamp><sync-itemid>648</sync-itemid><sync-prioritymapping>0:0-0/1:700-1000/2:300-699/3:1-299</sync-prioritymapping>
- 287: Text3: <sync-guid>{FB9B89A1-63DD-42DA-8DBE-9B45902A3DF3}</sync-guid><sync-parentguid>{E6CC990F-723C-4A62-88F3-D29DDF2A3247}</sync-parentguid><sync-checksum>-157576747</sync-checksum><sync-rootid>0</sync-rootid><sync-itemtype>0</sync-itemtype><sync-timestamp>12/2 / Text5: 1/2004 9:44:45 AM</sync-timestamp><sync-itemid>647</sync-itemid><sync-prioritymapping>0:0-0/1:700-1000/2:300-699/3:1-299</sync-prioritymapping>
- 288: Text3: <sync-guid>{0083DF27-85EF-48A3-83FC-F5AAF48361EC}</sync-guid><sync-parentguid>{E6CC990F-723C-4A62-88F3-D29DDF2A3247}</sync-parentguid><sync-checksum>1107768153</sync-checksum><sync-rootid>0</sync-rootid><sync-itemtype>0</sync-itemtype><sync-timestamp>12/2 / Text5: 1/2004 9:44:45 AM</sync-timestamp><sync-itemid>646</sync-itemid><sync-prioritymapping>0:0-0/1:700-1000/2:300-699/3:1-299</sync-prioritymapping>

| ID | WBS | Task | Duration | Start | Finish | Predecessors | Baseline start | Baseline finish | Baseline duration | Total slack | Free slack | Text4 |
| --- | --- | --- | --- | --- | --- | --- | --- | --- | --- | --- | --- | --- |
| 289 | 6.1.4 | **Conduct phase QA assessment** | 2d | 2005-02-16 | 2005-02-18 | 277 | 2005-02-16 | 2005-02-18 | 2d | 132.5d |  | {7086324D-AAFC-4DA5-A946-AB704C0AF636} |
| 290 | 6.1.4.1 | Consolidate phase results | 0.5d | 2005-02-16 | 2005-02-16 |  | 2005-02-16 | 2005-02-16 | 0.5d | 132.5d | 0d | {E671D749-463F-42F0-9C6D-718D499E7A10} |
| 291 | 6.1.4.2 | Conduct phase self-assessment | 0.25d | 2005-02-17 | 2005-02-17 | 290 | 2005-02-17 | 2005-02-17 | 0.25d | 132.5d | 0d | {2AAD8D73-7FB1-4E84-9362-188D093203DF} |
| 292 | 6.1.4.3 | Conduct QA assessment | 0.5d | 2005-02-17 | 2005-02-17 | 291 | 2005-02-17 | 2005-02-17 | 0.5d | 132.5d | 0d | {95269652-04FC-4FDB-802F-866095413EAD} |
| 293 | 6.1.4.4 | Review assessment feedback | 0.25d | 2005-02-17 | 2005-02-17 | 292 | 2005-02-17 | 2005-02-17 | 0.25d | 132.5d | 0d | {C411B2C6-9966-4174-96C8-195AD61243D5} |
| 294 | 6.1.4.5 | Implement QA feedback | 0.5d | 2005-02-18 | 2005-02-18 | 293 | 2005-02-18 | 2005-02-18 | 0.5d | 132.5d |  | {4F2C9D8D-15D1-45B4-9147-EAFF476659D9} |
| 295 | 6.2 | **ANALYSIS** | 37d | 2005-02-03 | 2005-03-28 |  | 2005-02-03 | 2005-03-28 | 37d | 106.5d |  | {C262EF5A-5F48-4212-9B7E-5E84299355EC} |
| 296 | 6.2.1 | **Define business requirements** | 7d | 2005-02-03 | 2005-02-14 |  | 2005-02-03 | 2005-02-14 | 7d | 106.5d | 3d | {15777315-E2E9-4DA3-BBED-7FBCD6591EA6} |
| 297 | 6.2.1.1 | Elicit initial business requirements | 1d | 2005-02-03 | 2005-02-04 |  | 2005-02-03 | 2005-02-04 | 1d | 106.5d | 0d | {457CBEF8-C424-4681-AAE2-E35DCF9E3382} |
| 298 | 6.2.1.2 | Prepare draft business requirements | 1d | 2005-02-04 | 2005-02-07 | 297 | 2005-02-04 | 2005-02-07 | 1d | 106.5d | 0d | {495A5AC3-A1D4-4BD9-92B2-2D0C12CFA15D} |
| 299 | 6.2.1.3 | Review draft requirements with team | 1d | 2005-02-07 | 2005-02-08 | 298 | 2005-02-07 | 2005-02-08 | 1d | 106.5d | 0d | {4B511E7D-9635-4D40-8326-FFD748703D60} |
| 300 | 6.2.1.4 | Conduct further business analysis | 1d | 2005-02-08 | 2005-02-09 | 299 | 2005-02-08 | 2005-02-09 | 1d | 109.5d | 0d | {E77DEAEB-1DA5-4943-BCB8-20F956FB077B} |
| 301 | 6.2.1.5 | Refine draft business requirements | 1d | 2005-02-09 | 2005-02-10 | 300 | 2005-02-09 | 2005-02-10 | 1d | 109.5d | 0d | {89E45624-4F24-4126-98AC-C735EE912631} |
| 302 | 6.2.1.6 | Review business reqts with stakeholders | 1d | 2005-02-10 | 2005-02-11 | 301 | 2005-02-10 | 2005-02-11 | 1d | 109.5d | 0d | {820432B3-F782-4A15-9147-F6733E05F3B0} |
| 303 | 6.2.1.7 | Apply business requirements feedback | 1d | 2005-02-11 | 2005-02-14 | 302 | 2005-02-11 | 2005-02-14 | 1d | 109.5d |  | {F23C7AD9-BDEA-4FED-A90B-43A246881CA0} |
| 304 | 6.2.2 | **Define data requirements** | 7d | 2005-02-08 | 2005-02-17 | 299 | 2005-02-08 | 2005-02-17 | 7d | 106.5d | 0d | {FE356C94-0CD6-47E4-8F13-E319F4D3890E} |
| 305 | 6.2.2.1 | Elicit initial data requirements | 1d | 2005-02-08 | 2005-02-09 |  | 2005-02-08 | 2005-02-09 | 1d | 106.5d | 0d | {AC6EA58B-430A-4584-AB3A-DF891968AD7B} |
| 306 | 6.2.2.2 | Prepare draft data requirements | 1d | 2005-02-09 | 2005-02-10 | 305 | 2005-02-09 | 2005-02-10 | 1d | 106.5d | 0d | {6ED44F36-71D3-42CC-90D9-9A4745EED623} |
| 307 | 6.2.2.3 | Review draft data requirements with team | 1d | 2005-02-10 | 2005-02-11 | 306 | 2005-02-10 | 2005-02-11 | 1d | 106.5d | 0d | {6154203A-C149-4DDF-BEAA-DE60813F7334} |
| 308 | 6.2.2.4 | Conduct further data analysis | 1d | 2005-02-11 | 2005-02-14 | 307 | 2005-02-11 | 2005-02-14 | 1d | 106.5d | 0d | {FEF6472B-A611-41D7-AD13-E8928F84BFAC} |
| 309 | 6.2.2.5 | Refine draft data requirements | 1d | 2005-02-14 | 2005-02-15 | 308 | 2005-02-14 | 2005-02-15 | 1d | 106.5d | 0d | {330A045B-BFAD-4F8E-B0C6-513A2C6BDB33} |
| 310 | 6.2.2.6 | Review data reqts with stakeholders | 1d | 2005-02-15 | 2005-02-16 | 309 | 2005-02-15 | 2005-02-16 | 1d | 106.5d | 0d | {C104B365-8730-438D-B388-25DCB4927C8C} |
| 311 | 6.2.2.7 | Apply data requirements feedback | 1d | 2005-02-16 | 2005-02-17 | 310 | 2005-02-16 | 2005-02-17 | 1d | 106.5d |  | {7E787811-FFC2-4A20-B924-BDAE4A4B7495} |
| 312 | 6.2.3 | **Define processing requirements** | 7d | 2005-02-08 | 2005-02-17 | 299 | 2005-02-08 | 2005-02-17 | 7d | 106.5d | 0d | {C6E15D20-CC62-4016-B549-A805296C9512} |
| 313 | 6.2.3.1 | Elicit initial processing requirements | 1d | 2005-02-08 | 2005-02-09 |  | 2005-02-08 | 2005-02-09 | 1d | 106.5d | 0d | {FC077322-8F05-4415-A782-160C2EACA18C} |
| 314 | 6.2.3.2 | Prepare draft processing requirements | 1d | 2005-02-09 | 2005-02-10 | 313 | 2005-02-09 | 2005-02-10 | 1d | 106.5d | 0d | {B6A62C33-0453-4A07-995E-D2725A5ED983} |
| 315 | 6.2.3.3 | Review draft processing reqts with team | 1d | 2005-02-10 | 2005-02-11 | 314 | 2005-02-10 | 2005-02-11 | 1d | 106.5d | 0d | {5DE34EE6-4BC1-46E3-AEFD-F5DD5B7D7D94} |
| 316 | 6.2.3.4 | Conduct further processing analysis | 1d | 2005-02-11 | 2005-02-14 | 315 | 2005-02-11 | 2005-02-14 | 1d | 106.5d | 0d | {CCE78B16-3DEB-4557-A552-8E07CE7002D2} |
| 317 | 6.2.3.5 | Refine draft processing requirements | 1d | 2005-02-14 | 2005-02-15 | 316 | 2005-02-14 | 2005-02-15 | 1d | 106.5d | 0d | {FEC8BF9A-4C9A-4334-BB6E-81E8A7D949E6} |
| 318 | 6.2.3.6 | Review processing reqts with stakeholders | 1d | 2005-02-15 | 2005-02-16 | 317 | 2005-02-15 | 2005-02-16 | 1d | 106.5d | 0d | {A6087256-E69B-4F76-A664-64FE77B99737} |
| 319 | 6.2.3.7 | Apply processing requirements feedback | 1d | 2005-02-16 | 2005-02-17 | 318 | 2005-02-16 | 2005-02-17 | 1d | 106.5d |  | {18387316-2593-47C1-8DA3-8833C10A0A17} |

Notes:
- 289: Text3: <sync-guid>{7086324D-AAFC-4DA5-A946-AB704C0AF636}</sync-guid><sync-parentguid>{3F24235F-9AD8-4ADA-8120-06887728D4F4}</sync-parentguid><sync-checksum>-2114493810</sync-checksum><sync-rootid>0</sync-rootid><sync-itemtype>0</sync-itemtype><sync-timestamp>12 / Text5: 30/2004 1:12:27 PM</sync-timestamp><sync-itemid>369</sync-itemid><sync-prioritymapping>0:0-0/1:700-1000/2:300-699/3:1-299</sync-prioritymapping>
- 290: Text3: <sync-guid>{E671D749-463F-42F0-9C6D-718D499E7A10}</sync-guid><sync-parentguid>{7086324D-AAFC-4DA5-A946-AB704C0AF636}</sync-parentguid><sync-checksum>1497934049</sync-checksum><sync-rootid>0</sync-rootid><sync-itemtype>0</sync-itemtype><sync-timestamp>12/3 / Text5: 0/2004 1:09:16 PM</sync-timestamp><sync-itemid>1088</sync-itemid><sync-prioritymapping>0:0-0/1:700-1000/2:300-699/3:1-299</sync-prioritymapping>
- 291: Text3: <sync-guid>{2AAD8D73-7FB1-4E84-9362-188D093203DF}</sync-guid><sync-parentguid>{7086324D-AAFC-4DA5-A946-AB704C0AF636}</sync-parentguid><sync-checksum>1998861361</sync-checksum><sync-rootid>0</sync-rootid><sync-itemtype>0</sync-itemtype><sync-timestamp>12/3 / Text5: 0/2004 1:09:16 PM</sync-timestamp><sync-itemid>1087</sync-itemid><sync-prioritymapping>0:0-0/1:700-1000/2:300-699/3:1-299</sync-prioritymapping>
- 292: Text3: <sync-guid>{95269652-04FC-4FDB-802F-866095413EAD}</sync-guid><sync-parentguid>{7086324D-AAFC-4DA5-A946-AB704C0AF636}</sync-parentguid><sync-checksum>-368080329</sync-checksum><sync-rootid>0</sync-rootid><sync-itemtype>0</sync-itemtype><sync-timestamp>12/3 / Text5: 0/2004 1:09:16 PM</sync-timestamp><sync-itemid>1086</sync-itemid><sync-prioritymapping>0:0-0/1:700-1000/2:300-699/3:1-299</sync-prioritymapping>
- 293: Text3: <sync-guid>{C411B2C6-9966-4174-96C8-195AD61243D5}</sync-guid><sync-parentguid>{7086324D-AAFC-4DA5-A946-AB704C0AF636}</sync-parentguid><sync-checksum>-1163666920</sync-checksum><sync-rootid>0</sync-rootid><sync-itemtype>0</sync-itemtype><sync-timestamp>12 / Text5: 30/2004 1:09:16 PM</sync-timestamp><sync-itemid>1085</sync-itemid><sync-prioritymapping>0:0-0/1:700-1000/2:300-699/3:1-299</sync-prioritymapping>
- 294: Text3: <sync-guid>{4F2C9D8D-15D1-45B4-9147-EAFF476659D9}</sync-guid><sync-parentguid>{7086324D-AAFC-4DA5-A946-AB704C0AF636}</sync-parentguid><sync-checksum>1271633914</sync-checksum><sync-rootid>0</sync-rootid><sync-itemtype>0</sync-itemtype><sync-timestamp>12/3 / Text5: 0/2004 1:09:16 PM</sync-timestamp><sync-itemid>1084</sync-itemid><sync-prioritymapping>0:0-0/1:700-1000/2:300-699/3:1-299</sync-prioritymapping>
- 295: Text3: <sync-guid>{C262EF5A-5F48-4212-9B7E-5E84299355EC}</sync-guid><sync-parentguid>{2B2817F9-76F5-4CDD-8182-CF152760D6BB}</sync-parentguid><sync-checksum>-1148033595</sync-checksum><sync-rootid>0</sync-rootid><sync-itemtype>0</sync-itemtype><sync-timestamp>12 / Text5: 30/2004 1:12:34 PM</sync-timestamp><sync-itemid>254</sync-itemid><sync-prioritymapping>0:0-0/1:700-1000/2:300-699/3:1-299</sync-prioritymapping>
- 296: Text3: <sync-guid>{15777315-E2E9-4DA3-BBED-7FBCD6591EA6}</sync-guid><sync-parentguid>{C262EF5A-5F48-4212-9B7E-5E84299355EC}</sync-parentguid><sync-checksum>992503090</sync-checksum><sync-rootid>0</sync-rootid><sync-itemtype>0</sync-itemtype><sync-timestamp>12/21 / Text5: 2004 9:44:45 AM</sync-timestamp><sync-itemid>255</sync-itemid><sync-prioritymapping>0:0-0/1:700-1000/2:300-699/3:1-299</sync-prioritymapping>
- 297: Text3: <sync-guid>{457CBEF8-C424-4681-AAE2-E35DCF9E3382}</sync-guid><sync-parentguid>{15777315-E2E9-4DA3-BBED-7FBCD6591EA6}</sync-parentguid><sync-checksum>1786898674</sync-checksum><sync-rootid>0</sync-rootid><sync-itemtype>0</sync-itemtype><sync-timestamp>12/2 / Text5: 1/2004 9:44:45 AM</sync-timestamp><sync-itemid>257</sync-itemid><sync-prioritymapping>0:0-0/1:700-1000/2:300-699/3:1-299</sync-prioritymapping>
- 298: Text3: <sync-guid>{495A5AC3-A1D4-4BD9-92B2-2D0C12CFA15D}</sync-guid><sync-parentguid>{15777315-E2E9-4DA3-BBED-7FBCD6591EA6}</sync-parentguid><sync-checksum>-577834222</sync-checksum><sync-rootid>0</sync-rootid><sync-itemtype>0</sync-itemtype><sync-timestamp>12/2 / Text5: 1/2004 9:44:46 AM</sync-timestamp><sync-itemid>269</sync-itemid><sync-prioritymapping>0:0-0/1:700-1000/2:300-699/3:1-299</sync-prioritymapping>
- 299: Text3: <sync-guid>{4B511E7D-9635-4D40-8326-FFD748703D60}</sync-guid><sync-parentguid>{15777315-E2E9-4DA3-BBED-7FBCD6591EA6}</sync-parentguid><sync-checksum>-1282011274</sync-checksum><sync-rootid>0</sync-rootid><sync-itemtype>0</sync-itemtype><sync-timestamp>12 / Text5: 21/2004 9:44:46 AM</sync-timestamp><sync-itemid>270</sync-itemid><sync-prioritymapping>0:0-0/1:700-1000/2:300-699/3:1-299</sync-prioritymapping>
- 300: Text3: <sync-guid>{E77DEAEB-1DA5-4943-BCB8-20F956FB077B}</sync-guid><sync-parentguid>{15777315-E2E9-4DA3-BBED-7FBCD6591EA6}</sync-parentguid><sync-checksum>-2021585971</sync-checksum><sync-rootid>0</sync-rootid><sync-itemtype>0</sync-itemtype><sync-timestamp>12 / Text5: 21/2004 9:44:46 AM</sync-timestamp><sync-itemid>272</sync-itemid><sync-prioritymapping>0:0-0/1:700-1000/2:300-699/3:1-299</sync-prioritymapping>
- 301: Text3: <sync-guid>{89E45624-4F24-4126-98AC-C735EE912631}</sync-guid><sync-parentguid>{15777315-E2E9-4DA3-BBED-7FBCD6591EA6}</sync-parentguid><sync-checksum>1477776415</sync-checksum><sync-rootid>0</sync-rootid><sync-itemtype>0</sync-itemtype><sync-timestamp>12/2 / Text5: 1/2004 9:44:46 AM</sync-timestamp><sync-itemid>273</sync-itemid><sync-prioritymapping>0:0-0/1:700-1000/2:300-699/3:1-299</sync-prioritymapping>
- 302: Text3: <sync-guid>{820432B3-F782-4A15-9147-F6733E05F3B0}</sync-guid><sync-parentguid>{15777315-E2E9-4DA3-BBED-7FBCD6591EA6}</sync-parentguid><sync-checksum>-336042284</sync-checksum><sync-rootid>0</sync-rootid><sync-itemtype>0</sync-itemtype><sync-timestamp>12/2 / Text5: 1/2004 9:44:46 AM</sync-timestamp><sync-itemid>274</sync-itemid><sync-prioritymapping>0:0-0/1:700-1000/2:300-699/3:1-299</sync-prioritymapping>
- 303: Text3: <sync-guid>{F23C7AD9-BDEA-4FED-A90B-43A246881CA0}</sync-guid><sync-parentguid>{15777315-E2E9-4DA3-BBED-7FBCD6591EA6}</sync-parentguid><sync-checksum>1317177417</sync-checksum><sync-rootid>0</sync-rootid><sync-itemtype>0</sync-itemtype><sync-timestamp>12/2 / Text5: 1/2004 9:44:46 AM</sync-timestamp><sync-itemid>982</sync-itemid><sync-prioritymapping>0:0-0/1:700-1000/2:300-699/3:1-299</sync-prioritymapping>
- 304: Text3: <sync-guid>{FE356C94-0CD6-47E4-8F13-E319F4D3890E}</sync-guid><sync-parentguid>{C262EF5A-5F48-4212-9B7E-5E84299355EC}</sync-parentguid><sync-checksum>-649959419</sync-checksum><sync-rootid>0</sync-rootid><sync-itemtype>0</sync-itemtype><sync-timestamp>12/2 / Text5: 1/2004 9:44:46 AM</sync-timestamp><sync-itemid>451</sync-itemid><sync-prioritymapping>0:0-0/1:700-1000/2:300-699/3:1-299</sync-prioritymapping>
- 305: Text3: <sync-guid>{AC6EA58B-430A-4584-AB3A-DF891968AD7B}</sync-guid><sync-parentguid>{FE356C94-0CD6-47E4-8F13-E319F4D3890E}</sync-parentguid><sync-checksum>-303429647</sync-checksum><sync-rootid>0</sync-rootid><sync-itemtype>0</sync-itemtype><sync-timestamp>12/2 / Text5: 1/2004 9:44:46 AM</sync-timestamp><sync-itemid>450</sync-itemid><sync-prioritymapping>0:0-0/1:700-1000/2:300-699/3:1-299</sync-prioritymapping>
- 306: Text3: <sync-guid>{6ED44F36-71D3-42CC-90D9-9A4745EED623}</sync-guid><sync-parentguid>{FE356C94-0CD6-47E4-8F13-E319F4D3890E}</sync-parentguid><sync-checksum>-1326318183</sync-checksum><sync-rootid>0</sync-rootid><sync-itemtype>0</sync-itemtype><sync-timestamp>12 / Text5: 21/2004 9:44:46 AM</sync-timestamp><sync-itemid>449</sync-itemid><sync-prioritymapping>0:0-0/1:700-1000/2:300-699/3:1-299</sync-prioritymapping>
- 307: Text3: <sync-guid>{6154203A-C149-4DDF-BEAA-DE60813F7334}</sync-guid><sync-parentguid>{FE356C94-0CD6-47E4-8F13-E319F4D3890E}</sync-parentguid><sync-checksum>1637570087</sync-checksum><sync-rootid>0</sync-rootid><sync-itemtype>0</sync-itemtype><sync-timestamp>12/2 / Text5: 1/2004 9:44:46 AM</sync-timestamp><sync-itemid>448</sync-itemid><sync-prioritymapping>0:0-0/1:700-1000/2:300-699/3:1-299</sync-prioritymapping>
- 308: Text3: <sync-guid>{FEF6472B-A611-41D7-AD13-E8928F84BFAC}</sync-guid><sync-parentguid>{FE356C94-0CD6-47E4-8F13-E319F4D3890E}</sync-parentguid><sync-checksum>1922698882</sync-checksum><sync-rootid>0</sync-rootid><sync-itemtype>0</sync-itemtype><sync-timestamp>12/2 / Text5: 1/2004 9:44:46 AM</sync-timestamp><sync-itemid>447</sync-itemid><sync-prioritymapping>0:0-0/1:700-1000/2:300-699/3:1-299</sync-prioritymapping>
- 309: Text3: <sync-guid>{330A045B-BFAD-4F8E-B0C6-513A2C6BDB33}</sync-guid><sync-parentguid>{FE356C94-0CD6-47E4-8F13-E319F4D3890E}</sync-parentguid><sync-checksum>-730828559</sync-checksum><sync-rootid>0</sync-rootid><sync-itemtype>0</sync-itemtype><sync-timestamp>12/2 / Text5: 1/2004 9:44:46 AM</sync-timestamp><sync-itemid>446</sync-itemid><sync-prioritymapping>0:0-0/1:700-1000/2:300-699/3:1-299</sync-prioritymapping>
- 310: Text3: <sync-guid>{C104B365-8730-438D-B388-25DCB4927C8C}</sync-guid><sync-parentguid>{FE356C94-0CD6-47E4-8F13-E319F4D3890E}</sync-parentguid><sync-checksum>972507733</sync-checksum><sync-rootid>0</sync-rootid><sync-itemtype>0</sync-itemtype><sync-timestamp>12/21 / Text5: 2004 9:44:47 AM</sync-timestamp><sync-itemid>984</sync-itemid><sync-prioritymapping>0:0-0/1:700-1000/2:300-699/3:1-299</sync-prioritymapping>
- 311: Text3: <sync-guid>{7E787811-FFC2-4A20-B924-BDAE4A4B7495}</sync-guid><sync-parentguid>{FE356C94-0CD6-47E4-8F13-E319F4D3890E}</sync-parentguid><sync-checksum>643403975</sync-checksum><sync-rootid>0</sync-rootid><sync-itemtype>0</sync-itemtype><sync-timestamp>12/21 / Text5: 2004 9:44:47 AM</sync-timestamp><sync-itemid>983</sync-itemid><sync-prioritymapping>0:0-0/1:700-1000/2:300-699/3:1-299</sync-prioritymapping>
- 312: Text3: <sync-guid>{C6E15D20-CC62-4016-B549-A805296C9512}</sync-guid><sync-parentguid>{C262EF5A-5F48-4212-9B7E-5E84299355EC}</sync-parentguid><sync-checksum>-190680385</sync-checksum><sync-rootid>0</sync-rootid><sync-itemtype>0</sync-itemtype><sync-timestamp>12/2 / Text5: 1/2004 9:44:47 AM</sync-timestamp><sync-itemid>445</sync-itemid><sync-prioritymapping>0:0-0/1:700-1000/2:300-699/3:1-299</sync-prioritymapping>
- 313: Text3: <sync-guid>{FC077322-8F05-4415-A782-160C2EACA18C}</sync-guid><sync-parentguid>{C6E15D20-CC62-4016-B549-A805296C9512}</sync-parentguid><sync-checksum>1726723439</sync-checksum><sync-rootid>0</sync-rootid><sync-itemtype>0</sync-itemtype><sync-timestamp>12/2 / Text5: 1/2004 9:44:47 AM</sync-timestamp><sync-itemid>444</sync-itemid><sync-prioritymapping>0:0-0/1:700-1000/2:300-699/3:1-299</sync-prioritymapping>
- 314: Text3: <sync-guid>{B6A62C33-0453-4A07-995E-D2725A5ED983}</sync-guid><sync-parentguid>{C6E15D20-CC62-4016-B549-A805296C9512}</sync-parentguid><sync-checksum>-1911489623</sync-checksum><sync-rootid>0</sync-rootid><sync-itemtype>0</sync-itemtype><sync-timestamp>12 / Text5: 21/2004 9:44:47 AM</sync-timestamp><sync-itemid>443</sync-itemid><sync-prioritymapping>0:0-0/1:700-1000/2:300-699/3:1-299</sync-prioritymapping>
- 315: Text3: <sync-guid>{5DE34EE6-4BC1-46E3-AEFD-F5DD5B7D7D94}</sync-guid><sync-parentguid>{C6E15D20-CC62-4016-B549-A805296C9512}</sync-parentguid><sync-checksum>-818575895</sync-checksum><sync-rootid>0</sync-rootid><sync-itemtype>0</sync-itemtype><sync-timestamp>12/2 / Text5: 1/2004 9:44:47 AM</sync-timestamp><sync-itemid>442</sync-itemid><sync-prioritymapping>0:0-0/1:700-1000/2:300-699/3:1-299</sync-prioritymapping>
- 316: Text3: <sync-guid>{CCE78B16-3DEB-4557-A552-8E07CE7002D2}</sync-guid><sync-parentguid>{C6E15D20-CC62-4016-B549-A805296C9512}</sync-parentguid><sync-checksum>1065741153</sync-checksum><sync-rootid>0</sync-rootid><sync-itemtype>0</sync-itemtype><sync-timestamp>12/2 / Text5: 1/2004 9:44:47 AM</sync-timestamp><sync-itemid>441</sync-itemid><sync-prioritymapping>0:0-0/1:700-1000/2:300-699/3:1-299</sync-prioritymapping>
- 317: Text3: <sync-guid>{FEC8BF9A-4C9A-4334-BB6E-81E8A7D949E6}</sync-guid><sync-parentguid>{C6E15D20-CC62-4016-B549-A805296C9512}</sync-parentguid><sync-checksum>-1711004305</sync-checksum><sync-rootid>0</sync-rootid><sync-itemtype>0</sync-itemtype><sync-timestamp>12 / Text5: 21/2004 9:44:47 AM</sync-timestamp><sync-itemid>440</sync-itemid><sync-prioritymapping>0:0-0/1:700-1000/2:300-699/3:1-299</sync-prioritymapping>
- 318: Text3: <sync-guid>{A6087256-E69B-4F76-A664-64FE77B99737}</sync-guid><sync-parentguid>{C6E15D20-CC62-4016-B549-A805296C9512}</sync-parentguid><sync-checksum>-557285948</sync-checksum><sync-rootid>0</sync-rootid><sync-itemtype>0</sync-itemtype><sync-timestamp>12/2 / Text5: 1/2004 9:44:47 AM</sync-timestamp><sync-itemid>986</sync-itemid><sync-prioritymapping>0:0-0/1:700-1000/2:300-699/3:1-299</sync-prioritymapping>
- 319: Text3: <sync-guid>{18387316-2593-47C1-8DA3-8833C10A0A17}</sync-guid><sync-parentguid>{C6E15D20-CC62-4016-B549-A805296C9512}</sync-parentguid><sync-checksum>-1872546183</sync-checksum><sync-rootid>0</sync-rootid><sync-itemtype>0</sync-itemtype><sync-timestamp>12 / Text5: 21/2004 9:44:47 AM</sync-timestamp><sync-itemid>985</sync-itemid><sync-prioritymapping>0:0-0/1:700-1000/2:300-699/3:1-299</sync-prioritymapping>

| ID | WBS | Task | Duration | Start | Finish | Predecessors | Baseline start | Baseline finish | Baseline duration | Total slack | Free slack | Text4 |
| --- | --- | --- | --- | --- | --- | --- | --- | --- | --- | --- | --- | --- |
| 320 | 6.2.4 | **Define interface requirements** | 7d | 2005-02-08 | 2005-02-17 | 299 | 2005-02-08 | 2005-02-17 | 7d | 133.5d |  | {0C468A7D-09A6-4C85-9681-89EDF07CEE96} |
| 321 | 6.2.4.1 | Elicit initial interface requirements | 1d | 2005-02-08 | 2005-02-09 |  | 2005-02-08 | 2005-02-09 | 1d | 133.5d | 0d | {B6EEDD77-8130-460C-B00D-A741361EFAFC} |
| 322 | 6.2.4.2 | Prepare draft interface requirements | 1d | 2005-02-09 | 2005-02-10 | 321 | 2005-02-09 | 2005-02-10 | 1d | 133.5d | 0d | {084A94BF-F5A2-41C4-AADD-3D43215E14CC} |
| 323 | 6.2.4.3 | Review draft interface reqts with team | 1d | 2005-02-10 | 2005-02-11 | 322 | 2005-02-10 | 2005-02-11 | 1d | 133.5d | 0d | {952F0EBD-A258-44C6-AE59-719612BB3597} |
| 324 | 6.2.4.4 | Conduct further interface analysis | 1d | 2005-02-11 | 2005-02-14 | 323 | 2005-02-11 | 2005-02-14 | 1d | 133.5d | 0d | {A05D5BEC-85DA-4A09-BD04-6A7EB944FE52} |
| 325 | 6.2.4.5 | Refine draft interface requirements | 1d | 2005-02-14 | 2005-02-15 | 324 | 2005-02-14 | 2005-02-15 | 1d | 133.5d | 0d | {E16DB955-0738-40CB-95E9-4577BABEEB2E} |
| 326 | 6.2.4.6 | Review interface reqts with stakeholders | 1d | 2005-02-15 | 2005-02-16 | 325 | 2005-02-15 | 2005-02-16 | 1d | 133.5d | 0d | {2698C7E4-0FED-457C-8310-8C6DD604274A} |
| 327 | 6.2.4.7 | Apply interface requirements feedback | 1d | 2005-02-16 | 2005-02-17 | 326 | 2005-02-16 | 2005-02-17 | 1d | 133.5d |  | {62DDF2CE-1221-45BF-82D2-C2343C4C31FB} |
| 328 | 6.2.5 | **Define control requirements** | 7d | 2005-02-08 | 2005-02-17 | 299 | 2005-02-08 | 2005-02-17 | 7d | 133.5d |  | {E1109C20-2D0C-4E83-9493-5AE831BF248D} |
| 329 | 6.2.5.1 | Elicit initial control requirements | 1d | 2005-02-08 | 2005-02-09 |  | 2005-02-08 | 2005-02-09 | 1d | 133.5d | 0d | {7FE840E8-E097-46EB-A73E-240BBBDA6FE2} |
| 330 | 6.2.5.2 | Prepare draft control requirements | 1d | 2005-02-09 | 2005-02-10 | 329 | 2005-02-09 | 2005-02-10 | 1d | 133.5d | 0d | {A899120F-70D3-4BEE-A255-80D53543AE24} |
| 331 | 6.2.5.3 | Review draft control reqts with team | 1d | 2005-02-10 | 2005-02-11 | 330 | 2005-02-10 | 2005-02-11 | 1d | 133.5d | 0d | {167FA712-E908-46CD-B93B-8F838F7588E2} |
| 332 | 6.2.5.4 | Conduct further control analysis | 1d | 2005-02-11 | 2005-02-14 | 331 | 2005-02-11 | 2005-02-14 | 1d | 133.5d | 0d | {FCB44C39-32E7-4A46-83C1-04C12D6D751E} |
| 333 | 6.2.5.5 | Refine draft control requirements | 1d | 2005-02-14 | 2005-02-15 | 332 | 2005-02-14 | 2005-02-15 | 1d | 133.5d | 0d | {91BA16D6-BF7A-4904-B9A8-C89DA055930C} |
| 334 | 6.2.5.6 | Review control reqts with stakeholders | 1d | 2005-02-15 | 2005-02-16 | 333 | 2005-02-15 | 2005-02-16 | 1d | 133.5d | 0d | {7D568D6F-BC9F-4E1F-97F4-F32541B33FAF} |
| 335 | 6.2.5.7 | Apply control requirements feedback | 1d | 2005-02-16 | 2005-02-17 | 334 | 2005-02-16 | 2005-02-17 | 1d | 133.5d |  | {D1CBC110-A48E-4698-AF7C-127C7B043027} |
| 336 | 6.2.6 | **Define safety requirements** | 7d | 2005-02-08 | 2005-02-17 | 299 | 2005-02-08 | 2005-02-17 | 7d | 133.5d |  | {F3098118-040B-48F1-84D5-D75BE47B13FB} |
| 337 | 6.2.6.1 | Elicit initial safety requirements | 1d | 2005-02-08 | 2005-02-09 |  | 2005-02-08 | 2005-02-09 | 1d | 133.5d | 0d | {82E31C2B-65A8-42F2-BDC1-D1C2DB35BF56} |
| 338 | 6.2.6.2 | Prepare draft safety requirements | 1d | 2005-02-09 | 2005-02-10 | 337 | 2005-02-09 | 2005-02-10 | 1d | 133.5d | 0d | {EE03887C-89BE-40E1-AF58-B9FB4A4D4479} |
| 339 | 6.2.6.3 | Review draft safety reqts with team | 1d | 2005-02-10 | 2005-02-11 | 338 | 2005-02-10 | 2005-02-11 | 1d | 133.5d | 0d | {50D7325B-C4BB-4C6E-A661-4F072D127BBD} |
| 340 | 6.2.6.4 | Conduct further safety analysis | 1d | 2005-02-11 | 2005-02-14 | 339 | 2005-02-11 | 2005-02-14 | 1d | 133.5d | 0d | {F5A022A2-315F-42AF-86FC-6952A0492C37} |
| 341 | 6.2.6.5 | Refine draft safety requirements | 1d | 2005-02-14 | 2005-02-15 | 340 | 2005-02-14 | 2005-02-15 | 1d | 133.5d | 0d | {4D01F5DE-225C-4109-8D98-CFA79EEAC712} |
| 342 | 6.2.6.6 | Review safety reqts with stakeholders | 1d | 2005-02-15 | 2005-02-16 | 341 | 2005-02-15 | 2005-02-16 | 1d | 133.5d | 0d | {4912D7C1-4B06-4228-874A-67EB58E72A74} |
| 343 | 6.2.6.7 | Apply safety requirements feedback | 1d | 2005-02-16 | 2005-02-17 | 342 | 2005-02-16 | 2005-02-17 | 1d | 133.5d |  | {9565584D-465B-426C-A2B4-5F72573478BB} |

Notes:
- 320: Text3: <sync-guid>{0C468A7D-09A6-4C85-9681-89EDF07CEE96}</sync-guid><sync-parentguid>{C262EF5A-5F48-4212-9B7E-5E84299355EC}</sync-parentguid><sync-checksum>1788076083</sync-checksum><sync-rootid>0</sync-rootid><sync-itemtype>0</sync-itemtype><sync-timestamp>12/2 / Text5: 1/2004 9:44:47 AM</sync-timestamp><sync-itemid>1040</sync-itemid><sync-prioritymapping>0:0-0/1:700-1000/2:300-699/3:1-299</sync-prioritymapping>
- 321: Text3: <sync-guid>{B6EEDD77-8130-460C-B00D-A741361EFAFC}</sync-guid><sync-parentguid>{0C468A7D-09A6-4C85-9681-89EDF07CEE96}</sync-parentguid><sync-checksum>84732279</sync-checksum><sync-rootid>0</sync-rootid><sync-itemtype>0</sync-itemtype><sync-timestamp>12/21 / Text5: 2004 9:44:48 AM</sync-timestamp><sync-itemid>1039</sync-itemid><sync-prioritymapping>0:0-0/1:700-1000/2:300-699/3:1-299</sync-prioritymapping>
- 322: Text3: <sync-guid>{084A94BF-F5A2-41C4-AADD-3D43215E14CC}</sync-guid><sync-parentguid>{0C468A7D-09A6-4C85-9681-89EDF07CEE96}</sync-parentguid><sync-checksum>1422145232</sync-checksum><sync-rootid>0</sync-rootid><sync-itemtype>0</sync-itemtype><sync-timestamp>12/2 / Text5: 1/2004 9:44:48 AM</sync-timestamp><sync-itemid>1038</sync-itemid><sync-prioritymapping>0:0-0/1:700-1000/2:300-699/3:1-299</sync-prioritymapping>
- 323: Text3: <sync-guid>{952F0EBD-A258-44C6-AE59-719612BB3597}</sync-guid><sync-parentguid>{0C468A7D-09A6-4C85-9681-89EDF07CEE96}</sync-parentguid><sync-checksum>-1844307205</sync-checksum><sync-rootid>0</sync-rootid><sync-itemtype>0</sync-itemtype><sync-timestamp>12 / Text5: 21/2004 9:44:48 AM</sync-timestamp><sync-itemid>1037</sync-itemid><sync-prioritymapping>0:0-0/1:700-1000/2:300-699/3:1-299</sync-prioritymapping>
- 324: Text3: <sync-guid>{A05D5BEC-85DA-4A09-BD04-6A7EB944FE52}</sync-guid><sync-parentguid>{0C468A7D-09A6-4C85-9681-89EDF07CEE96}</sync-parentguid><sync-checksum>-1248706144</sync-checksum><sync-rootid>0</sync-rootid><sync-itemtype>0</sync-itemtype><sync-timestamp>12 / Text5: 21/2004 9:44:48 AM</sync-timestamp><sync-itemid>1036</sync-itemid><sync-prioritymapping>0:0-0/1:700-1000/2:300-699/3:1-299</sync-prioritymapping>
- 325: Text3: <sync-guid>{E16DB955-0738-40CB-95E9-4577BABEEB2E}</sync-guid><sync-parentguid>{0C468A7D-09A6-4C85-9681-89EDF07CEE96}</sync-parentguid><sync-checksum>-747287852</sync-checksum><sync-rootid>0</sync-rootid><sync-itemtype>0</sync-itemtype><sync-timestamp>12/2 / Text5: 1/2004 9:44:48 AM</sync-timestamp><sync-itemid>1035</sync-itemid><sync-prioritymapping>0:0-0/1:700-1000/2:300-699/3:1-299</sync-prioritymapping>
- 326: Text3: <sync-guid>{2698C7E4-0FED-457C-8310-8C6DD604274A}</sync-guid><sync-parentguid>{0C468A7D-09A6-4C85-9681-89EDF07CEE96}</sync-parentguid><sync-checksum>-2037833103</sync-checksum><sync-rootid>0</sync-rootid><sync-itemtype>0</sync-itemtype><sync-timestamp>12 / Text5: 21/2004 9:44:48 AM</sync-timestamp><sync-itemid>1034</sync-itemid><sync-prioritymapping>0:0-0/1:700-1000/2:300-699/3:1-299</sync-prioritymapping>
- 327: Text3: <sync-guid>{62DDF2CE-1221-45BF-82D2-C2343C4C31FB}</sync-guid><sync-parentguid>{0C468A7D-09A6-4C85-9681-89EDF07CEE96}</sync-parentguid><sync-checksum>-1576208318</sync-checksum><sync-rootid>0</sync-rootid><sync-itemtype>0</sync-itemtype><sync-timestamp>12 / Text5: 21/2004 9:44:48 AM</sync-timestamp><sync-itemid>1033</sync-itemid><sync-prioritymapping>0:0-0/1:700-1000/2:300-699/3:1-299</sync-prioritymapping>
- 328: Text3: <sync-guid>{E1109C20-2D0C-4E83-9493-5AE831BF248D}</sync-guid><sync-parentguid>{C262EF5A-5F48-4212-9B7E-5E84299355EC}</sync-parentguid><sync-checksum>2127842634</sync-checksum><sync-rootid>0</sync-rootid><sync-itemtype>0</sync-itemtype><sync-timestamp>12/2 / Text5: 1/2004 9:44:48 AM</sync-timestamp><sync-itemid>994</sync-itemid><sync-prioritymapping>0:0-0/1:700-1000/2:300-699/3:1-299</sync-prioritymapping>
- 329: Text3: <sync-guid>{7FE840E8-E097-46EB-A73E-240BBBDA6FE2}</sync-guid><sync-parentguid>{E1109C20-2D0C-4E83-9493-5AE831BF248D}</sync-parentguid><sync-checksum>-98136503</sync-checksum><sync-rootid>0</sync-rootid><sync-itemtype>0</sync-itemtype><sync-timestamp>12/21 / Text5: 2004 9:44:48 AM</sync-timestamp><sync-itemid>993</sync-itemid><sync-prioritymapping>0:0-0/1:700-1000/2:300-699/3:1-299</sync-prioritymapping>
- 330: Text3: <sync-guid>{A899120F-70D3-4BEE-A255-80D53543AE24}</sync-guid><sync-parentguid>{E1109C20-2D0C-4E83-9493-5AE831BF248D}</sync-parentguid><sync-checksum>-1092263889</sync-checksum><sync-rootid>0</sync-rootid><sync-itemtype>0</sync-itemtype><sync-timestamp>12 / Text5: 21/2004 9:44:48 AM</sync-timestamp><sync-itemid>992</sync-itemid><sync-prioritymapping>0:0-0/1:700-1000/2:300-699/3:1-299</sync-prioritymapping>
- 331: Text3: <sync-guid>{167FA712-E908-46CD-B93B-8F838F7588E2}</sync-guid><sync-parentguid>{E1109C20-2D0C-4E83-9493-5AE831BF248D}</sync-parentguid><sync-checksum>-1437612262</sync-checksum><sync-rootid>0</sync-rootid><sync-itemtype>0</sync-itemtype><sync-timestamp>12 / Text5: 21/2004 9:44:49 AM</sync-timestamp><sync-itemid>991</sync-itemid><sync-prioritymapping>0:0-0/1:700-1000/2:300-699/3:1-299</sync-prioritymapping>
- 332: Text3: <sync-guid>{FCB44C39-32E7-4A46-83C1-04C12D6D751E}</sync-guid><sync-parentguid>{E1109C20-2D0C-4E83-9493-5AE831BF248D}</sync-parentguid><sync-checksum>-388994535</sync-checksum><sync-rootid>0</sync-rootid><sync-itemtype>0</sync-itemtype><sync-timestamp>12/2 / Text5: 1/2004 9:44:49 AM</sync-timestamp><sync-itemid>990</sync-itemid><sync-prioritymapping>0:0-0/1:700-1000/2:300-699/3:1-299</sync-prioritymapping>
- 333: Text3: <sync-guid>{91BA16D6-BF7A-4904-B9A8-C89DA055930C}</sync-guid><sync-parentguid>{E1109C20-2D0C-4E83-9493-5AE831BF248D}</sync-parentguid><sync-checksum>1957662349</sync-checksum><sync-rootid>0</sync-rootid><sync-itemtype>0</sync-itemtype><sync-timestamp>12/2 / Text5: 1/2004 9:44:49 AM</sync-timestamp><sync-itemid>989</sync-itemid><sync-prioritymapping>0:0-0/1:700-1000/2:300-699/3:1-299</sync-prioritymapping>
- 334: Text3: <sync-guid>{7D568D6F-BC9F-4E1F-97F4-F32541B33FAF}</sync-guid><sync-parentguid>{E1109C20-2D0C-4E83-9493-5AE831BF248D}</sync-parentguid><sync-checksum>-739854322</sync-checksum><sync-rootid>0</sync-rootid><sync-itemtype>0</sync-itemtype><sync-timestamp>12/2 / Text5: 1/2004 9:44:49 AM</sync-timestamp><sync-itemid>988</sync-itemid><sync-prioritymapping>0:0-0/1:700-1000/2:300-699/3:1-299</sync-prioritymapping>
- 335: Text3: <sync-guid>{D1CBC110-A48E-4698-AF7C-127C7B043027}</sync-guid><sync-parentguid>{E1109C20-2D0C-4E83-9493-5AE831BF248D}</sync-parentguid><sync-checksum>-1155752431</sync-checksum><sync-rootid>0</sync-rootid><sync-itemtype>0</sync-itemtype><sync-timestamp>12 / Text5: 21/2004 9:44:49 AM</sync-timestamp><sync-itemid>987</sync-itemid><sync-prioritymapping>0:0-0/1:700-1000/2:300-699/3:1-299</sync-prioritymapping>
- 336: Text3: <sync-guid>{F3098118-040B-48F1-84D5-D75BE47B13FB}</sync-guid><sync-parentguid>{C262EF5A-5F48-4212-9B7E-5E84299355EC}</sync-parentguid><sync-checksum>1843979666</sync-checksum><sync-rootid>0</sync-rootid><sync-itemtype>0</sync-itemtype><sync-timestamp>12/2 / Text5: 1/2004 9:44:49 AM</sync-timestamp><sync-itemid>1002</sync-itemid><sync-prioritymapping>0:0-0/1:700-1000/2:300-699/3:1-299</sync-prioritymapping>
- 337: Text3: <sync-guid>{82E31C2B-65A8-42F2-BDC1-D1C2DB35BF56}</sync-guid><sync-parentguid>{F3098118-040B-48F1-84D5-D75BE47B13FB}</sync-parentguid><sync-checksum>1299289007</sync-checksum><sync-rootid>0</sync-rootid><sync-itemtype>0</sync-itemtype><sync-timestamp>12/2 / Text5: 1/2004 9:44:50 AM</sync-timestamp><sync-itemid>1001</sync-itemid><sync-prioritymapping>0:0-0/1:700-1000/2:300-699/3:1-299</sync-prioritymapping>
- 338: Text3: <sync-guid>{EE03887C-89BE-40E1-AF58-B9FB4A4D4479}</sync-guid><sync-parentguid>{F3098118-040B-48F1-84D5-D75BE47B13FB}</sync-parentguid><sync-checksum>-1730106333</sync-checksum><sync-rootid>0</sync-rootid><sync-itemtype>0</sync-itemtype><sync-timestamp>12 / Text5: 21/2004 9:44:50 AM</sync-timestamp><sync-itemid>1000</sync-itemid><sync-prioritymapping>0:0-0/1:700-1000/2:300-699/3:1-299</sync-prioritymapping>
- 339: Text3: <sync-guid>{50D7325B-C4BB-4C6E-A661-4F072D127BBD}</sync-guid><sync-parentguid>{F3098118-040B-48F1-84D5-D75BE47B13FB}</sync-parentguid><sync-checksum>1386357075</sync-checksum><sync-rootid>0</sync-rootid><sync-itemtype>0</sync-itemtype><sync-timestamp>12/2 / Text5: 1/2004 9:44:50 AM</sync-timestamp><sync-itemid>999</sync-itemid><sync-prioritymapping>0:0-0/1:700-1000/2:300-699/3:1-299</sync-prioritymapping>
- 340: Text3: <sync-guid>{F5A022A2-315F-42AF-86FC-6952A0492C37}</sync-guid><sync-parentguid>{F3098118-040B-48F1-84D5-D75BE47B13FB}</sync-parentguid><sync-checksum>589618819</sync-checksum><sync-rootid>0</sync-rootid><sync-itemtype>0</sync-itemtype><sync-timestamp>12/21 / Text5: 2004 9:44:50 AM</sync-timestamp><sync-itemid>998</sync-itemid><sync-prioritymapping>0:0-0/1:700-1000/2:300-699/3:1-299</sync-prioritymapping>
- 341: Text3: <sync-guid>{4D01F5DE-225C-4109-8D98-CFA79EEAC712}</sync-guid><sync-parentguid>{F3098118-040B-48F1-84D5-D75BE47B13FB}</sync-parentguid><sync-checksum>-83922486</sync-checksum><sync-rootid>0</sync-rootid><sync-itemtype>0</sync-itemtype><sync-timestamp>12/21 / Text5: 2004 9:44:50 AM</sync-timestamp><sync-itemid>997</sync-itemid><sync-prioritymapping>0:0-0/1:700-1000/2:300-699/3:1-299</sync-prioritymapping>
- 342: Text3: <sync-guid>{4912D7C1-4B06-4228-874A-67EB58E72A74}</sync-guid><sync-parentguid>{F3098118-040B-48F1-84D5-D75BE47B13FB}</sync-parentguid><sync-checksum>1302942904</sync-checksum><sync-rootid>0</sync-rootid><sync-itemtype>0</sync-itemtype><sync-timestamp>12/2 / Text5: 1/2004 9:44:50 AM</sync-timestamp><sync-itemid>996</sync-itemid><sync-prioritymapping>0:0-0/1:700-1000/2:300-699/3:1-299</sync-prioritymapping>
- 343: Text3: <sync-guid>{9565584D-465B-426C-A2B4-5F72573478BB}</sync-guid><sync-parentguid>{F3098118-040B-48F1-84D5-D75BE47B13FB}</sync-parentguid><sync-checksum>-1174927255</sync-checksum><sync-rootid>0</sync-rootid><sync-itemtype>0</sync-itemtype><sync-timestamp>12 / Text5: 21/2004 9:44:50 AM</sync-timestamp><sync-itemid>995</sync-itemid><sync-prioritymapping>0:0-0/1:700-1000/2:300-699/3:1-299</sync-prioritymapping>

| ID | WBS | Task | Duration | Start | Finish | Predecessors | Baseline start | Baseline finish | Baseline duration | Total slack | Free slack | Text4 |
| --- | --- | --- | --- | --- | --- | --- | --- | --- | --- | --- | --- | --- |
| 344 | 6.2.7 | **Define regulatory requirements** | 7d | 2005-02-08 | 2005-02-17 | 299 | 2005-02-08 | 2005-02-17 | 7d | 133.5d |  | {9DB22F97-8D3E-4972-AF62-89495613C41B} |
| 345 | 6.2.7.1 | Elicit initial regulatory requirements | 1d | 2005-02-08 | 2005-02-09 |  | 2005-02-08 | 2005-02-09 | 1d | 133.5d | 0d | {EF7345AB-213D-4462-A6F3-66304DD95F73} |
| 346 | 6.2.7.2 | Prepare draft regulatory requirements | 1d | 2005-02-09 | 2005-02-10 | 345 | 2005-02-09 | 2005-02-10 | 1d | 133.5d | 0d | {9A115EE9-E212-4CE1-8CCB-C89D7A065E0A} |
| 347 | 6.2.7.3 | Review draft regulatory reqts with team | 1d | 2005-02-10 | 2005-02-11 | 346 | 2005-02-10 | 2005-02-11 | 1d | 133.5d | 0d | {CF2A322C-B240-4F32-B203-E6E11A1A1716} |
| 348 | 6.2.7.4 | Conduct further regulatory analysis | 1d | 2005-02-11 | 2005-02-14 | 347 | 2005-02-11 | 2005-02-14 | 1d | 133.5d | 0d | {B7A368CE-C8DF-4ABC-ABC5-B535A110C0EC} |
| 349 | 6.2.7.5 | Refine draft regulatory requirements | 1d | 2005-02-14 | 2005-02-15 | 348 | 2005-02-14 | 2005-02-15 | 1d | 133.5d | 0d | {5287F2E8-FA72-4172-9C0D-795C112E8267} |
| 350 | 6.2.7.6 | Review regulatory reqts with stakeholders | 1d | 2005-02-15 | 2005-02-16 | 349 | 2005-02-15 | 2005-02-16 | 1d | 133.5d | 0d | {B72B462B-807C-43B2-9EFF-54CA681F62F6} |
| 351 | 6.2.7.7 | Apply regulatory requirements feedback | 1d | 2005-02-16 | 2005-02-17 | 350 | 2005-02-16 | 2005-02-17 | 1d | 133.5d |  | {5F9887E1-14C5-4D17-992D-E9273DB03CBA} |
| 352 | 6.2.8 | **Define conversion requirements** | 7d | 2005-02-08 | 2005-02-17 | 299 | 2005-02-08 | 2005-02-17 | 7d | 133.5d |  | {A938AB95-4415-449C-AEAF-D371B2384F1C} |
| 353 | 6.2.8.1 | Elicit initial conversion requirements | 1d | 2005-02-08 | 2005-02-09 |  | 2005-02-08 | 2005-02-09 | 1d | 133.5d | 0d | {C87A9DBC-C213-432F-9FC4-64D38A20DADC} |
| 354 | 6.2.8.2 | Prepare draft conversion requirements | 1d | 2005-02-09 | 2005-02-10 | 353 | 2005-02-09 | 2005-02-10 | 1d | 133.5d | 0d | {1E7C415D-D52E-4519-8C43-9A3A4212AB12} |
| 355 | 6.2.8.3 | Review draft conversion reqts with team | 1d | 2005-02-10 | 2005-02-11 | 354 | 2005-02-10 | 2005-02-11 | 1d | 133.5d | 0d | {1A19E6E3-8302-45FF-956D-3C15B2D477AA} |
| 356 | 6.2.8.4 | Conduct further conversion analysis | 1d | 2005-02-11 | 2005-02-14 | 355 | 2005-02-11 | 2005-02-14 | 1d | 133.5d | 0d | {71CDF55D-D5B4-46EF-8521-9BFC9DE7F65B} |
| 357 | 6.2.8.5 | Refine draft conversion requirements | 1d | 2005-02-14 | 2005-02-15 | 356 | 2005-02-14 | 2005-02-15 | 1d | 133.5d | 0d | {AFE8FCAB-DC5B-4A95-BBE0-949BBF55A7A1} |
| 358 | 6.2.8.6 | Review conversion reqts with stakeholders | 1d | 2005-02-15 | 2005-02-16 | 357 | 2005-02-15 | 2005-02-16 | 1d | 133.5d | 0d | {E8A27768-D2DB-45A4-B8EE-D6D426D57897} |
| 359 | 6.2.8.7 | Apply conversion requirements feedback | 1d | 2005-02-16 | 2005-02-17 | 358 | 2005-02-16 | 2005-02-17 | 1d | 133.5d |  | {4ABDA57B-FABF-43DE-B0E0-61A90A110999} |
| 360 | 6.2.9 | **Define training requirements** | 7d | 2005-02-08 | 2005-02-17 | 299 | 2005-02-08 | 2005-02-17 | 7d | 133.5d |  | {E3AAF401-EAC4-4C09-8107-D7001EEBD035} |
| 361 | 6.2.9.1 | Elicit initial training requirements | 1d | 2005-02-08 | 2005-02-09 |  | 2005-02-08 | 2005-02-09 | 1d | 133.5d | 0d | {49137065-5AC1-414A-B1B8-5F7E4CE541B3} |
| 362 | 6.2.9.2 | Prepare draft training requirements | 1d | 2005-02-09 | 2005-02-10 | 361 | 2005-02-09 | 2005-02-10 | 1d | 133.5d | 0d | {5184CC18-29AF-4576-AED7-85265020A82C} |
| 363 | 6.2.9.3 | Review draft training reqts with team | 1d | 2005-02-10 | 2005-02-11 | 362 | 2005-02-10 | 2005-02-11 | 1d | 133.5d | 0d | {9E9553E5-6AF4-465D-B399-F1C32BA43849} |
| 364 | 6.2.9.4 | Conduct further training analysis | 1d | 2005-02-11 | 2005-02-14 | 363 | 2005-02-11 | 2005-02-14 | 1d | 133.5d | 0d | {611C619B-16A1-4261-AD86-8E3B324FF1A7} |
| 365 | 6.2.9.5 | Refine draft training requirements | 1d | 2005-02-14 | 2005-02-15 | 364 | 2005-02-14 | 2005-02-15 | 1d | 133.5d | 0d | {AEBD5697-28A9-45AC-89B2-E64A2106BED5} |
| 366 | 6.2.9.6 | Review training reqts with stakeholders | 1d | 2005-02-15 | 2005-02-16 | 365 | 2005-02-15 | 2005-02-16 | 1d | 133.5d | 0d | {3DF532ED-5E5F-4A2D-9C58-01AF644A07B3} |
| 367 | 6.2.9.7 | Apply training requirements feedback | 1d | 2005-02-16 | 2005-02-17 | 366 | 2005-02-16 | 2005-02-17 | 1d | 133.5d |  | {C83A2C70-D2FE-4324-920E-59C8B3D72F1E} |

Notes:
- 344: Text3: <sync-guid>{9DB22F97-8D3E-4972-AF62-89495613C41B}</sync-guid><sync-parentguid>{C262EF5A-5F48-4212-9B7E-5E84299355EC}</sync-parentguid><sync-checksum>-755213946</sync-checksum><sync-rootid>0</sync-rootid><sync-itemtype>0</sync-itemtype><sync-timestamp>12/2 / Text5: 1/2004 9:44:50 AM</sync-timestamp><sync-itemid>1010</sync-itemid><sync-prioritymapping>0:0-0/1:700-1000/2:300-699/3:1-299</sync-prioritymapping>
- 345: Text3: <sync-guid>{EF7345AB-213D-4462-A6F3-66304DD95F73}</sync-guid><sync-parentguid>{9DB22F97-8D3E-4972-AF62-89495613C41B}</sync-parentguid><sync-checksum>-504356769</sync-checksum><sync-rootid>0</sync-rootid><sync-itemtype>0</sync-itemtype><sync-timestamp>12/2 / Text5: 1/2004 9:44:50 AM</sync-timestamp><sync-itemid>1009</sync-itemid><sync-prioritymapping>0:0-0/1:700-1000/2:300-699/3:1-299</sync-prioritymapping>
- 346: Text3: <sync-guid>{9A115EE9-E212-4CE1-8CCB-C89D7A065E0A}</sync-guid><sync-parentguid>{9DB22F97-8D3E-4972-AF62-89495613C41B}</sync-parentguid><sync-checksum>151744153</sync-checksum><sync-rootid>0</sync-rootid><sync-itemtype>0</sync-itemtype><sync-timestamp>12/21 / Text5: 2004 9:44:50 AM</sync-timestamp><sync-itemid>1008</sync-itemid><sync-prioritymapping>0:0-0/1:700-1000/2:300-699/3:1-299</sync-prioritymapping>
- 347: Text3: <sync-guid>{CF2A322C-B240-4F32-B203-E6E11A1A1716}</sync-guid><sync-parentguid>{9DB22F97-8D3E-4972-AF62-89495613C41B}</sync-parentguid><sync-checksum>1829623629</sync-checksum><sync-rootid>0</sync-rootid><sync-itemtype>0</sync-itemtype><sync-timestamp>12/2 / Text5: 1/2004 9:44:50 AM</sync-timestamp><sync-itemid>1007</sync-itemid><sync-prioritymapping>0:0-0/1:700-1000/2:300-699/3:1-299</sync-prioritymapping>
- 348: Text3: <sync-guid>{B7A368CE-C8DF-4ABC-ABC5-B535A110C0EC}</sync-guid><sync-parentguid>{9DB22F97-8D3E-4972-AF62-89495613C41B}</sync-parentguid><sync-checksum>1300999725</sync-checksum><sync-rootid>0</sync-rootid><sync-itemtype>0</sync-itemtype><sync-timestamp>12/2 / Text5: 1/2004 9:44:51 AM</sync-timestamp><sync-itemid>1006</sync-itemid><sync-prioritymapping>0:0-0/1:700-1000/2:300-699/3:1-299</sync-prioritymapping>
- 349: Text3: <sync-guid>{5287F2E8-FA72-4172-9C0D-795C112E8267}</sync-guid><sync-parentguid>{9DB22F97-8D3E-4972-AF62-89495613C41B}</sync-parentguid><sync-checksum>488616031</sync-checksum><sync-rootid>0</sync-rootid><sync-itemtype>0</sync-itemtype><sync-timestamp>12/21 / Text5: 2004 9:44:51 AM</sync-timestamp><sync-itemid>1005</sync-itemid><sync-prioritymapping>0:0-0/1:700-1000/2:300-699/3:1-299</sync-prioritymapping>
- 350: Text3: <sync-guid>{B72B462B-807C-43B2-9EFF-54CA681F62F6}</sync-guid><sync-parentguid>{9DB22F97-8D3E-4972-AF62-89495613C41B}</sync-parentguid><sync-checksum>-1505024742</sync-checksum><sync-rootid>0</sync-rootid><sync-itemtype>0</sync-itemtype><sync-timestamp>12 / Text5: 21/2004 9:44:51 AM</sync-timestamp><sync-itemid>1004</sync-itemid><sync-prioritymapping>0:0-0/1:700-1000/2:300-699/3:1-299</sync-prioritymapping>
- 351: Text3: <sync-guid>{5F9887E1-14C5-4D17-992D-E9273DB03CBA}</sync-guid><sync-parentguid>{9DB22F97-8D3E-4972-AF62-89495613C41B}</sync-parentguid><sync-checksum>-1084317590</sync-checksum><sync-rootid>0</sync-rootid><sync-itemtype>0</sync-itemtype><sync-timestamp>12 / Text5: 21/2004 9:44:51 AM</sync-timestamp><sync-itemid>1003</sync-itemid><sync-prioritymapping>0:0-0/1:700-1000/2:300-699/3:1-299</sync-prioritymapping>
- 352: Text3: <sync-guid>{A938AB95-4415-449C-AEAF-D371B2384F1C}</sync-guid><sync-parentguid>{C262EF5A-5F48-4212-9B7E-5E84299355EC}</sync-parentguid><sync-checksum>-486482465</sync-checksum><sync-rootid>0</sync-rootid><sync-itemtype>0</sync-itemtype><sync-timestamp>12/2 / Text5: 1/2004 9:44:51 AM</sync-timestamp><sync-itemid>1018</sync-itemid><sync-prioritymapping>0:0-0/1:700-1000/2:300-699/3:1-299</sync-prioritymapping>
- 353: Text3: <sync-guid>{C87A9DBC-C213-432F-9FC4-64D38A20DADC}</sync-guid><sync-parentguid>{A938AB95-4415-449C-AEAF-D371B2384F1C}</sync-parentguid><sync-checksum>1945802481</sync-checksum><sync-rootid>0</sync-rootid><sync-itemtype>0</sync-itemtype><sync-timestamp>12/2 / Text5: 1/2004 9:44:51 AM</sync-timestamp><sync-itemid>1017</sync-itemid><sync-prioritymapping>0:0-0/1:700-1000/2:300-699/3:1-299</sync-prioritymapping>
- 354: Text3: <sync-guid>{1E7C415D-D52E-4519-8C43-9A3A4212AB12}</sync-guid><sync-parentguid>{A938AB95-4415-449C-AEAF-D371B2384F1C}</sync-parentguid><sync-checksum>-1694377929</sync-checksum><sync-rootid>0</sync-rootid><sync-itemtype>0</sync-itemtype><sync-timestamp>12 / Text5: 21/2004 9:44:51 AM</sync-timestamp><sync-itemid>1016</sync-itemid><sync-prioritymapping>0:0-0/1:700-1000/2:300-699/3:1-299</sync-prioritymapping>
- 355: Text3: <sync-guid>{1A19E6E3-8302-45FF-956D-3C15B2D477AA}</sync-guid><sync-parentguid>{A938AB95-4415-449C-AEAF-D371B2384F1C}</sync-parentguid><sync-checksum>-324974699</sync-checksum><sync-rootid>0</sync-rootid><sync-itemtype>0</sync-itemtype><sync-timestamp>12/2 / Text5: 1/2004 9:44:51 AM</sync-timestamp><sync-itemid>1015</sync-itemid><sync-prioritymapping>0:0-0/1:700-1000/2:300-699/3:1-299</sync-prioritymapping>
- 356: Text3: <sync-guid>{71CDF55D-D5B4-46EF-8521-9BFC9DE7F65B}</sync-guid><sync-parentguid>{A938AB95-4415-449C-AEAF-D371B2384F1C}</sync-parentguid><sync-checksum>585424642</sync-checksum><sync-rootid>0</sync-rootid><sync-itemtype>0</sync-itemtype><sync-timestamp>12/21 / Text5: 2004 9:44:51 AM</sync-timestamp><sync-itemid>1014</sync-itemid><sync-prioritymapping>0:0-0/1:700-1000/2:300-699/3:1-299</sync-prioritymapping>
- 357: Text3: <sync-guid>{AFE8FCAB-DC5B-4A95-BBE0-949BBF55A7A1}</sync-guid><sync-parentguid>{A938AB95-4415-449C-AEAF-D371B2384F1C}</sync-parentguid><sync-checksum>-1894447375</sync-checksum><sync-rootid>0</sync-rootid><sync-itemtype>0</sync-itemtype><sync-timestamp>12 / Text5: 21/2004 9:44:51 AM</sync-timestamp><sync-itemid>1013</sync-itemid><sync-prioritymapping>0:0-0/1:700-1000/2:300-699/3:1-299</sync-prioritymapping>
- 358: Text3: <sync-guid>{E8A27768-D2DB-45A4-B8EE-D6D426D57897}</sync-guid><sync-parentguid>{A938AB95-4415-449C-AEAF-D371B2384F1C}</sync-parentguid><sync-checksum>2116253240</sync-checksum><sync-rootid>0</sync-rootid><sync-itemtype>0</sync-itemtype><sync-timestamp>12/2 / Text5: 1/2004 9:44:51 AM</sync-timestamp><sync-itemid>1012</sync-itemid><sync-prioritymapping>0:0-0/1:700-1000/2:300-699/3:1-299</sync-prioritymapping>
- 359: Text3: <sync-guid>{4ABDA57B-FABF-43DE-B0E0-61A90A110999}</sync-guid><sync-parentguid>{A938AB95-4415-449C-AEAF-D371B2384F1C}</sync-parentguid><sync-checksum>2004864562</sync-checksum><sync-rootid>0</sync-rootid><sync-itemtype>0</sync-itemtype><sync-timestamp>12/2 / Text5: 1/2004 9:44:51 AM</sync-timestamp><sync-itemid>1011</sync-itemid><sync-prioritymapping>0:0-0/1:700-1000/2:300-699/3:1-299</sync-prioritymapping>
- 360: Text3: <sync-guid>{E3AAF401-EAC4-4C09-8107-D7001EEBD035}</sync-guid><sync-parentguid>{C262EF5A-5F48-4212-9B7E-5E84299355EC}</sync-parentguid><sync-checksum>-568932254</sync-checksum><sync-rootid>0</sync-rootid><sync-itemtype>0</sync-itemtype><sync-timestamp>12/2 / Text5: 1/2004 9:44:52 AM</sync-timestamp><sync-itemid>1026</sync-itemid><sync-prioritymapping>0:0-0/1:700-1000/2:300-699/3:1-299</sync-prioritymapping>
- 361: Text3: <sync-guid>{49137065-5AC1-414A-B1B8-5F7E4CE541B3}</sync-guid><sync-parentguid>{E3AAF401-EAC4-4C09-8107-D7001EEBD035}</sync-parentguid><sync-checksum>1755538977</sync-checksum><sync-rootid>0</sync-rootid><sync-itemtype>0</sync-itemtype><sync-timestamp>12/2 / Text5: 1/2004 9:44:52 AM</sync-timestamp><sync-itemid>1025</sync-itemid><sync-prioritymapping>0:0-0/1:700-1000/2:300-699/3:1-299</sync-prioritymapping>
- 362: Text3: <sync-guid>{5184CC18-29AF-4576-AED7-85265020A82C}</sync-guid><sync-parentguid>{E3AAF401-EAC4-4C09-8107-D7001EEBD035}</sync-parentguid><sync-checksum>1815007728</sync-checksum><sync-rootid>0</sync-rootid><sync-itemtype>0</sync-itemtype><sync-timestamp>12/2 / Text5: 1/2004 9:44:52 AM</sync-timestamp><sync-itemid>1024</sync-itemid><sync-prioritymapping>0:0-0/1:700-1000/2:300-699/3:1-299</sync-prioritymapping>
- 363: Text3: <sync-guid>{9E9553E5-6AF4-465D-B399-F1C32BA43849}</sync-guid><sync-parentguid>{E3AAF401-EAC4-4C09-8107-D7001EEBD035}</sync-parentguid><sync-checksum>-1357675278</sync-checksum><sync-rootid>0</sync-rootid><sync-itemtype>0</sync-itemtype><sync-timestamp>12 / Text5: 21/2004 9:44:52 AM</sync-timestamp><sync-itemid>1023</sync-itemid><sync-prioritymapping>0:0-0/1:700-1000/2:300-699/3:1-299</sync-prioritymapping>
- 364: Text3: <sync-guid>{611C619B-16A1-4261-AD86-8E3B324FF1A7}</sync-guid><sync-parentguid>{E3AAF401-EAC4-4C09-8107-D7001EEBD035}</sync-parentguid><sync-checksum>-1249098757</sync-checksum><sync-rootid>0</sync-rootid><sync-itemtype>0</sync-itemtype><sync-timestamp>12 / Text5: 21/2004 9:44:52 AM</sync-timestamp><sync-itemid>1022</sync-itemid><sync-prioritymapping>0:0-0/1:700-1000/2:300-699/3:1-299</sync-prioritymapping>
- 365: Text3: <sync-guid>{AEBD5697-28A9-45AC-89B2-E64A2106BED5}</sync-guid><sync-parentguid>{E3AAF401-EAC4-4C09-8107-D7001EEBD035}</sync-parentguid><sync-checksum>1203958393</sync-checksum><sync-rootid>0</sync-rootid><sync-itemtype>0</sync-itemtype><sync-timestamp>12/2 / Text5: 1/2004 9:44:52 AM</sync-timestamp><sync-itemid>1021</sync-itemid><sync-prioritymapping>0:0-0/1:700-1000/2:300-699/3:1-299</sync-prioritymapping>
- 366: Text3: <sync-guid>{3DF532ED-5E5F-4A2D-9C58-01AF644A07B3}</sync-guid><sync-parentguid>{E3AAF401-EAC4-4C09-8107-D7001EEBD035}</sync-parentguid><sync-checksum>-885509490</sync-checksum><sync-rootid>0</sync-rootid><sync-itemtype>0</sync-itemtype><sync-timestamp>12/2 / Text5: 1/2004 9:44:52 AM</sync-timestamp><sync-itemid>1020</sync-itemid><sync-prioritymapping>0:0-0/1:700-1000/2:300-699/3:1-299</sync-prioritymapping>
- 367: Text3: <sync-guid>{C83A2C70-D2FE-4324-920E-59C8B3D72F1E}</sync-guid><sync-parentguid>{E3AAF401-EAC4-4C09-8107-D7001EEBD035}</sync-parentguid><sync-checksum>93110045</sync-checksum><sync-rootid>0</sync-rootid><sync-itemtype>0</sync-itemtype><sync-timestamp>12/21 / Text5: 2004 9:44:52 AM</sync-timestamp><sync-itemid>1019</sync-itemid><sync-prioritymapping>0:0-0/1:700-1000/2:300-699/3:1-299</sync-prioritymapping>

| ID | WBS | Task | Type | Duration | Start | Finish | Predecessors | Baseline start | Baseline finish | Baseline duration | Total slack | Free slack | Text4 |
| --- | --- | --- | --- | --- | --- | --- | --- | --- | --- | --- | --- | --- | --- |
| 368 | 6.2.10 | **Consolidate draft requirements** |  | 7d | 2005-02-17 | 2005-02-28 | 296, 304, 312 | 2005-02-17 | 2005-02-28 | 7d | 106.5d | 0d | {BEF2567E-CE9E-448B-B505-FD7D71A45672} |
| 369 | 6.2.10.1 | Build consolidated requirements listing |  | 1d | 2005-02-17 | 2005-02-18 |  | 2005-02-17 | 2005-02-18 | 1d | 106.5d | 0d | {CD0D24AF-AAC4-4827-87C0-7D9A7766CD79} |
| 370 | 6.2.10.2 | Review consolidation with team |  | 2d | 2005-02-18 | 2005-02-22 | 369 | 2005-02-18 | 2005-02-22 | 2d | 106.5d | 0d | {238C873E-D2E8-42C5-AF3A-6E5407ABCBBE} |
| 371 | 6.2.10.3 | Identify release sequence |  | 1d | 2005-02-22 | 2005-02-23 | 370 | 2005-02-22 | 2005-02-23 | 1d | 106.5d | 0d | {5BDC9DE6-6CF4-48E5-BAEE-7304D3C6D692} |
| 372 | 6.2.10.4 | Identify architecture alternatives |  | 1d | 2005-02-22 | 2005-02-23 | 370 | 2005-02-22 | 2005-02-23 | 1d | 106.5d | 0d | {6A64E297-7418-40AD-BF08-A3EA99FAA6AA} |
| 373 | 6.2.10.5 | Segment draft requirements |  | 1d | 2005-02-23 | 2005-02-24 | 371, 372 | 2005-02-23 | 2005-02-24 | 1d | 106.5d | 0d | {5D8AF282-2FE1-46FF-AFA0-0BAC2F87CC2B} |
| 374 | 6.2.10.6 | Review segmentation with stakeholders |  | 1d | 2005-02-24 | 2005-02-25 | 373 | 2005-02-24 | 2005-02-25 | 1d | 106.5d | 0d | {A8487E90-0285-42DA-8FD6-878781F6B616} |
| 375 | 6.2.10.7 | Revise segmentation of requirements |  | 1d | 2005-02-25 | 2005-02-28 | 374 | 2005-02-25 | 2005-02-28 | 1d | 106.5d |  | {3989A3F9-971E-4C5F-93D4-E3573DFAE79C} |
| 376 | 6.2.11 | **Build requirements deliverables** |  | 11d | 2005-02-28 | 2005-03-15 | 368 | 2005-02-28 | 2005-03-15 | 11d | 106.5d | 0d | {394DBB3C-8440-4CDE-A852-21CA82C4ED37} |
| 377 | 6.2.11.1 | Finalize reqts documentation strategy |  | 1d | 2005-02-28 | 2005-03-01 |  | 2005-02-28 | 2005-03-01 | 1d | 106.5d | 0d | {EADE2312-FC99-4ADC-B46E-9E7A61C136E3} |
| 378 | 6.2.11.2 | Build requirements specifications |  | 4d | 2005-03-01 | 2005-03-07 | 377 | 2005-03-01 | 2005-03-07 | 4d | 106.5d | 0d | {D4C7008E-4FBE-4984-AE1F-0B6CBF026E84} |
| 379 | 6.2.11.3 | Circulate for team review |  | 1d | 2005-03-07 | 2005-03-08 | 378 | 2005-03-07 | 2005-03-08 | 1d | 106.5d | 0d | {DAAE0052-8B8E-4057-A0F8-4C7EA52C53B1} |
| 380 | 6.2.11.4 | Revise based on team feedback |  | 1d | 2005-03-08 | 2005-03-09 | 379 | 2005-03-08 | 2005-03-09 | 1d | 106.5d | 0d | {8E9A45BF-CCE4-4E4F-B103-C53619A5C947} |
| 381 | 6.2.11.5 | Conduct walkthrough for stakeholders |  | 1d | 2005-03-09 | 2005-03-10 | 380 | 2005-03-09 | 2005-03-10 | 1d | 106.5d | 0d | {2147F24F-EBD7-41FE-9996-9ECAD1296CC0} |
| 382 | 6.2.11.6 | Finalize requirements specification |  | 1d | 2005-03-10 | 2005-03-11 | 381 | 2005-03-10 | 2005-03-11 | 1d | 106.5d | 0d | {2BF3C98B-D281-4919-95EA-4F57F39502A1} |
| 383 | 6.2.11.7 | Conduct requirements peer review |  | 1d | 2005-03-11 | 2005-03-14 | 382 | 2005-03-11 | 2005-03-14 | 1d | 106.5d | 0d | {6259044D-BDF9-4DA9-8B09-CA5418D6A320} |
| 384 | 6.2.11.8 | Apply peer feedback to requirements |  | 1d | 2005-03-14 | 2005-03-15 | 383 | 2005-03-14 | 2005-03-15 | 1d | 106.5d |  | {2E816B05-E837-4427-A93F-A1B6F38CB554} |
| 385 | 6.2.12 | **Finalize requirements** |  | 7d | 2005-03-15 | 2005-03-24 | 376 | 2005-03-15 | 2005-03-24 | 7d | 106.5d | 0d | {6886E03B-DD13-4E6C-9EF9-D1F4ACFE1ED2} |
| 386 | 6.2.12.1 | Consolidate all draft feedback |  | 1d | 2005-03-15 | 2005-03-16 |  | 2005-03-15 | 2005-03-16 | 1d | 106.5d | 0d | {11A2D364-42F5-4317-A90D-C5616B5DF98A} |
| 387 | 6.2.12.2 | Update requirements specifications |  | 1d | 2005-03-16 | 2005-03-17 | 386 | 2005-03-16 | 2005-03-17 | 1d | 106.5d | 0d | {F97CA563-BED9-4BC6-8001-B8F5755E2B75} |
| 388 | 6.2.12.3 | Build final requirements deliverables |  | 1d | 2005-03-17 | 2005-03-18 | 387 | 2005-03-17 | 2005-03-18 | 1d | 106.5d | 0d | {C3AAF7C9-03CA-4DDE-BC67-EE16E9111F1E} |
| 389 | 6.2.12.4 | Circulate for review |  | 1d | 2005-03-18 | 2005-03-21 | 388 | 2005-03-18 | 2005-03-21 | 1d | 106.5d | 0d | {EBFF9D26-5E28-4074-B935-18E07CC16789} |
| 390 | 6.2.12.5 | Revise based on team feedback |  | 1d | 2005-03-21 | 2005-03-22 | 389 | 2005-03-21 | 2005-03-22 | 1d | 106.5d | 0d | {1E1CCF83-2676-4BF4-93E3-98C27A79C4B7} |
| 391 | 6.2.12.6 | Conduct walkthrough with stakeholders |  | 1d | 2005-03-22 | 2005-03-23 | 390 | 2005-03-22 | 2005-03-23 | 1d | 106.5d | 0d | {DD84FCAC-B2D2-412C-8D9C-276BBD3E0286} |
| 392 | 6.2.12.7 | Finalize requirements specification |  | 1d | 2005-03-23 | 2005-03-24 | 391 | 2005-03-23 | 2005-03-24 | 1d | 106.5d | 0d | {E84F2F5F-9E29-44AF-A228-410657781B62} |
| 393 | 6.2.12.8 | Approve requirements specification | milestone | 0d | 2005-03-24 | 2005-03-24 | 392 | 2005-03-24 | 2005-03-24 | 0d | 106.5d |  | {A61CC3BD-835D-4A59-A711-F170817932F7} |

Notes:
- 368: Text3: <sync-guid>{BEF2567E-CE9E-448B-B505-FD7D71A45672}</sync-guid><sync-parentguid>{C262EF5A-5F48-4212-9B7E-5E84299355EC}</sync-parentguid><sync-checksum>-409849834</sync-checksum><sync-rootid>0</sync-rootid><sync-itemtype>0</sync-itemtype><sync-timestamp>12/2 / Text5: 1/2004 9:44:52 AM</sync-timestamp><sync-itemid>439</sync-itemid><sync-prioritymapping>0:0-0/1:700-1000/2:300-699/3:1-299</sync-prioritymapping>
- 369: Text3: <sync-guid>{CD0D24AF-AAC4-4827-87C0-7D9A7766CD79}</sync-guid><sync-parentguid>{BEF2567E-CE9E-448B-B505-FD7D71A45672}</sync-parentguid><sync-checksum>-481965037</sync-checksum><sync-rootid>0</sync-rootid><sync-itemtype>0</sync-itemtype><sync-timestamp>12/2 / Text5: 1/2004 9:44:52 AM</sync-timestamp><sync-itemid>438</sync-itemid><sync-prioritymapping>0:0-0/1:700-1000/2:300-699/3:1-299</sync-prioritymapping>
- 370: Text3: <sync-guid>{238C873E-D2E8-42C5-AF3A-6E5407ABCBBE}</sync-guid><sync-parentguid>{BEF2567E-CE9E-448B-B505-FD7D71A45672}</sync-parentguid><sync-checksum>1502060148</sync-checksum><sync-rootid>0</sync-rootid><sync-itemtype>0</sync-itemtype><sync-timestamp>12/2 / Text5: 1/2004 9:44:53 AM</sync-timestamp><sync-itemid>437</sync-itemid><sync-prioritymapping>0:0-0/1:700-1000/2:300-699/3:1-299</sync-prioritymapping>
- 371: Text3: <sync-guid>{5BDC9DE6-6CF4-48E5-BAEE-7304D3C6D692}</sync-guid><sync-parentguid>{BEF2567E-CE9E-448B-B505-FD7D71A45672}</sync-parentguid><sync-checksum>-131849434</sync-checksum><sync-rootid>0</sync-rootid><sync-itemtype>0</sync-itemtype><sync-timestamp>12/2 / Text5: 1/2004 9:44:53 AM</sync-timestamp><sync-itemid>436</sync-itemid><sync-prioritymapping>0:0-0/1:700-1000/2:300-699/3:1-299</sync-prioritymapping>
- 372: Text3: <sync-guid>{6A64E297-7418-40AD-BF08-A3EA99FAA6AA}</sync-guid><sync-parentguid>{BEF2567E-CE9E-448B-B505-FD7D71A45672}</sync-parentguid><sync-checksum>1871185174</sync-checksum><sync-rootid>0</sync-rootid><sync-itemtype>0</sync-itemtype><sync-timestamp>12/2 / Text5: 1/2004 9:44:53 AM</sync-timestamp><sync-itemid>435</sync-itemid><sync-prioritymapping>0:0-0/1:700-1000/2:300-699/3:1-299</sync-prioritymapping>
- 373: Text3: <sync-guid>{5D8AF282-2FE1-46FF-AFA0-0BAC2F87CC2B}</sync-guid><sync-parentguid>{BEF2567E-CE9E-448B-B505-FD7D71A45672}</sync-parentguid><sync-checksum>-1682362071</sync-checksum><sync-rootid>0</sync-rootid><sync-itemtype>0</sync-itemtype><sync-timestamp>12 / Text5: 21/2004 9:44:53 AM</sync-timestamp><sync-itemid>1028</sync-itemid><sync-prioritymapping>0:0-0/1:700-1000/2:300-699/3:1-299</sync-prioritymapping>
- 374: Text3: <sync-guid>{A8487E90-0285-42DA-8FD6-878781F6B616}</sync-guid><sync-parentguid>{BEF2567E-CE9E-448B-B505-FD7D71A45672}</sync-parentguid><sync-checksum>1041393553</sync-checksum><sync-rootid>0</sync-rootid><sync-itemtype>0</sync-itemtype><sync-timestamp>12/2 / Text5: 1/2004 9:44:53 AM</sync-timestamp><sync-itemid>1029</sync-itemid><sync-prioritymapping>0:0-0/1:700-1000/2:300-699/3:1-299</sync-prioritymapping>
- 375: Text3: <sync-guid>{3989A3F9-971E-4C5F-93D4-E3573DFAE79C}</sync-guid><sync-parentguid>{BEF2567E-CE9E-448B-B505-FD7D71A45672}</sync-parentguid><sync-checksum>1095490286</sync-checksum><sync-rootid>0</sync-rootid><sync-itemtype>0</sync-itemtype><sync-timestamp>12/2 / Text5: 1/2004 9:44:53 AM</sync-timestamp><sync-itemid>1030</sync-itemid><sync-prioritymapping>0:0-0/1:700-1000/2:300-699/3:1-299</sync-prioritymapping>
- 376: Text3: <sync-guid>{394DBB3C-8440-4CDE-A852-21CA82C4ED37}</sync-guid><sync-parentguid>{C262EF5A-5F48-4212-9B7E-5E84299355EC}</sync-parentguid><sync-checksum>1564153795</sync-checksum><sync-rootid>0</sync-rootid><sync-itemtype>0</sync-itemtype><sync-timestamp>12/2 / Text5: 1/2004 9:44:53 AM</sync-timestamp><sync-itemid>426</sync-itemid><sync-prioritymapping>0:0-0/1:700-1000/2:300-699/3:1-299</sync-prioritymapping>
- 377: Text3: <sync-guid>{EADE2312-FC99-4ADC-B46E-9E7A61C136E3}</sync-guid><sync-parentguid>{394DBB3C-8440-4CDE-A852-21CA82C4ED37}</sync-parentguid><sync-checksum>-107050571</sync-checksum><sync-rootid>0</sync-rootid><sync-itemtype>0</sync-itemtype><sync-timestamp>12/2 / Text5: 1/2004 9:44:53 AM</sync-timestamp><sync-itemid>425</sync-itemid><sync-prioritymapping>0:0-0/1:700-1000/2:300-699/3:1-299</sync-prioritymapping>
- 378: Text3: <sync-guid>{D4C7008E-4FBE-4984-AE1F-0B6CBF026E84}</sync-guid><sync-parentguid>{394DBB3C-8440-4CDE-A852-21CA82C4ED37}</sync-parentguid><sync-checksum>-2110007945</sync-checksum><sync-rootid>0</sync-rootid><sync-itemtype>0</sync-itemtype><sync-timestamp>12 / Text5: 21/2004 9:44:53 AM</sync-timestamp><sync-itemid>424</sync-itemid><sync-prioritymapping>0:0-0/1:700-1000/2:300-699/3:1-299</sync-prioritymapping>
- 379: Text3: <sync-guid>{DAAE0052-8B8E-4057-A0F8-4C7EA52C53B1}</sync-guid><sync-parentguid>{394DBB3C-8440-4CDE-A852-21CA82C4ED37}</sync-parentguid><sync-checksum>647834620</sync-checksum><sync-rootid>0</sync-rootid><sync-itemtype>0</sync-itemtype><sync-timestamp>12/21 / Text5: 2004 9:44:53 AM</sync-timestamp><sync-itemid>422</sync-itemid><sync-prioritymapping>0:0-0/1:700-1000/2:300-699/3:1-299</sync-prioritymapping>
- 380: Text3: <sync-guid>{8E9A45BF-CCE4-4E4F-B103-C53619A5C947}</sync-guid><sync-parentguid>{394DBB3C-8440-4CDE-A852-21CA82C4ED37}</sync-parentguid><sync-checksum>-2049546695</sync-checksum><sync-rootid>0</sync-rootid><sync-itemtype>0</sync-itemtype><sync-timestamp>12 / Text5: 21/2004 9:44:53 AM</sync-timestamp><sync-itemid>1031</sync-itemid><sync-prioritymapping>0:0-0/1:700-1000/2:300-699/3:1-299</sync-prioritymapping>
- 381: Text3: <sync-guid>{2147F24F-EBD7-41FE-9996-9ECAD1296CC0}</sync-guid><sync-parentguid>{394DBB3C-8440-4CDE-A852-21CA82C4ED37}</sync-parentguid><sync-checksum>1519315065</sync-checksum><sync-rootid>0</sync-rootid><sync-itemtype>0</sync-itemtype><sync-timestamp>12/2 / Text5: 1/2004 9:44:54 AM</sync-timestamp><sync-itemid>421</sync-itemid><sync-prioritymapping>0:0-0/1:700-1000/2:300-699/3:1-299</sync-prioritymapping>
- 382: Text3: <sync-guid>{2BF3C98B-D281-4919-95EA-4F57F39502A1}</sync-guid><sync-parentguid>{394DBB3C-8440-4CDE-A852-21CA82C4ED37}</sync-parentguid><sync-checksum>1215546939</sync-checksum><sync-rootid>0</sync-rootid><sync-itemtype>0</sync-itemtype><sync-timestamp>12/2 / Text5: 1/2004 9:44:54 AM</sync-timestamp><sync-itemid>420</sync-itemid><sync-prioritymapping>0:0-0/1:700-1000/2:300-699/3:1-299</sync-prioritymapping>
- 383: Text3: <sync-guid>{6259044D-BDF9-4DA9-8B09-CA5418D6A320}</sync-guid><sync-parentguid>{394DBB3C-8440-4CDE-A852-21CA82C4ED37}</sync-parentguid><sync-checksum>-338083999</sync-checksum><sync-rootid>0</sync-rootid><sync-itemtype>0</sync-itemtype><sync-timestamp>12/2 / Text5: 1/2004 9:44:54 AM</sync-timestamp><sync-itemid>419</sync-itemid><sync-prioritymapping>0:0-0/1:700-1000/2:300-699/3:1-299</sync-prioritymapping>
- 384: Text3: <sync-guid>{2E816B05-E837-4427-A93F-A1B6F38CB554}</sync-guid><sync-parentguid>{394DBB3C-8440-4CDE-A852-21CA82C4ED37}</sync-parentguid><sync-checksum>-674889138</sync-checksum><sync-rootid>0</sync-rootid><sync-itemtype>0</sync-itemtype><sync-timestamp>12/2 / Text5: 1/2004 9:44:54 AM</sync-timestamp><sync-itemid>1027</sync-itemid><sync-prioritymapping>0:0-0/1:700-1000/2:300-699/3:1-299</sync-prioritymapping>
- 385: Text3: <sync-guid>{6886E03B-DD13-4E6C-9EF9-D1F4ACFE1ED2}</sync-guid><sync-parentguid>{C262EF5A-5F48-4212-9B7E-5E84299355EC}</sync-parentguid><sync-checksum>1581296440</sync-checksum><sync-rootid>0</sync-rootid><sync-itemtype>0</sync-itemtype><sync-timestamp>12/2 / Text5: 1/2004 9:44:54 AM</sync-timestamp><sync-itemid>283</sync-itemid><sync-prioritymapping>0:0-0/1:700-1000/2:300-699/3:1-299</sync-prioritymapping>
- 386: Text3: <sync-guid>{11A2D364-42F5-4317-A90D-C5616B5DF98A}</sync-guid><sync-parentguid>{6886E03B-DD13-4E6C-9EF9-D1F4ACFE1ED2}</sync-parentguid><sync-checksum>529181228</sync-checksum><sync-rootid>0</sync-rootid><sync-itemtype>0</sync-itemtype><sync-timestamp>12/21 / Text5: 2004 9:44:54 AM</sync-timestamp><sync-itemid>284</sync-itemid><sync-prioritymapping>0:0-0/1:700-1000/2:300-699/3:1-299</sync-prioritymapping>
- 387: Text3: <sync-guid>{F97CA563-BED9-4BC6-8001-B8F5755E2B75}</sync-guid><sync-parentguid>{6886E03B-DD13-4E6C-9EF9-D1F4ACFE1ED2}</sync-parentguid><sync-checksum>1900560731</sync-checksum><sync-rootid>0</sync-rootid><sync-itemtype>0</sync-itemtype><sync-timestamp>12/2 / Text5: 1/2004 9:44:54 AM</sync-timestamp><sync-itemid>285</sync-itemid><sync-prioritymapping>0:0-0/1:700-1000/2:300-699/3:1-299</sync-prioritymapping>
- 388: Text3: <sync-guid>{C3AAF7C9-03CA-4DDE-BC67-EE16E9111F1E}</sync-guid><sync-parentguid>{6886E03B-DD13-4E6C-9EF9-D1F4ACFE1ED2}</sync-parentguid><sync-checksum>2072539249</sync-checksum><sync-rootid>0</sync-rootid><sync-itemtype>0</sync-itemtype><sync-timestamp>12/2 / Text5: 1/2004 9:44:54 AM</sync-timestamp><sync-itemid>286</sync-itemid><sync-prioritymapping>0:0-0/1:700-1000/2:300-699/3:1-299</sync-prioritymapping>
- 389: Text3: <sync-guid>{EBFF9D26-5E28-4074-B935-18E07CC16789}</sync-guid><sync-parentguid>{6886E03B-DD13-4E6C-9EF9-D1F4ACFE1ED2}</sync-parentguid><sync-checksum>508611648</sync-checksum><sync-rootid>0</sync-rootid><sync-itemtype>0</sync-itemtype><sync-timestamp>12/21 / Text5: 2004 9:44:54 AM</sync-timestamp><sync-itemid>287</sync-itemid><sync-prioritymapping>0:0-0/1:700-1000/2:300-699/3:1-299</sync-prioritymapping>
- 390: Text3: <sync-guid>{1E1CCF83-2676-4BF4-93E3-98C27A79C4B7}</sync-guid><sync-parentguid>{6886E03B-DD13-4E6C-9EF9-D1F4ACFE1ED2}</sync-parentguid><sync-checksum>-2006934539</sync-checksum><sync-rootid>0</sync-rootid><sync-itemtype>0</sync-itemtype><sync-timestamp>12 / Text5: 21/2004 9:44:54 AM</sync-timestamp><sync-itemid>1032</sync-itemid><sync-prioritymapping>0:0-0/1:700-1000/2:300-699/3:1-299</sync-prioritymapping>
- 391: Text3: <sync-guid>{DD84FCAC-B2D2-412C-8D9C-276BBD3E0286}</sync-guid><sync-parentguid>{6886E03B-DD13-4E6C-9EF9-D1F4ACFE1ED2}</sync-parentguid><sync-checksum>2042904702</sync-checksum><sync-rootid>0</sync-rootid><sync-itemtype>0</sync-itemtype><sync-timestamp>12/2 / Text5: 1/2004 9:44:54 AM</sync-timestamp><sync-itemid>288</sync-itemid><sync-prioritymapping>0:0-0/1:700-1000/2:300-699/3:1-299</sync-prioritymapping>
- 392: Text3: <sync-guid>{E84F2F5F-9E29-44AF-A228-410657781B62}</sync-guid><sync-parentguid>{6886E03B-DD13-4E6C-9EF9-D1F4ACFE1ED2}</sync-parentguid><sync-checksum>-1179839796</sync-checksum><sync-rootid>0</sync-rootid><sync-itemtype>0</sync-itemtype><sync-timestamp>12 / Text5: 21/2004 9:44:55 AM</sync-timestamp><sync-itemid>289</sync-itemid><sync-prioritymapping>0:0-0/1:700-1000/2:300-699/3:1-299</sync-prioritymapping>
- 393: Text3: <sync-guid>{A61CC3BD-835D-4A59-A711-F170817932F7}</sync-guid><sync-parentguid>{6886E03B-DD13-4E6C-9EF9-D1F4ACFE1ED2}</sync-parentguid><sync-checksum>1412764129</sync-checksum><sync-rootid>0</sync-rootid><sync-itemtype>0</sync-itemtype><sync-timestamp>1/10 / Text5: 2005 9:28:52 AM</sync-timestamp><sync-itemid>290</sync-itemid><sync-prioritymapping>0:0-0/1:700-1000/2:300-699/3:1-299</sync-prioritymapping>

| ID | WBS | Task | Type | Duration | Start | Finish | Predecessors | Baseline start | Baseline finish | Baseline duration | Total slack | Free slack | Text4 |
| --- | --- | --- | --- | --- | --- | --- | --- | --- | --- | --- | --- | --- | --- |
| 394 | 6.2.13 | **Define acceptance test plan** |  | 13d | 2005-03-08 | 2005-03-25 | 379 | 2005-03-08 | 2005-03-25 | 13d | 107.5d |  | {F33DDF90-FB31-44CD-8A73-7EEE0949B943} |
| 395 | 6.2.13.1 | Define testing objectives |  | 1d | 2005-03-08 | 2005-03-09 |  | 2005-03-08 | 2005-03-09 | 1d | 112.5d | 0d | {0EC9EBEC-E849-40C6-BF2C-A99382487603} |
| 396 | 6.2.13.2 | Develop system-level scenarios |  | 1d | 2005-03-09 | 2005-03-10 | 395 | 2005-03-09 | 2005-03-10 | 1d | 112.5d | 0d | {B1963044-3E58-458F-8169-F661CCC81A2F} |
| 397 | 6.2.13.3 | Define test cases & outcomes |  | 1d | 2005-03-10 | 2005-03-11 | 396 | 2005-03-10 | 2005-03-11 | 1d | 112.5d | 0d | {EAC781DD-13CD-448B-A8A7-B93292A6EC36} |
| 398 | 6.2.13.4 | Develop test conditions and data |  | 1d | 2005-03-11 | 2005-03-14 | 397 | 2005-03-11 | 2005-03-14 | 1d | 112.5d | 0d | {157A176B-CB85-4748-BBE5-8613C1811301} |
| 399 | 6.2.13.5 | Define acceptance responsibilities |  | 1d | 2005-03-14 | 2005-03-15 | 398 | 2005-03-14 | 2005-03-15 | 1d | 112.5d | 0d | {DBD44D15-77D9-4181-B26E-53C702EB0370} |
| 400 | 6.2.13.6 | Consolidate acceptance test plan |  | 1d | 2005-03-15 | 2005-03-16 | 399 | 2005-03-15 | 2005-03-16 | 1d | 112.5d | 5d | {2FF898FA-CBF3-469C-BE20-64B2BB4E572F} |
| 401 | 6.2.13.7 | Conduct peer review of acceptance plan |  | 1d | 2005-03-23 | 2005-03-24 | 400, 391 | 2005-03-23 | 2005-03-24 | 1d | 107.5d | 0d | {3D1F930A-DB60-46FF-B99B-EA1917C7E8A6} |
| 402 | 6.2.13.8 | Revise test plan based on feedback |  | 1d | 2005-03-24 | 2005-03-25 | 401 | 2005-03-24 | 2005-03-25 | 1d | 107.5d | 0d | {D690E33C-F176-4D13-94F9-61B24FA38B1C} |
| 403 | 6.2.13.9 | Approve acceptance test plan | milestone | 0d | 2005-03-25 | 2005-03-25 | 402 | 2005-03-25 | 2005-03-25 | 0d | 107.5d |  | {C27D0DCE-3459-4A6A-9198-C6F0B51FB53E} |
| 404 | 6.2.14 | **Update subproject plan** |  | 4d | 2005-03-21 | 2005-03-25 | 389 | 2005-03-21 | 2005-03-25 | 4d | 107.5d |  | {42A1BDAF-07E8-48E2-A41C-A4EF4365F19A} |
| 405 | 6.2.14.1 | Review project status and milestones |  | 1d | 2005-03-21 | 2005-03-22 |  | 2005-03-21 | 2005-03-22 | 1d | 107.5d | 0d | {CD499C08-0923-4D27-BA54-04B5B42E8C3C} |
| 406 | 6.2.14.2 | Revise plan schedule & assignments |  | 1d | 2005-03-22 | 2005-03-23 | 405 | 2005-03-22 | 2005-03-23 | 1d | 107.5d | 0d | {DC42509B-EBAC-4A8D-9362-133BF9BF746D} |
| 407 | 6.2.14.3 | Review charter & plan with stakeholders |  | 1d | 2005-03-23 | 2005-03-24 | 406 | 2005-03-23 | 2005-03-24 | 1d | 107.5d | 0d | {AEA2E6D8-DDCE-400C-BBA2-BBC3F03D5779} |
| 408 | 6.2.14.4 | Finalize plan revisions |  | 1d | 2005-03-24 | 2005-03-25 | 407 | 2005-03-24 | 2005-03-25 | 1d | 107.5d | 0d | {2C9F6C64-EB87-4C52-B3DC-70683FE1CCBE} |
| 409 | 6.2.14.5 | Approve revised subproject plan | milestone | 0d | 2005-03-25 | 2005-03-25 | 408 | 2005-03-25 | 2005-03-25 | 0d | 107.5d |  | {ECD9650F-7477-4706-B489-52D38E33D413} |
| 410 | 6.2.15 | **Conduct phase QA assessment** |  | 2d | 2005-03-24 | 2005-03-28 | 385 | 2005-03-24 | 2005-03-28 | 2d | 106.5d |  | {12B4BAA6-89B0-4039-B9E8-A5B7B5CE20E9} |
| 411 | 6.2.15.1 | Consolidate phase results |  | 0.5d | 2005-03-24 | 2005-03-24 |  | 2005-03-24 | 2005-03-24 | 0.5d | 106.5d | 0d | {4A958737-355F-436E-8A23-B39C4F51DE26} |
| 412 | 6.2.15.2 | Conduct phase self-assessment |  | 0.25d | 2005-03-25 | 2005-03-25 | 411 | 2005-03-25 | 2005-03-25 | 0.25d | 106.5d | 0d | {9C98F157-A879-4ED5-A5CF-0F8088AAE41E} |
| 413 | 6.2.15.3 | Conduct QA assessment |  | 0.5d | 2005-03-25 | 2005-03-25 | 412 | 2005-03-25 | 2005-03-25 | 0.5d | 106.5d | 0d | {2A23A213-2619-41F8-8F95-394CB6B21908} |
| 414 | 6.2.15.4 | Review assessment feedback |  | 0.25d | 2005-03-25 | 2005-03-25 | 413 | 2005-03-25 | 2005-03-25 | 0.25d | 106.5d | 0d | {456A4AC1-7B9A-475C-B978-46FBD1CE43F1} |
| 415 | 6.2.15.5 | Implement QA feedback |  | 0.5d | 2005-03-28 | 2005-03-28 | 414 | 2005-03-28 | 2005-03-28 | 0.5d | 106.5d |  | {2EC09B5D-3DE9-482E-8BA2-D33888F6DB09} |
| 416 | 6.3 | **BID & CONTRACT** |  | 4d? | 2005-03-15 | 2005-03-21 | 385SS | 2005-03-15 | 2005-03-21 | 4d? | 52.5d | 0d | {03522C42-F1C0-43E4-A4A9-38DC904A263E} |
| 417 | 6.3.1 | < Project-specific Tasks > |  | 1d? | 2005-03-15 | 2005-03-16 |  | 2005-03-15 | 2005-03-16 | 1d? | 55.5d |  | {3E688726-486E-4660-B789-6727BF41A2C4} |

Notes:
- 394: Text3: <sync-guid>{F33DDF90-FB31-44CD-8A73-7EEE0949B943}</sync-guid><sync-parentguid>{C262EF5A-5F48-4212-9B7E-5E84299355EC}</sync-parentguid><sync-checksum>-1045478304</sync-checksum><sync-rootid>0</sync-rootid><sync-itemtype>0</sync-itemtype><sync-timestamp>1/1 / Text5: 0/2005 9:26:26 AM</sync-timestamp><sync-itemid>1302</sync-itemid><sync-prioritymapping>0:0-0/1:700-1000/2:300-699/3:1-299</sync-prioritymapping>
- 395: Text3: <sync-guid>{0EC9EBEC-E849-40C6-BF2C-A99382487603}</sync-guid><sync-parentguid>{F33DDF90-FB31-44CD-8A73-7EEE0949B943}</sync-parentguid><sync-checksum>225641832</sync-checksum><sync-rootid>0</sync-rootid><sync-itemtype>0</sync-itemtype><sync-timestamp>1/10 / Text5: 2005 9:26:26 AM</sync-timestamp><sync-itemid>1301</sync-itemid><sync-prioritymapping>0:0-0/1:700-1000/2:300-699/3:1-299</sync-prioritymapping>
- 396: Text3: <sync-guid>{B1963044-3E58-458F-8169-F661CCC81A2F}</sync-guid><sync-parentguid>{F33DDF90-FB31-44CD-8A73-7EEE0949B943}</sync-parentguid><sync-checksum>-692264395</sync-checksum><sync-rootid>0</sync-rootid><sync-itemtype>0</sync-itemtype><sync-timestamp>1/10 / Text5: 2005 9:26:26 AM</sync-timestamp><sync-itemid>1300</sync-itemid><sync-prioritymapping>0:0-0/1:700-1000/2:300-699/3:1-299</sync-prioritymapping>
- 397: Text3: <sync-guid>{EAC781DD-13CD-448B-A8A7-B93292A6EC36}</sync-guid><sync-parentguid>{F33DDF90-FB31-44CD-8A73-7EEE0949B943}</sync-parentguid><sync-checksum>-542612477</sync-checksum><sync-rootid>0</sync-rootid><sync-itemtype>0</sync-itemtype><sync-timestamp>1/10 / Text5: 2005 9:26:27 AM</sync-timestamp><sync-itemid>1299</sync-itemid><sync-prioritymapping>0:0-0/1:700-1000/2:300-699/3:1-299</sync-prioritymapping>
- 398: Text3: <sync-guid>{157A176B-CB85-4748-BBE5-8613C1811301}</sync-guid><sync-parentguid>{F33DDF90-FB31-44CD-8A73-7EEE0949B943}</sync-parentguid><sync-checksum>-2071686215</sync-checksum><sync-rootid>0</sync-rootid><sync-itemtype>0</sync-itemtype><sync-timestamp>1/1 / Text5: 0/2005 9:26:27 AM</sync-timestamp><sync-itemid>1298</sync-itemid><sync-prioritymapping>0:0-0/1:700-1000/2:300-699/3:1-299</sync-prioritymapping>
- 399: Text3: <sync-guid>{DBD44D15-77D9-4181-B26E-53C702EB0370}</sync-guid><sync-parentguid>{F33DDF90-FB31-44CD-8A73-7EEE0949B943}</sync-parentguid><sync-checksum>-927233595</sync-checksum><sync-rootid>0</sync-rootid><sync-itemtype>0</sync-itemtype><sync-timestamp>1/10 / Text5: 2005 9:26:27 AM</sync-timestamp><sync-itemid>1297</sync-itemid><sync-prioritymapping>0:0-0/1:700-1000/2:300-699/3:1-299</sync-prioritymapping>
- 400: Text3: <sync-guid>{2FF898FA-CBF3-469C-BE20-64B2BB4E572F}</sync-guid><sync-parentguid>{F33DDF90-FB31-44CD-8A73-7EEE0949B943}</sync-parentguid><sync-checksum>203649157</sync-checksum><sync-rootid>0</sync-rootid><sync-itemtype>0</sync-itemtype><sync-timestamp>1/10 / Text5: 2005 9:26:27 AM</sync-timestamp><sync-itemid>1296</sync-itemid><sync-prioritymapping>0:0-0/1:700-1000/2:300-699/3:1-299</sync-prioritymapping>
- 401: Text3: <sync-guid>{3D1F930A-DB60-46FF-B99B-EA1917C7E8A6}</sync-guid><sync-parentguid>{F33DDF90-FB31-44CD-8A73-7EEE0949B943}</sync-parentguid><sync-checksum>184073146</sync-checksum><sync-rootid>0</sync-rootid><sync-itemtype>0</sync-itemtype><sync-timestamp>1/10 / Text5: 2005 9:26:28 AM</sync-timestamp><sync-itemid>1295</sync-itemid><sync-prioritymapping>0:0-0/1:700-1000/2:300-699/3:1-299</sync-prioritymapping>
- 402: Text3: <sync-guid>{D690E33C-F176-4D13-94F9-61B24FA38B1C}</sync-guid><sync-parentguid>{F33DDF90-FB31-44CD-8A73-7EEE0949B943}</sync-parentguid><sync-checksum>-2144523771</sync-checksum><sync-rootid>0</sync-rootid><sync-itemtype>0</sync-itemtype><sync-timestamp>1/1 / Text5: 0/2005 9:26:28 AM</sync-timestamp><sync-itemid>1294</sync-itemid><sync-prioritymapping>0:0-0/1:700-1000/2:300-699/3:1-299</sync-prioritymapping>
- 403: Text3: <sync-guid>{C27D0DCE-3459-4A6A-9198-C6F0B51FB53E}</sync-guid><sync-parentguid>{F33DDF90-FB31-44CD-8A73-7EEE0949B943}</sync-parentguid><sync-checksum>-111441324</sync-checksum><sync-rootid>0</sync-rootid><sync-itemtype>0</sync-itemtype><sync-timestamp>1/10 / Text5: 2005 9:26:28 AM</sync-timestamp><sync-itemid>1293</sync-itemid><sync-prioritymapping>0:0-0/1:700-1000/2:300-699/3:1-299</sync-prioritymapping>
- 404: Text3: <sync-guid>{42A1BDAF-07E8-48E2-A41C-A4EF4365F19A}</sync-guid><sync-parentguid>{C262EF5A-5F48-4212-9B7E-5E84299355EC}</sync-parentguid><sync-checksum>-1677106715</sync-checksum><sync-rootid>0</sync-rootid><sync-itemtype>0</sync-itemtype><sync-timestamp>12 / Text5: 21/2004 9:44:55 AM</sync-timestamp><sync-itemid>663</sync-itemid><sync-prioritymapping>0:0-0/1:700-1000/2:300-699/3:1-299</sync-prioritymapping>
- 405: Text3: <sync-guid>{CD499C08-0923-4D27-BA54-04B5B42E8C3C}</sync-guid><sync-parentguid>{42A1BDAF-07E8-48E2-A41C-A4EF4365F19A}</sync-parentguid><sync-checksum>-1553178452</sync-checksum><sync-rootid>0</sync-rootid><sync-itemtype>0</sync-itemtype><sync-timestamp>12 / Text5: 21/2004 9:44:55 AM</sync-timestamp><sync-itemid>662</sync-itemid><sync-prioritymapping>0:0-0/1:700-1000/2:300-699/3:1-299</sync-prioritymapping>
- 406: Text3: <sync-guid>{DC42509B-EBAC-4A8D-9362-133BF9BF746D}</sync-guid><sync-parentguid>{42A1BDAF-07E8-48E2-A41C-A4EF4365F19A}</sync-parentguid><sync-checksum>-858147568</sync-checksum><sync-rootid>0</sync-rootid><sync-itemtype>0</sync-itemtype><sync-timestamp>12/2 / Text5: 1/2004 9:44:55 AM</sync-timestamp><sync-itemid>661</sync-itemid><sync-prioritymapping>0:0-0/1:700-1000/2:300-699/3:1-299</sync-prioritymapping>
- 407: Text3: <sync-guid>{AEA2E6D8-DDCE-400C-BBA2-BBC3F03D5779}</sync-guid><sync-parentguid>{42A1BDAF-07E8-48E2-A41C-A4EF4365F19A}</sync-parentguid><sync-checksum>-1779614499</sync-checksum><sync-rootid>0</sync-rootid><sync-itemtype>0</sync-itemtype><sync-timestamp>12 / Text5: 21/2004 9:44:55 AM</sync-timestamp><sync-itemid>660</sync-itemid><sync-prioritymapping>0:0-0/1:700-1000/2:300-699/3:1-299</sync-prioritymapping>
- 408: Text3: <sync-guid>{2C9F6C64-EB87-4C52-B3DC-70683FE1CCBE}</sync-guid><sync-parentguid>{42A1BDAF-07E8-48E2-A41C-A4EF4365F19A}</sync-parentguid><sync-checksum>-1532000170</sync-checksum><sync-rootid>0</sync-rootid><sync-itemtype>0</sync-itemtype><sync-timestamp>12 / Text5: 21/2004 9:44:55 AM</sync-timestamp><sync-itemid>659</sync-itemid><sync-prioritymapping>0:0-0/1:700-1000/2:300-699/3:1-299</sync-prioritymapping>
- 409: Text3: <sync-guid>{ECD9650F-7477-4706-B489-52D38E33D413}</sync-guid><sync-parentguid>{42A1BDAF-07E8-48E2-A41C-A4EF4365F19A}</sync-parentguid><sync-checksum>181961954</sync-checksum><sync-rootid>0</sync-rootid><sync-itemtype>0</sync-itemtype><sync-timestamp>12/21 / Text5: 2004 9:44:55 AM</sync-timestamp><sync-itemid>658</sync-itemid><sync-prioritymapping>0:0-0/1:700-1000/2:300-699/3:1-299</sync-prioritymapping>
- 410: Text3: <sync-guid>{12B4BAA6-89B0-4039-B9E8-A5B7B5CE20E9}</sync-guid><sync-parentguid>{C262EF5A-5F48-4212-9B7E-5E84299355EC}</sync-parentguid><sync-checksum>-1921177616</sync-checksum><sync-rootid>0</sync-rootid><sync-itemtype>0</sync-itemtype><sync-timestamp>12 / Text5: 30/2004 1:12:34 PM</sync-timestamp><sync-itemid>370</sync-itemid><sync-prioritymapping>0:0-0/1:700-1000/2:300-699/3:1-299</sync-prioritymapping>
- 411: Text3: <sync-guid>{4A958737-355F-436E-8A23-B39C4F51DE26}</sync-guid><sync-parentguid>{12B4BAA6-89B0-4039-B9E8-A5B7B5CE20E9}</sync-parentguid><sync-checksum>-1174834432</sync-checksum><sync-rootid>0</sync-rootid><sync-itemtype>0</sync-itemtype><sync-timestamp>12 / Text5: 30/2004 1:09:21 PM</sync-timestamp><sync-itemid>1093</sync-itemid><sync-prioritymapping>0:0-0/1:700-1000/2:300-699/3:1-299</sync-prioritymapping>
- 412: Text3: <sync-guid>{9C98F157-A879-4ED5-A5CF-0F8088AAE41E}</sync-guid><sync-parentguid>{12B4BAA6-89B0-4039-B9E8-A5B7B5CE20E9}</sync-parentguid><sync-checksum>-1751781424</sync-checksum><sync-rootid>0</sync-rootid><sync-itemtype>0</sync-itemtype><sync-timestamp>12 / Text5: 30/2004 1:09:22 PM</sync-timestamp><sync-itemid>1092</sync-itemid><sync-prioritymapping>0:0-0/1:700-1000/2:300-699/3:1-299</sync-prioritymapping>
- 413: Text3: <sync-guid>{2A23A213-2619-41F8-8F95-394CB6B21908}</sync-guid><sync-parentguid>{12B4BAA6-89B0-4039-B9E8-A5B7B5CE20E9}</sync-parentguid><sync-checksum>180244950</sync-checksum><sync-rootid>0</sync-rootid><sync-itemtype>0</sync-itemtype><sync-timestamp>12/30 / Text5: 2004 1:09:22 PM</sync-timestamp><sync-itemid>1091</sync-itemid><sync-prioritymapping>0:0-0/1:700-1000/2:300-699/3:1-299</sync-prioritymapping>
- 414: Text3: <sync-guid>{456A4AC1-7B9A-475C-B978-46FBD1CE43F1}</sync-guid><sync-parentguid>{12B4BAA6-89B0-4039-B9E8-A5B7B5CE20E9}</sync-parentguid><sync-checksum>1511129593</sync-checksum><sync-rootid>0</sync-rootid><sync-itemtype>0</sync-itemtype><sync-timestamp>12/3 / Text5: 0/2004 1:09:22 PM</sync-timestamp><sync-itemid>1090</sync-itemid><sync-prioritymapping>0:0-0/1:700-1000/2:300-699/3:1-299</sync-prioritymapping>
- 415: Text3: <sync-guid>{2EC09B5D-3DE9-482E-8BA2-D33888F6DB09}</sync-guid><sync-parentguid>{12B4BAA6-89B0-4039-B9E8-A5B7B5CE20E9}</sync-parentguid><sync-checksum>-1919966200</sync-checksum><sync-rootid>0</sync-rootid><sync-itemtype>0</sync-itemtype><sync-timestamp>12 / Text5: 30/2004 1:09:22 PM</sync-timestamp><sync-itemid>1089</sync-itemid><sync-prioritymapping>0:0-0/1:700-1000/2:300-699/3:1-299</sync-prioritymapping>
- 416: Text3: <sync-guid>{03522C42-F1C0-43E4-A4A9-38DC904A263E}</sync-guid><sync-parentguid>{2B2817F9-76F5-4CDD-8182-CF152760D6BB}</sync-parentguid><sync-checksum>-2003817402</sync-checksum><sync-rootid>0</sync-rootid><sync-itemtype>0</sync-itemtype><sync-timestamp>12 / Text5: 30/2004 1:12:36 PM</sync-timestamp><sync-itemid>291</sync-itemid><sync-prioritymapping>0:0-0/1:700-1000/2:300-699/3:1-299</sync-prioritymapping>
- 417: Text3: <sync-guid>{3E688726-486E-4660-B789-6727BF41A2C4}</sync-guid><sync-parentguid>{03522C42-F1C0-43E4-A4A9-38DC904A263E}</sync-parentguid><sync-checksum>-794430853</sync-checksum><sync-rootid>0</sync-rootid><sync-itemtype>0</sync-itemtype><sync-timestamp>12/3 / Text5: 0/2004 1:12:34 PM</sync-timestamp><sync-itemid>1197</sync-itemid><sync-prioritymapping>0:0-0/1:700-1000/2:300-699/3:1-299</sync-prioritymapping>

| ID | WBS | Task | Type | Duration | Start | Finish | Predecessors | Baseline start | Baseline finish | Baseline duration | Total slack | Free slack | Text4 |
| --- | --- | --- | --- | --- | --- | --- | --- | --- | --- | --- | --- | --- | --- |
| 418 | 6.3.2 | **Update subproject plan** |  | 4d | 2005-03-15 | 2005-03-21 |  | 2005-03-15 | 2005-03-21 | 4d | 52.5d |  | {3EEAF351-752E-4CF6-BDB3-4CBFA2E8D4C5} |
| 419 | 6.3.2.1 | Review project status and milestones |  | 1d | 2005-03-15 | 2005-03-16 |  | 2005-03-15 | 2005-03-16 | 1d | 52.5d | 0d | {BF8F11C4-4B6A-41CE-9137-0840BA872249} |
| 420 | 6.3.2.2 | Revise plan schedule & assignments |  | 1d | 2005-03-16 | 2005-03-17 | 419 | 2005-03-16 | 2005-03-17 | 1d | 52.5d | 0d | {5C82421F-E275-4774-859B-60543FAD00D4} |
| 421 | 6.3.2.3 | Review charter & plan with stakeholders |  | 1d | 2005-03-17 | 2005-03-18 | 420 | 2005-03-17 | 2005-03-18 | 1d | 52.5d | 0d | {EAE21200-DB2F-4C01-B1B3-BD3ED618AAD4} |
| 422 | 6.3.2.4 | Finalize plan revisions |  | 1d | 2005-03-18 | 2005-03-21 | 421 | 2005-03-18 | 2005-03-21 | 1d | 52.5d | 0d | {6FA6C09A-B338-41B2-8C5C-369009764DA6} |
| 423 | 6.3.2.5 | Approve revised subproject plan | milestone | 0d | 2005-03-21 | 2005-03-21 | 422 | 2005-03-21 | 2005-03-21 | 0d | 52.5d |  | {05EE4FC9-A0C3-476B-BFF9-53D498DDD094} |
| 424 | 6.3.3 | **Conduct phase QA assessment** |  | 2d | 2005-03-15 | 2005-03-17 |  | 2005-03-15 | 2005-03-17 | 2d | 54.5d |  | {E77E8EC1-3BC8-49E2-9228-C2701EA13B1C} |
| 425 | 6.3.3.1 | Consolidate phase results |  | 0.5d | 2005-03-15 | 2005-03-15 |  | 2005-03-15 | 2005-03-15 | 0.5d | 54.5d | 0d | {571BF8B7-D375-4F13-B16B-680FBB3DCB4B} |
| 426 | 6.3.3.2 | Conduct phase self-assessment |  | 0.25d | 2005-03-16 | 2005-03-16 | 425 | 2005-03-16 | 2005-03-16 | 0.25d | 54.5d | 0d | {544D0342-EBEF-443C-8B2B-805C9A7A63F3} |
| 427 | 6.3.3.3 | Conduct QA assessment |  | 0.5d | 2005-03-16 | 2005-03-16 | 426 | 2005-03-16 | 2005-03-16 | 0.5d | 54.5d | 0d | {0283A223-C995-4611-AB59-5AAEE69C3C9B} |
| 428 | 6.3.3.4 | Review assessment feedback |  | 0.25d | 2005-03-16 | 2005-03-16 | 427 | 2005-03-16 | 2005-03-16 | 0.25d | 54.5d | 0d | {0DF33A4E-7260-4193-9472-E282A2ADDCDA} |
| 429 | 6.3.3.5 | Implement QA feedback |  | 0.5d | 2005-03-17 | 2005-03-17 | 428 | 2005-03-17 | 2005-03-17 | 0.5d | 54.5d |  | {C91A7831-F558-4058-8F97-C1659A41F3E5} |
| 430 | 6.4 | **DESIGN & BUILD** |  | 38d | 2005-03-21 | 2005-05-12 | 416 | 2005-03-21 | 2005-05-12 | 38d | 39.5d | 0d | {CEC90403-F9AB-4406-8038-2DF145BE3AC4} |
| 431 | 6.4.1 | **Conduct architectural design** |  | 6d | 2005-03-21 | 2005-03-29 |  | 2005-03-21 | 2005-03-29 | 6d | 52.5d | 0d | {200F1A68-A0AF-4982-8F73-9A202E2750EE} |
| 432 | 6.4.1.1 | Define preliminary architecture |  | 1d | 2005-03-21 | 2005-03-22 |  | 2005-03-21 | 2005-03-22 | 1d | 52.5d | 0d | {106E0714-62E5-48BB-948D-6473007E735D} |
| 433 | 6.4.1.2 | Identify architectural failure modes |  | 1d | 2005-03-22 | 2005-03-23 | 432 | 2005-03-22 | 2005-03-23 | 1d | 52.5d | 0d | {BDED48D8-D1A2-4222-A3FF-1897B28109BC} |
| 434 | 6.4.1.3 | Define architectural controls |  | 1d | 2005-03-23 | 2005-03-24 | 433 | 2005-03-23 | 2005-03-24 | 1d | 52.5d | 0d | {35EC0B9B-B537-4483-8D3E-5445FD884D64} |
| 435 | 6.4.1.4 | Consolidate initial architecture description |  | 1d | 2005-03-24 | 2005-03-25 | 434 | 2005-03-24 | 2005-03-25 | 1d | 52.5d | 0d | {66DA7DAC-BBC9-494A-929B-69672D323491} |
| 436 | 6.4.1.5 | Circulate architecture for team review |  | 1d | 2005-03-25 | 2005-03-28 | 435 | 2005-03-25 | 2005-03-28 | 1d | 52.5d | 0d | {C349BED0-3C89-49C9-A861-F73F733DF755} |
| 437 | 6.4.1.6 | Revise architecture based on feedback |  | 1d | 2005-03-28 | 2005-03-29 | 436 | 2005-03-28 | 2005-03-29 | 1d | 52.5d |  | {CB3A1ABE-5B96-481D-B253-C81F831B0602} |
| 438 | 6.4.2 | **Conduct functional design** |  | 9d | 2005-03-21 | 2005-04-01 |  | 2005-03-21 | 2005-04-01 | 9d | 68.5d |  | {4259B0EB-9792-40C3-8F7C-DCB30D9B5FCD} |
| 439 | 6.4.2.1 | Define functional components |  | 1d | 2005-03-21 | 2005-03-22 |  | 2005-03-21 | 2005-03-22 | 1d | 68.5d | 0d | {0623C8E2-8376-4BA8-89AB-5DF2F2DB4BA2} |
| 440 | 6.4.2.2 | Design processing functions |  | 5d | 2005-03-22 | 2005-03-29 | 439 | 2005-03-22 | 2005-03-29 | 5d | 68.5d | 0d | {EFDC0A24-E26C-4EDF-AE51-6AF67EFB9E38} |
| 441 | 6.4.2.3 | Define human interfaces |  | 5d | 2005-03-22 | 2005-03-29 | 439 | 2005-03-22 | 2005-03-29 | 5d | 68.5d | 0d | {5EB61B78-74F3-40BA-B620-00A91EF07DDF} |
| 442 | 6.4.2.4 | Define system interfaces |  | 5d | 2005-03-22 | 2005-03-29 | 439 | 2005-03-22 | 2005-03-29 | 5d | 68.5d | 0d | {B23A6121-259A-4946-A88F-5EFB27A451C2} |
| 443 | 6.4.2.5 | Define data structures |  | 5d | 2005-03-22 | 2005-03-29 | 439 | 2005-03-22 | 2005-03-29 | 5d | 68.5d | 0d | {112AC802-7AF7-404D-B120-834819072DB2} |
| 444 | 6.4.2.6 | Define system controls |  | 2d | 2005-03-25 | 2005-03-29 | 440FF, 441FF, 442FF, 443FF | 2005-03-25 | 2005-03-29 | 2d | 68.5d | 0d | {477F4EC0-FA2E-4349-AE2C-C602FB2F329B} |
| 445 | 6.4.2.7 | Consolidate functional system design |  | 1d | 2005-03-29 | 2005-03-30 | 444 | 2005-03-29 | 2005-03-30 | 1d | 68.5d | 0d | {DABCD39F-664D-4889-AA01-F2D0D2B7DA89} |
| 446 | 6.4.2.8 | Conduct peer review of functional system |  | 1d | 2005-03-30 | 2005-03-31 | 445 | 2005-03-30 | 2005-03-31 | 1d | 68.5d | 0d | {F3C363F2-BD08-47DB-BB15-CB3A895FF565} |
| 447 | 6.4.2.9 | Revise functions based on feedback |  | 1d | 2005-03-31 | 2005-04-01 | 446 | 2005-03-31 | 2005-04-01 | 1d | 68.5d |  | {609CCE8F-530F-40F2-BDB9-F27600F76E1C} |

Notes:
- 418: Text3: <sync-guid>{3EEAF351-752E-4CF6-BDB3-4CBFA2E8D4C5}</sync-guid><sync-parentguid>{03522C42-F1C0-43E4-A4A9-38DC904A263E}</sync-parentguid><sync-checksum>1999741576</sync-checksum><sync-rootid>0</sync-rootid><sync-itemtype>0</sync-itemtype><sync-timestamp>12/3 / Text5: 0/2004 1:12:35 PM</sync-timestamp><sync-itemid>669</sync-itemid><sync-prioritymapping>0:0-0/1:700-1000/2:300-699/3:1-299</sync-prioritymapping>
- 419: Text3: <sync-guid>{BF8F11C4-4B6A-41CE-9137-0840BA872249}</sync-guid><sync-parentguid>{3EEAF351-752E-4CF6-BDB3-4CBFA2E8D4C5}</sync-parentguid><sync-checksum>676552359</sync-checksum><sync-rootid>0</sync-rootid><sync-itemtype>0</sync-itemtype><sync-timestamp>12/30 / Text5: 2004 1:12:34 PM</sync-timestamp><sync-itemid>668</sync-itemid><sync-prioritymapping>0:0-0/1:700-1000/2:300-699/3:1-299</sync-prioritymapping>
- 420: Text3: <sync-guid>{5C82421F-E275-4774-859B-60543FAD00D4}</sync-guid><sync-parentguid>{3EEAF351-752E-4CF6-BDB3-4CBFA2E8D4C5}</sync-parentguid><sync-checksum>1206291227</sync-checksum><sync-rootid>0</sync-rootid><sync-itemtype>0</sync-itemtype><sync-timestamp>12/3 / Text5: 0/2004 1:12:34 PM</sync-timestamp><sync-itemid>667</sync-itemid><sync-prioritymapping>0:0-0/1:700-1000/2:300-699/3:1-299</sync-prioritymapping>
- 421: Text3: <sync-guid>{EAE21200-DB2F-4C01-B1B3-BD3ED618AAD4}</sync-guid><sync-parentguid>{3EEAF351-752E-4CF6-BDB3-4CBFA2E8D4C5}</sync-parentguid><sync-checksum>417231912</sync-checksum><sync-rootid>0</sync-rootid><sync-itemtype>0</sync-itemtype><sync-timestamp>12/30 / Text5: 2004 1:12:34 PM</sync-timestamp><sync-itemid>666</sync-itemid><sync-prioritymapping>0:0-0/1:700-1000/2:300-699/3:1-299</sync-prioritymapping>
- 422: Text3: <sync-guid>{6FA6C09A-B338-41B2-8C5C-369009764DA6}</sync-guid><sync-parentguid>{3EEAF351-752E-4CF6-BDB3-4CBFA2E8D4C5}</sync-parentguid><sync-checksum>260115489</sync-checksum><sync-rootid>0</sync-rootid><sync-itemtype>0</sync-itemtype><sync-timestamp>12/30 / Text5: 2004 1:12:35 PM</sync-timestamp><sync-itemid>665</sync-itemid><sync-prioritymapping>0:0-0/1:700-1000/2:300-699/3:1-299</sync-prioritymapping>
- 423: Text3: <sync-guid>{05EE4FC9-A0C3-476B-BFF9-53D498DDD094}</sync-guid><sync-parentguid>{3EEAF351-752E-4CF6-BDB3-4CBFA2E8D4C5}</sync-parentguid><sync-checksum>144438174</sync-checksum><sync-rootid>0</sync-rootid><sync-itemtype>0</sync-itemtype><sync-timestamp>12/30 / Text5: 2004 1:12:35 PM</sync-timestamp><sync-itemid>664</sync-itemid><sync-prioritymapping>0:0-0/1:700-1000/2:300-699/3:1-299</sync-prioritymapping>
- 424: Text3: <sync-guid>{E77E8EC1-3BC8-49E2-9228-C2701EA13B1C}</sync-guid><sync-parentguid>{03522C42-F1C0-43E4-A4A9-38DC904A263E}</sync-parentguid><sync-checksum>1549430250</sync-checksum><sync-rootid>0</sync-rootid><sync-itemtype>0</sync-itemtype><sync-timestamp>12/3 / Text5: 0/2004 1:12:36 PM</sync-timestamp><sync-itemid>371</sync-itemid><sync-prioritymapping>0:0-0/1:700-1000/2:300-699/3:1-299</sync-prioritymapping>
- 425: Text3: <sync-guid>{571BF8B7-D375-4F13-B16B-680FBB3DCB4B}</sync-guid><sync-parentguid>{E77E8EC1-3BC8-49E2-9228-C2701EA13B1C}</sync-parentguid><sync-checksum>-2114983420</sync-checksum><sync-rootid>0</sync-rootid><sync-itemtype>0</sync-itemtype><sync-timestamp>12 / Text5: 30/2004 1:12:35 PM</sync-timestamp><sync-itemid>1098</sync-itemid><sync-prioritymapping>0:0-0/1:700-1000/2:300-699/3:1-299</sync-prioritymapping>
- 426: Text3: <sync-guid>{544D0342-EBEF-443C-8B2B-805C9A7A63F3}</sync-guid><sync-parentguid>{E77E8EC1-3BC8-49E2-9228-C2701EA13B1C}</sync-parentguid><sync-checksum>-1988714809</sync-checksum><sync-rootid>0</sync-rootid><sync-itemtype>0</sync-itemtype><sync-timestamp>12 / Text5: 30/2004 1:12:35 PM</sync-timestamp><sync-itemid>1097</sync-itemid><sync-prioritymapping>0:0-0/1:700-1000/2:300-699/3:1-299</sync-prioritymapping>
- 427: Text3: <sync-guid>{0283A223-C995-4611-AB59-5AAEE69C3C9B}</sync-guid><sync-parentguid>{E77E8EC1-3BC8-49E2-9228-C2701EA13B1C}</sync-parentguid><sync-checksum>341647553</sync-checksum><sync-rootid>0</sync-rootid><sync-itemtype>0</sync-itemtype><sync-timestamp>12/30 / Text5: 2004 1:12:35 PM</sync-timestamp><sync-itemid>1096</sync-itemid><sync-prioritymapping>0:0-0/1:700-1000/2:300-699/3:1-299</sync-prioritymapping>
- 428: Text3: <sync-guid>{0DF33A4E-7260-4193-9472-E282A2ADDCDA}</sync-guid><sync-parentguid>{E77E8EC1-3BC8-49E2-9228-C2701EA13B1C}</sync-parentguid><sync-checksum>1156673774</sync-checksum><sync-rootid>0</sync-rootid><sync-itemtype>0</sync-itemtype><sync-timestamp>12/3 / Text5: 0/2004 1:12:35 PM</sync-timestamp><sync-itemid>1095</sync-itemid><sync-prioritymapping>0:0-0/1:700-1000/2:300-699/3:1-299</sync-prioritymapping>
- 429: Text3: <sync-guid>{C91A7831-F558-4058-8F97-C1659A41F3E5}</sync-guid><sync-parentguid>{E77E8EC1-3BC8-49E2-9228-C2701EA13B1C}</sync-parentguid><sync-checksum>1162913141</sync-checksum><sync-rootid>0</sync-rootid><sync-itemtype>0</sync-itemtype><sync-timestamp>12/3 / Text5: 0/2004 1:12:36 PM</sync-timestamp><sync-itemid>1094</sync-itemid><sync-prioritymapping>0:0-0/1:700-1000/2:300-699/3:1-299</sync-prioritymapping>
- 430: Text3: <sync-guid>{CEC90403-F9AB-4406-8038-2DF145BE3AC4}</sync-guid><sync-parentguid>{2B2817F9-76F5-4CDD-8182-CF152760D6BB}</sync-parentguid><sync-checksum>-92491205</sync-checksum><sync-rootid>0</sync-rootid><sync-itemtype>0</sync-itemtype><sync-timestamp>12/30 / Text5: 2004 1:12:53 PM</sync-timestamp><sync-itemid>294</sync-itemid><sync-prioritymapping>0:0-0/1:700-1000/2:300-699/3:1-299</sync-prioritymapping>
- 431: Text3: <sync-guid>{200F1A68-A0AF-4982-8F73-9A202E2750EE}</sync-guid><sync-parentguid>{CEC90403-F9AB-4406-8038-2DF145BE3AC4}</sync-parentguid><sync-checksum>1547515823</sync-checksum><sync-rootid>0</sync-rootid><sync-itemtype>0</sync-itemtype><sync-timestamp>12/3 / Text5: 0/2004 1:12:37 PM</sync-timestamp><sync-itemid>568</sync-itemid><sync-prioritymapping>0:0-0/1:700-1000/2:300-699/3:1-299</sync-prioritymapping>
- 432: Text3: <sync-guid>{106E0714-62E5-48BB-948D-6473007E735D}</sync-guid><sync-parentguid>{200F1A68-A0AF-4982-8F73-9A202E2750EE}</sync-parentguid><sync-checksum>1663825829</sync-checksum><sync-rootid>0</sync-rootid><sync-itemtype>0</sync-itemtype><sync-timestamp>12/3 / Text5: 0/2004 1:12:36 PM</sync-timestamp><sync-itemid>574</sync-itemid><sync-prioritymapping>0:0-0/1:700-1000/2:300-699/3:1-299</sync-prioritymapping>
- 433: Text3: <sync-guid>{BDED48D8-D1A2-4222-A3FF-1897B28109BC}</sync-guid><sync-parentguid>{200F1A68-A0AF-4982-8F73-9A202E2750EE}</sync-parentguid><sync-checksum>285760421</sync-checksum><sync-rootid>0</sync-rootid><sync-itemtype>0</sync-itemtype><sync-timestamp>12/30 / Text5: 2004 1:12:36 PM</sync-timestamp><sync-itemid>573</sync-itemid><sync-prioritymapping>0:0-0/1:700-1000/2:300-699/3:1-299</sync-prioritymapping>
- 434: Text3: <sync-guid>{35EC0B9B-B537-4483-8D3E-5445FD884D64}</sync-guid><sync-parentguid>{200F1A68-A0AF-4982-8F73-9A202E2750EE}</sync-parentguid><sync-checksum>-1441805551</sync-checksum><sync-rootid>0</sync-rootid><sync-itemtype>0</sync-itemtype><sync-timestamp>12 / Text5: 30/2004 1:12:36 PM</sync-timestamp><sync-itemid>572</sync-itemid><sync-prioritymapping>0:0-0/1:700-1000/2:300-699/3:1-299</sync-prioritymapping>
- 435: Text3: <sync-guid>{66DA7DAC-BBC9-494A-929B-69672D323491}</sync-guid><sync-parentguid>{200F1A68-A0AF-4982-8F73-9A202E2750EE}</sync-parentguid><sync-checksum>1665080449</sync-checksum><sync-rootid>0</sync-rootid><sync-itemtype>0</sync-itemtype><sync-timestamp>12/3 / Text5: 0/2004 1:12:36 PM</sync-timestamp><sync-itemid>571</sync-itemid><sync-prioritymapping>0:0-0/1:700-1000/2:300-699/3:1-299</sync-prioritymapping>
- 436: Text3: <sync-guid>{C349BED0-3C89-49C9-A861-F73F733DF755}</sync-guid><sync-parentguid>{200F1A68-A0AF-4982-8F73-9A202E2750EE}</sync-parentguid><sync-checksum>-1708767538</sync-checksum><sync-rootid>0</sync-rootid><sync-itemtype>0</sync-itemtype><sync-timestamp>12 / Text5: 30/2004 1:12:37 PM</sync-timestamp><sync-itemid>570</sync-itemid><sync-prioritymapping>0:0-0/1:700-1000/2:300-699/3:1-299</sync-prioritymapping>
- 437: Text3: <sync-guid>{CB3A1ABE-5B96-481D-B253-C81F831B0602}</sync-guid><sync-parentguid>{200F1A68-A0AF-4982-8F73-9A202E2750EE}</sync-parentguid><sync-checksum>1456410775</sync-checksum><sync-rootid>0</sync-rootid><sync-itemtype>0</sync-itemtype><sync-timestamp>12/3 / Text5: 0/2004 1:12:37 PM</sync-timestamp><sync-itemid>569</sync-itemid><sync-prioritymapping>0:0-0/1:700-1000/2:300-699/3:1-299</sync-prioritymapping>
- 438: Text3: <sync-guid>{4259B0EB-9792-40C3-8F7C-DCB30D9B5FCD}</sync-guid><sync-parentguid>{CEC90403-F9AB-4406-8038-2DF145BE3AC4}</sync-parentguid><sync-checksum>-1208731860</sync-checksum><sync-rootid>0</sync-rootid><sync-itemtype>0</sync-itemtype><sync-timestamp>12 / Text5: 30/2004 1:12:38 PM</sync-timestamp><sync-itemid>301</sync-itemid><sync-prioritymapping>0:0-0/1:700-1000/2:300-699/3:1-299</sync-prioritymapping>
- 439: Text3: <sync-guid>{0623C8E2-8376-4BA8-89AB-5DF2F2DB4BA2}</sync-guid><sync-parentguid>{4259B0EB-9792-40C3-8F7C-DCB30D9B5FCD}</sync-parentguid><sync-checksum>51240603</sync-checksum><sync-rootid>0</sync-rootid><sync-itemtype>0</sync-itemtype><sync-timestamp>12/30 / Text5: 2004 1:12:37 PM</sync-timestamp><sync-itemid>578</sync-itemid><sync-prioritymapping>0:0-0/1:700-1000/2:300-699/3:1-299</sync-prioritymapping>
- 440: Text3: <sync-guid>{EFDC0A24-E26C-4EDF-AE51-6AF67EFB9E38}</sync-guid><sync-parentguid>{4259B0EB-9792-40C3-8F7C-DCB30D9B5FCD}</sync-parentguid><sync-checksum>-1378197240</sync-checksum><sync-rootid>0</sync-rootid><sync-itemtype>0</sync-itemtype><sync-timestamp>12 / Text5: 30/2004 1:12:37 PM</sync-timestamp><sync-itemid>577</sync-itemid><sync-prioritymapping>0:0-0/1:700-1000/2:300-699/3:1-299</sync-prioritymapping>
- 441: Text3: <sync-guid>{5EB61B78-74F3-40BA-B620-00A91EF07DDF}</sync-guid><sync-parentguid>{4259B0EB-9792-40C3-8F7C-DCB30D9B5FCD}</sync-parentguid><sync-checksum>205444976</sync-checksum><sync-rootid>0</sync-rootid><sync-itemtype>0</sync-itemtype><sync-timestamp>12/30 / Text5: 2004 1:12:37 PM</sync-timestamp><sync-itemid>576</sync-itemid><sync-prioritymapping>0:0-0/1:700-1000/2:300-699/3:1-299</sync-prioritymapping>
- 442: Text3: <sync-guid>{B23A6121-259A-4946-A88F-5EFB27A451C2}</sync-guid><sync-parentguid>{4259B0EB-9792-40C3-8F7C-DCB30D9B5FCD}</sync-parentguid><sync-checksum>1984185421</sync-checksum><sync-rootid>0</sync-rootid><sync-itemtype>0</sync-itemtype><sync-timestamp>12/3 / Text5: 0/2004 1:12:37 PM</sync-timestamp><sync-itemid>581</sync-itemid><sync-prioritymapping>0:0-0/1:700-1000/2:300-699/3:1-299</sync-prioritymapping>
- 443: Text3: <sync-guid>{112AC802-7AF7-404D-B120-834819072DB2}</sync-guid><sync-parentguid>{4259B0EB-9792-40C3-8F7C-DCB30D9B5FCD}</sync-parentguid><sync-checksum>-259970240</sync-checksum><sync-rootid>0</sync-rootid><sync-itemtype>0</sync-itemtype><sync-timestamp>12/3 / Text5: 0/2004 1:12:38 PM</sync-timestamp><sync-itemid>580</sync-itemid><sync-prioritymapping>0:0-0/1:700-1000/2:300-699/3:1-299</sync-prioritymapping>
- 444: Text3: <sync-guid>{477F4EC0-FA2E-4349-AE2C-C602FB2F329B}</sync-guid><sync-parentguid>{4259B0EB-9792-40C3-8F7C-DCB30D9B5FCD}</sync-parentguid><sync-checksum>1581059816</sync-checksum><sync-rootid>0</sync-rootid><sync-itemtype>0</sync-itemtype><sync-timestamp>12/3 / Text5: 0/2004 1:12:38 PM</sync-timestamp><sync-itemid>579</sync-itemid><sync-prioritymapping>0:0-0/1:700-1000/2:300-699/3:1-299</sync-prioritymapping>
- 445: Text3: <sync-guid>{DABCD39F-664D-4889-AA01-F2D0D2B7DA89}</sync-guid><sync-parentguid>{4259B0EB-9792-40C3-8F7C-DCB30D9B5FCD}</sync-parentguid><sync-checksum>-197608131</sync-checksum><sync-rootid>0</sync-rootid><sync-itemtype>0</sync-itemtype><sync-timestamp>12/3 / Text5: 0/2004 1:12:38 PM</sync-timestamp><sync-itemid>575</sync-itemid><sync-prioritymapping>0:0-0/1:700-1000/2:300-699/3:1-299</sync-prioritymapping>
- 446: Text3: <sync-guid>{F3C363F2-BD08-47DB-BB15-CB3A895FF565}</sync-guid><sync-parentguid>{4259B0EB-9792-40C3-8F7C-DCB30D9B5FCD}</sync-parentguid><sync-checksum>-1935454251</sync-checksum><sync-rootid>0</sync-rootid><sync-itemtype>0</sync-itemtype><sync-timestamp>12 / Text5: 30/2004 1:12:38 PM</sync-timestamp><sync-itemid>583</sync-itemid><sync-prioritymapping>0:0-0/1:700-1000/2:300-699/3:1-299</sync-prioritymapping>
- 447: Text3: <sync-guid>{609CCE8F-530F-40F2-BDB9-F27600F76E1C}</sync-guid><sync-parentguid>{4259B0EB-9792-40C3-8F7C-DCB30D9B5FCD}</sync-parentguid><sync-checksum>-1592691121</sync-checksum><sync-rootid>0</sync-rootid><sync-itemtype>0</sync-itemtype><sync-timestamp>12 / Text5: 30/2004 1:12:38 PM</sync-timestamp><sync-itemid>586</sync-itemid><sync-prioritymapping>0:0-0/1:700-1000/2:300-699/3:1-299</sync-prioritymapping>

| ID | WBS | Task | Duration | Start | Finish | Predecessors | Baseline start | Baseline finish | Baseline duration | Total slack | Free slack | Text4 |
| --- | --- | --- | --- | --- | --- | --- | --- | --- | --- | --- | --- | --- |
| 448 | 6.4.3 | **Conduct technical design** | 7d | 2005-03-29 | 2005-04-07 | 431 | 2005-03-29 | 2005-04-07 | 7d | 52.5d | 0d | {90F2BF98-793F-42C7-B83F-108557127F4B} |
| 449 | 6.4.3.1 | Map functions to architecture | 1d | 2005-03-29 | 2005-03-30 |  | 2005-03-29 | 2005-03-30 | 1d | 52.5d | 0d | {FD4AC17F-A6DD-407A-9947-389B1D4FFFFC} |
| 450 | 6.4.3.2 | Define initial system design | 1d | 2005-03-30 | 2005-03-31 | 449 | 2005-03-30 | 2005-03-31 | 1d | 52.5d | 0d | {C73546F5-D649-4691-A7C4-00FB60EF3821} |
| 451 | 6.4.3.3 | Design system components | 1d | 2005-03-31 | 2005-04-01 | 450 | 2005-03-31 | 2005-04-01 | 1d | 52.5d | 0d | {2012108C-C561-4745-8D0E-E17C5B65185D} |
| 452 | 6.4.3.4 | Design processing components | 1d | 2005-04-01 | 2005-04-04 | 451 | 2005-04-01 | 2005-04-04 | 1d | 52.5d | 0d | {C69BEC6B-2BA1-4C87-848B-DFE78BF6F88C} |
| 453 | 6.4.3.5 | Design human interfaces | 1d | 2005-04-01 | 2005-04-04 | 451 | 2005-04-01 | 2005-04-04 | 1d | 52.5d | 0d | {460062B2-B097-42BE-990D-8D86EE8B7F93} |
| 454 | 6.4.3.6 | Design system interfaces | 1d | 2005-04-01 | 2005-04-04 | 451 | 2005-04-01 | 2005-04-04 | 1d | 52.5d | 0d | {CD123B85-0969-420B-9CCE-2F3A5419648E} |
| 455 | 6.4.3.7 | Design data structures | 1d | 2005-04-01 | 2005-04-04 | 451 | 2005-04-01 | 2005-04-04 | 1d | 52.5d | 0d | {8378E5FF-A307-4622-82D1-EC338752354A} |
| 456 | 6.4.3.8 | Design system controls | 1d | 2005-04-01 | 2005-04-04 | 452FF, 453FF, 454FF, 455FF | 2005-04-01 | 2005-04-04 | 1d | 52.5d | 0d | {17574CD3-0351-4661-A08B-FFA27254DF6D} |
| 457 | 6.4.3.9 | Consolidate technical system design | 1d | 2005-04-04 | 2005-04-05 | 456 | 2005-04-04 | 2005-04-05 | 1d | 52.5d | 0d | {66E6FD34-64B9-4EBD-8A93-4853F5FA2E3A} |
| 458 | 6.4.3.10 | Conduct peer review of technical system | 1d | 2005-04-05 | 2005-04-06 | 457 | 2005-04-05 | 2005-04-06 | 1d | 52.5d | 0d | {C334951C-7BC4-4F04-9B76-3E5FF60DFFCC} |
| 459 | 6.4.3.11 | Revise technical design based on feedback | 1d | 2005-04-06 | 2005-04-07 | 458 | 2005-04-06 | 2005-04-07 | 1d | 52.5d |  | {B61690D7-B8AC-4FA9-A76C-AB3F5F73ACB2} |
| 460 | 6.4.4 | **Define system test plan** | 8d | 2005-04-04 | 2005-04-14 | 456 | 2005-04-04 | 2005-04-14 | 8d | 56.5d |  | {8C12B441-69FE-437B-B6B6-2051B11F4240} |
| 461 | 6.4.4.1 | Define testing objectives | 1d | 2005-04-04 | 2005-04-05 |  | 2005-04-04 | 2005-04-05 | 1d | 56.5d | 0d | {59B211E5-EEF4-473A-934A-BE9D2DE476DC} |
| 462 | 6.4.4.2 | Develop system-level scenarios | 1d | 2005-04-05 | 2005-04-06 | 461 | 2005-04-05 | 2005-04-06 | 1d | 56.5d | 0d | {D5173C4C-43BE-445E-AE10-A5D6B3E29505} |
| 463 | 6.4.4.3 | Define test cases & outcomes | 1d | 2005-04-06 | 2005-04-07 | 462 | 2005-04-06 | 2005-04-07 | 1d | 56.5d | 0d | {B3C09B6B-1F37-45EA-A999-D3418915E9B6} |
| 464 | 6.4.4.4 | Develop test conditions and data | 1d | 2005-04-07 | 2005-04-08 | 463 | 2005-04-07 | 2005-04-08 | 1d | 56.5d | 0d | {19A97172-F1C0-4DAA-A054-A7FEC4FAB14C} |
| 465 | 6.4.4.5 | Define integration test plans | 1d | 2005-04-08 | 2005-04-11 | 464 | 2005-04-08 | 2005-04-11 | 1d | 56.5d | 0d | {B0445C96-88E0-4E3D-92A0-E1BD7051F4F4} |
| 466 | 6.4.4.6 | Consolidate system test plan | 1d | 2005-04-11 | 2005-04-12 | 465 | 2005-04-11 | 2005-04-12 | 1d | 59.5d | 0d | {47DCFC33-E996-45F7-A3A3-15DC104DE5E0} |
| 467 | 6.4.4.7 | Conduct peer review of system test plan | 1d | 2005-04-12 | 2005-04-13 | 466 | 2005-04-12 | 2005-04-13 | 1d | 59.5d | 0d | {3F2D1878-7161-4864-BC1D-7682F0EBC11A} |
| 468 | 6.4.4.8 | Revise test plan based on feedback | 1d | 2005-04-13 | 2005-04-14 | 467 | 2005-04-13 | 2005-04-14 | 1d | 59.5d |  | {F6E7368B-80D2-4FC3-BF64-94577326EFDB} |
| 469 | 6.4.5 | **Build system components** | 12d | 2005-04-07 | 2005-04-25 | 448 | 2005-04-07 | 2005-04-25 | 12d | 52.5d |  | {12D0C578-0A27-4CD4-B7A4-4E1AF672B60D} |
| 470 | 6.4.5.1 | Finalize detail designs | 1d | 2005-04-07 | 2005-04-08 |  | 2005-04-07 | 2005-04-08 | 1d | 52.5d | 0d | {F27EBDD7-18A0-4037-8A99-D10FD9082187} |
| 471 | 6.4.5.2 | Finalize integration test plans | 1d | 2005-04-08 | 2005-04-11 | 465FF | 2005-04-08 | 2005-04-11 | 1d | 56.5d | 0d | {CD8232B8-1E6F-488F-99BE-4E08EABC66BC} |
| 472 | 6.4.5.3 | Develop unit test plans | 1d | 2005-04-08 | 2005-04-11 | 470 | 2005-04-08 | 2005-04-11 | 1d | 52.5d | 0d | {3310AC76-6174-41F9-939D-5A78FD7DC8E1} |
| 473 | 6.4.5.4 | Build components | 5d | 2005-04-11 | 2005-04-18 | 472 | 2005-04-11 | 2005-04-18 | 5d | 57.5d |  | {604B970A-2D44-4EAF-BDA5-5887B51E6A95} |
| 474 | 6.4.5.5 | Conduct peer reviews of unit components | 5d | 2005-04-11 | 2005-04-18 | 472 | 2005-04-11 | 2005-04-18 | 5d | 57.5d |  | {040171D2-F8F8-4B25-8C62-7AF9F6839B11} |
| 475 | 6.4.5.6 | Unit test components | 5d | 2005-04-11 | 2005-04-18 | 472 | 2005-04-11 | 2005-04-18 | 5d | 52.5d | 0d | {40611373-6AD9-4511-8985-CB1443AD3D26} |
| 476 | 6.4.5.7 | Conduct integration testing | 5d | 2005-04-18 | 2005-04-25 | 475 | 2005-04-18 | 2005-04-25 | 5d | 52.5d |  | {CF7FEF10-B21F-4BE9-AC5D-9C42591D1C50} |

Notes:
- 448: Text3: <sync-guid>{90F2BF98-793F-42C7-B83F-108557127F4B}</sync-guid><sync-parentguid>{CEC90403-F9AB-4406-8038-2DF145BE3AC4}</sync-parentguid><sync-checksum>1874782923</sync-checksum><sync-rootid>0</sync-rootid><sync-itemtype>0</sync-itemtype><sync-timestamp>12/3 / Text5: 0/2004 1:12:40 PM</sync-timestamp><sync-itemid>302</sync-itemid><sync-prioritymapping>0:0-0/1:700-1000/2:300-699/3:1-299</sync-prioritymapping>
- 449: Text3: <sync-guid>{FD4AC17F-A6DD-407A-9947-389B1D4FFFFC}</sync-guid><sync-parentguid>{90F2BF98-793F-42C7-B83F-108557127F4B}</sync-parentguid><sync-checksum>60898848</sync-checksum><sync-rootid>0</sync-rootid><sync-itemtype>0</sync-itemtype><sync-timestamp>12/30 / Text5: 2004 1:12:39 PM</sync-timestamp><sync-itemid>595</sync-itemid><sync-prioritymapping>0:0-0/1:700-1000/2:300-699/3:1-299</sync-prioritymapping>
- 450: Text3: <sync-guid>{C73546F5-D649-4691-A7C4-00FB60EF3821}</sync-guid><sync-parentguid>{90F2BF98-793F-42C7-B83F-108557127F4B}</sync-parentguid><sync-checksum>-1687867395</sync-checksum><sync-rootid>0</sync-rootid><sync-itemtype>0</sync-itemtype><sync-timestamp>12 / Text5: 30/2004 1:12:39 PM</sync-timestamp><sync-itemid>594</sync-itemid><sync-prioritymapping>0:0-0/1:700-1000/2:300-699/3:1-299</sync-prioritymapping>
- 451: Text3: <sync-guid>{2012108C-C561-4745-8D0E-E17C5B65185D}</sync-guid><sync-parentguid>{90F2BF98-793F-42C7-B83F-108557127F4B}</sync-parentguid><sync-checksum>732037272</sync-checksum><sync-rootid>0</sync-rootid><sync-itemtype>0</sync-itemtype><sync-timestamp>12/30 / Text5: 2004 1:12:39 PM</sync-timestamp><sync-itemid>593</sync-itemid><sync-prioritymapping>0:0-0/1:700-1000/2:300-699/3:1-299</sync-prioritymapping>
- 452: Text3: <sync-guid>{C69BEC6B-2BA1-4C87-848B-DFE78BF6F88C}</sync-guid><sync-parentguid>{90F2BF98-793F-42C7-B83F-108557127F4B}</sync-parentguid><sync-checksum>-292778416</sync-checksum><sync-rootid>0</sync-rootid><sync-itemtype>0</sync-itemtype><sync-timestamp>12/3 / Text5: 0/2004 1:12:39 PM</sync-timestamp><sync-itemid>597</sync-itemid><sync-prioritymapping>0:0-0/1:700-1000/2:300-699/3:1-299</sync-prioritymapping>
- 453: Text3: <sync-guid>{460062B2-B097-42BE-990D-8D86EE8B7F93}</sync-guid><sync-parentguid>{90F2BF98-793F-42C7-B83F-108557127F4B}</sync-parentguid><sync-checksum>1583306455</sync-checksum><sync-rootid>0</sync-rootid><sync-itemtype>0</sync-itemtype><sync-timestamp>12/3 / Text5: 0/2004 1:12:39 PM</sync-timestamp><sync-itemid>596</sync-itemid><sync-prioritymapping>0:0-0/1:700-1000/2:300-699/3:1-299</sync-prioritymapping>
- 454: Text3: <sync-guid>{CD123B85-0969-420B-9CCE-2F3A5419648E}</sync-guid><sync-parentguid>{90F2BF98-793F-42C7-B83F-108557127F4B}</sync-parentguid><sync-checksum>-1257307179</sync-checksum><sync-rootid>0</sync-rootid><sync-itemtype>0</sync-itemtype><sync-timestamp>12 / Text5: 30/2004 1:12:39 PM</sync-timestamp><sync-itemid>600</sync-itemid><sync-prioritymapping>0:0-0/1:700-1000/2:300-699/3:1-299</sync-prioritymapping>
- 455: Text3: <sync-guid>{8378E5FF-A307-4622-82D1-EC338752354A}</sync-guid><sync-parentguid>{90F2BF98-793F-42C7-B83F-108557127F4B}</sync-parentguid><sync-checksum>363329235</sync-checksum><sync-rootid>0</sync-rootid><sync-itemtype>0</sync-itemtype><sync-timestamp>12/30 / Text5: 2004 1:12:40 PM</sync-timestamp><sync-itemid>599</sync-itemid><sync-prioritymapping>0:0-0/1:700-1000/2:300-699/3:1-299</sync-prioritymapping>
- 456: Text3: <sync-guid>{17574CD3-0351-4661-A08B-FFA27254DF6D}</sync-guid><sync-parentguid>{90F2BF98-793F-42C7-B83F-108557127F4B}</sync-parentguid><sync-checksum>417051290</sync-checksum><sync-rootid>0</sync-rootid><sync-itemtype>0</sync-itemtype><sync-timestamp>12/30 / Text5: 2004 1:12:40 PM</sync-timestamp><sync-itemid>592</sync-itemid><sync-prioritymapping>0:0-0/1:700-1000/2:300-699/3:1-299</sync-prioritymapping>
- 457: Text3: <sync-guid>{66E6FD34-64B9-4EBD-8A93-4853F5FA2E3A}</sync-guid><sync-parentguid>{90F2BF98-793F-42C7-B83F-108557127F4B}</sync-parentguid><sync-checksum>1884280823</sync-checksum><sync-rootid>0</sync-rootid><sync-itemtype>0</sync-itemtype><sync-timestamp>12/3 / Text5: 0/2004 1:12:40 PM</sync-timestamp><sync-itemid>591</sync-itemid><sync-prioritymapping>0:0-0/1:700-1000/2:300-699/3:1-299</sync-prioritymapping>
- 458: Text3: <sync-guid>{C334951C-7BC4-4F04-9B76-3E5FF60DFFCC}</sync-guid><sync-parentguid>{90F2BF98-793F-42C7-B83F-108557127F4B}</sync-parentguid><sync-checksum>-1096807730</sync-checksum><sync-rootid>0</sync-rootid><sync-itemtype>0</sync-itemtype><sync-timestamp>12 / Text5: 30/2004 1:12:40 PM</sync-timestamp><sync-itemid>590</sync-itemid><sync-prioritymapping>0:0-0/1:700-1000/2:300-699/3:1-299</sync-prioritymapping>
- 459: Text3: <sync-guid>{B61690D7-B8AC-4FA9-A76C-AB3F5F73ACB2}</sync-guid><sync-parentguid>{90F2BF98-793F-42C7-B83F-108557127F4B}</sync-parentguid><sync-checksum>203232152</sync-checksum><sync-rootid>0</sync-rootid><sync-itemtype>0</sync-itemtype><sync-timestamp>12/30 / Text5: 2004 1:12:40 PM</sync-timestamp><sync-itemid>589</sync-itemid><sync-prioritymapping>0:0-0/1:700-1000/2:300-699/3:1-299</sync-prioritymapping>
- 460: Text3: <sync-guid>{8C12B441-69FE-437B-B6B6-2051B11F4240}</sync-guid><sync-parentguid>{CEC90403-F9AB-4406-8038-2DF145BE3AC4}</sync-parentguid><sync-checksum>-1652360267</sync-checksum><sync-rootid>0</sync-rootid><sync-itemtype>0</sync-itemtype><sync-timestamp>12 / Text5: 30/2004 1:12:42 PM</sync-timestamp><sync-itemid>612</sync-itemid><sync-prioritymapping>0:0-0/1:700-1000/2:300-699/3:1-299</sync-prioritymapping>
- 461: Text3: <sync-guid>{59B211E5-EEF4-473A-934A-BE9D2DE476DC}</sync-guid><sync-parentguid>{8C12B441-69FE-437B-B6B6-2051B11F4240}</sync-parentguid><sync-checksum>-658676705</sync-checksum><sync-rootid>0</sync-rootid><sync-itemtype>0</sync-itemtype><sync-timestamp>12/3 / Text5: 0/2004 1:12:41 PM</sync-timestamp><sync-itemid>623</sync-itemid><sync-prioritymapping>0:0-0/1:700-1000/2:300-699/3:1-299</sync-prioritymapping>
- 462: Text3: <sync-guid>{D5173C4C-43BE-445E-AE10-A5D6B3E29505}</sync-guid><sync-parentguid>{8C12B441-69FE-437B-B6B6-2051B11F4240}</sync-parentguid><sync-checksum>886289062</sync-checksum><sync-rootid>0</sync-rootid><sync-itemtype>0</sync-itemtype><sync-timestamp>12/30 / Text5: 2004 1:12:41 PM</sync-timestamp><sync-itemid>621</sync-itemid><sync-prioritymapping>0:0-0/1:700-1000/2:300-699/3:1-299</sync-prioritymapping>
- 463: Text3: <sync-guid>{B3C09B6B-1F37-45EA-A999-D3418915E9B6}</sync-guid><sync-parentguid>{8C12B441-69FE-437B-B6B6-2051B11F4240}</sync-parentguid><sync-checksum>-184019152</sync-checksum><sync-rootid>0</sync-rootid><sync-itemtype>0</sync-itemtype><sync-timestamp>12/3 / Text5: 0/2004 1:12:41 PM</sync-timestamp><sync-itemid>625</sync-itemid><sync-prioritymapping>0:0-0/1:700-1000/2:300-699/3:1-299</sync-prioritymapping>
- 464: Text3: <sync-guid>{19A97172-F1C0-4DAA-A054-A7FEC4FAB14C}</sync-guid><sync-parentguid>{8C12B441-69FE-437B-B6B6-2051B11F4240}</sync-parentguid><sync-checksum>1142098155</sync-checksum><sync-rootid>0</sync-rootid><sync-itemtype>0</sync-itemtype><sync-timestamp>12/3 / Text5: 0/2004 1:12:41 PM</sync-timestamp><sync-itemid>624</sync-itemid><sync-prioritymapping>0:0-0/1:700-1000/2:300-699/3:1-299</sync-prioritymapping>
- 465: Text3: <sync-guid>{B0445C96-88E0-4E3D-92A0-E1BD7051F4F4}</sync-guid><sync-parentguid>{8C12B441-69FE-437B-B6B6-2051B11F4240}</sync-parentguid><sync-checksum>2022937699</sync-checksum><sync-rootid>0</sync-rootid><sync-itemtype>0</sync-itemtype><sync-timestamp>12/3 / Text5: 0/2004 1:12:41 PM</sync-timestamp><sync-itemid>620</sync-itemid><sync-prioritymapping>0:0-0/1:700-1000/2:300-699/3:1-299</sync-prioritymapping>
- 466: Text3: <sync-guid>{47DCFC33-E996-45F7-A3A3-15DC104DE5E0}</sync-guid><sync-parentguid>{8C12B441-69FE-437B-B6B6-2051B11F4240}</sync-parentguid><sync-checksum>466165480</sync-checksum><sync-rootid>0</sync-rootid><sync-itemtype>0</sync-itemtype><sync-timestamp>12/30 / Text5: 2004 1:12:41 PM</sync-timestamp><sync-itemid>628</sync-itemid><sync-prioritymapping>0:0-0/1:700-1000/2:300-699/3:1-299</sync-prioritymapping>
- 467: Text3: <sync-guid>{3F2D1878-7161-4864-BC1D-7682F0EBC11A}</sync-guid><sync-parentguid>{8C12B441-69FE-437B-B6B6-2051B11F4240}</sync-parentguid><sync-checksum>-301332460</sync-checksum><sync-rootid>0</sync-rootid><sync-itemtype>0</sync-itemtype><sync-timestamp>12/3 / Text5: 0/2004 1:12:41 PM</sync-timestamp><sync-itemid>627</sync-itemid><sync-prioritymapping>0:0-0/1:700-1000/2:300-699/3:1-299</sync-prioritymapping>
- 468: Text3: <sync-guid>{F6E7368B-80D2-4FC3-BF64-94577326EFDB}</sync-guid><sync-parentguid>{8C12B441-69FE-437B-B6B6-2051B11F4240}</sync-parentguid><sync-checksum>1072316361</sync-checksum><sync-rootid>0</sync-rootid><sync-itemtype>0</sync-itemtype><sync-timestamp>12/3 / Text5: 0/2004 1:12:42 PM</sync-timestamp><sync-itemid>626</sync-itemid><sync-prioritymapping>0:0-0/1:700-1000/2:300-699/3:1-299</sync-prioritymapping>
- 469: Text3: <sync-guid>{12D0C578-0A27-4CD4-B7A4-4E1AF672B60D}</sync-guid><sync-parentguid>{CEC90403-F9AB-4406-8038-2DF145BE3AC4}</sync-parentguid><sync-checksum>-1821013877</sync-checksum><sync-rootid>0</sync-rootid><sync-itemtype>0</sync-itemtype><sync-timestamp>12 / Text5: 30/2004 1:12:43 PM</sync-timestamp><sync-itemid>303</sync-itemid><sync-prioritymapping>0:0-0/1:700-1000/2:300-699/3:1-299</sync-prioritymapping>
- 470: Text3: <sync-guid>{F27EBDD7-18A0-4037-8A99-D10FD9082187}</sync-guid><sync-parentguid>{12D0C578-0A27-4CD4-B7A4-4E1AF672B60D}</sync-parentguid><sync-checksum>-49639638</sync-checksum><sync-rootid>0</sync-rootid><sync-itemtype>0</sync-itemtype><sync-timestamp>12/30 / Text5: 2004 1:12:42 PM</sync-timestamp><sync-itemid>614</sync-itemid><sync-prioritymapping>0:0-0/1:700-1000/2:300-699/3:1-299</sync-prioritymapping>
- 471: Text3: <sync-guid>{CD8232B8-1E6F-488F-99BE-4E08EABC66BC}</sync-guid><sync-parentguid>{12D0C578-0A27-4CD4-B7A4-4E1AF672B60D}</sync-parentguid><sync-checksum>566996762</sync-checksum><sync-rootid>0</sync-rootid><sync-itemtype>0</sync-itemtype><sync-timestamp>12/30 / Text5: 2004 1:12:42 PM</sync-timestamp><sync-itemid>619</sync-itemid><sync-prioritymapping>0:0-0/1:700-1000/2:300-699/3:1-299</sync-prioritymapping>
- 472: Text3: <sync-guid>{3310AC76-6174-41F9-939D-5A78FD7DC8E1}</sync-guid><sync-parentguid>{12D0C578-0A27-4CD4-B7A4-4E1AF672B60D}</sync-parentguid><sync-checksum>-220967302</sync-checksum><sync-rootid>0</sync-rootid><sync-itemtype>0</sync-itemtype><sync-timestamp>12/3 / Text5: 0/2004 1:12:42 PM</sync-timestamp><sync-itemid>618</sync-itemid><sync-prioritymapping>0:0-0/1:700-1000/2:300-699/3:1-299</sync-prioritymapping>
- 473: Text3: <sync-guid>{604B970A-2D44-4EAF-BDA5-5887B51E6A95}</sync-guid><sync-parentguid>{12D0C578-0A27-4CD4-B7A4-4E1AF672B60D}</sync-parentguid><sync-checksum>-2102119910</sync-checksum><sync-rootid>0</sync-rootid><sync-itemtype>0</sync-itemtype><sync-timestamp>12 / Text5: 30/2004 1:12:42 PM</sync-timestamp><sync-itemid>617</sync-itemid><sync-prioritymapping>0:0-0/1:700-1000/2:300-699/3:1-299</sync-prioritymapping>
- 474: Text3: <sync-guid>{040171D2-F8F8-4B25-8C62-7AF9F6839B11}</sync-guid><sync-parentguid>{12D0C578-0A27-4CD4-B7A4-4E1AF672B60D}</sync-parentguid><sync-checksum>309273042</sync-checksum><sync-rootid>0</sync-rootid><sync-itemtype>0</sync-itemtype><sync-timestamp>12/30 / Text5: 2004 1:12:43 PM</sync-timestamp><sync-itemid>629</sync-itemid><sync-prioritymapping>0:0-0/1:700-1000/2:300-699/3:1-299</sync-prioritymapping>
- 475: Text3: <sync-guid>{40611373-6AD9-4511-8985-CB1443AD3D26}</sync-guid><sync-parentguid>{12D0C578-0A27-4CD4-B7A4-4E1AF672B60D}</sync-parentguid><sync-checksum>-2055048600</sync-checksum><sync-rootid>0</sync-rootid><sync-itemtype>0</sync-itemtype><sync-timestamp>12 / Text5: 30/2004 1:12:43 PM</sync-timestamp><sync-itemid>616</sync-itemid><sync-prioritymapping>0:0-0/1:700-1000/2:300-699/3:1-299</sync-prioritymapping>
- 476: Text3: <sync-guid>{CF7FEF10-B21F-4BE9-AC5D-9C42591D1C50}</sync-guid><sync-parentguid>{12D0C578-0A27-4CD4-B7A4-4E1AF672B60D}</sync-parentguid><sync-checksum>-993692264</sync-checksum><sync-rootid>0</sync-rootid><sync-itemtype>0</sync-itemtype><sync-timestamp>12/3 / Text5: 0/2004 1:12:43 PM</sync-timestamp><sync-itemid>615</sync-itemid><sync-prioritymapping>0:0-0/1:700-1000/2:300-699/3:1-299</sync-prioritymapping>

| ID | WBS | Task | Duration | Start | Finish | Predecessors | Baseline start | Baseline finish | Baseline duration | Total slack | Free slack | Text4 |
| --- | --- | --- | --- | --- | --- | --- | --- | --- | --- | --- | --- | --- |
| 477 | 6.4.6 | **Develop system procedures** | 6d | 2005-04-11 | 2005-04-19 | 471 | 2005-04-11 | 2005-04-19 | 6d | 56.5d | 0d | {4A2D3155-C310-4172-8626-FB84B8C89579} |
| 478 | 6.4.6.1 | Define functional procedures | 2d | 2005-04-11 | 2005-04-13 |  | 2005-04-11 | 2005-04-13 | 2d | 56.5d | 0d | {0FC99675-D734-4953-81D5-B19E99C25F93} |
| 479 | 6.4.6.2 | Define administrative procedures | 2d | 2005-04-11 | 2005-04-13 |  | 2005-04-11 | 2005-04-13 | 2d | 56.5d | 0d | {6DA58A14-1E18-440E-9B72-564480A79565} |
| 480 | 6.4.6.3 | Define support procedures | 2d | 2005-04-11 | 2005-04-13 |  | 2005-04-11 | 2005-04-13 | 2d | 56.5d | 0d | {509A299F-3289-4E4E-BD3A-FE76FFE194A4} |
| 481 | 6.4.6.4 | Define conversion/cutover procedures | 2d | 2005-04-11 | 2005-04-13 |  | 2005-04-11 | 2005-04-13 | 2d | 56.5d | 0d | {CCBEF9FE-1787-422A-B682-4175F81B249D} |
| 482 | 6.4.6.5 | Define training procedures | 2d | 2005-04-11 | 2005-04-13 |  | 2005-04-11 | 2005-04-13 | 2d | 56.5d | 0d | {BDA158C7-9C2B-4703-AC8D-526EEAD0FB19} |
| 483 | 6.4.6.6 | Define backup & recovery procedures | 2d | 2005-04-11 | 2005-04-13 |  | 2005-04-11 | 2005-04-13 | 2d | 56.5d | 0d | {0973CEA2-8FA6-4832-8332-4E2A2B2BC1B3} |
| 484 | 6.4.6.7 | Define audit & archive procedures | 2d | 2005-04-11 | 2005-04-13 |  | 2005-04-11 | 2005-04-13 | 2d | 56.5d | 0d | {D28CACE0-A757-4C5C-AC41-11968E5A98D0} |
| 485 | 6.4.6.8 | Consolidate procedures | 1d | 2005-04-12 | 2005-04-13 | 478FF, 479FF, 480FF, 481FF, 482FF, 483FF, 484FF | 2005-04-12 | 2005-04-13 | 1d | 56.5d | 0d | {6B13E324-3D93-4F7C-9EF4-73FF10987D02} |
| 486 | 6.4.6.9 | Conduct peer review of procedures | 1d | 2005-04-13 | 2005-04-14 | 485 | 2005-04-13 | 2005-04-14 | 1d | 56.5d | 0d | {BE2A33AF-D9DD-4BC5-BB71-F1CFA07253DA} |
| 487 | 6.4.6.10 | Revise procedures based on feedback | 3d | 2005-04-14 | 2005-04-19 | 486 | 2005-04-14 | 2005-04-19 | 3d | 56.5d |  | {D27BFC0C-69BB-40A5-B295-313E978C61EE} |
| 488 | 6.4.7 | **Test system functionality** | 13d | 2005-04-11 | 2005-04-28 | 477SS | 2005-04-11 | 2005-04-28 | 13d | 49.5d |  | {2B251437-8D6F-4D5B-BF63-3FDF471DA01C} |
| 489 | 6.4.7.1 | Confirm system test plans | 1d | 2005-04-11 | 2005-04-12 |  | 2005-04-11 | 2005-04-12 | 1d | 49.5d | 0d | {6E3D43AB-55B6-4CA0-862D-9AC58505F684} |
| 490 | 6.4.7.2 | Finalize system test scripts | 1d | 2005-04-12 | 2005-04-13 | 489 | 2005-04-12 | 2005-04-13 | 1d | 49.5d | 0d | {225EB40D-2231-4D80-BDCA-183ED627B43C} |
| 491 | 6.4.7.3 | Finalize system test data | 1d | 2005-04-13 | 2005-04-14 | 490 | 2005-04-13 | 2005-04-14 | 1d | 49.5d | 0d | {BF49DC36-B2A2-4885-9E5A-92029E33F157} |
| 492 | 6.4.7.4 | Conduct system tests | 3d | 2005-04-14 | 2005-04-19 | 491 | 2005-04-14 | 2005-04-19 | 3d | 49.5d | 0d | {0333C95B-1FC9-4421-8952-4AFF59066737} |
| 493 | 6.4.7.5 | Monitor & correct defects | 4d | 2005-04-14 | 2005-04-20 | 492SS | 2005-04-14 | 2005-04-20 | 4d | 49.5d | 0d | {0E6078B2-3BF4-4D37-958F-A9771849E00D} |
| 494 | 6.4.7.6 | Prepare system test report | 1d | 2005-04-20 | 2005-04-21 | 493 | 2005-04-20 | 2005-04-21 | 1d | 49.5d | 0d | {7F11B29F-D103-480D-AD48-FE9281761FD1} |
| 495 | 6.4.7.7 | Review system test results | 1d | 2005-04-21 | 2005-04-22 | 494 | 2005-04-21 | 2005-04-22 | 1d | 49.5d | 0d | {C1A83D68-8E99-40F2-93D3-6F1B4B91619E} |
| 496 | 6.4.7.8 | Revise & rerun identified tests | 2d | 2005-04-22 | 2005-04-26 | 495 | 2005-04-22 | 2005-04-26 | 2d | 49.5d | 0d | {C003F923-157F-4682-9DE4-20B67188CBB1} |
| 497 | 6.4.7.9 | Finalize system test results | 1d | 2005-04-26 | 2005-04-27 | 496 | 2005-04-26 | 2005-04-27 | 1d | 49.5d | 0d | {5FC2D111-4118-48DB-9D03-12CA4C7EF02B} |
| 498 | 6.4.7.10 | Approve system test results | 1d | 2005-04-27 | 2005-04-28 | 497 | 2005-04-27 | 2005-04-28 | 1d | 49.5d |  | {2D971DAD-805B-4879-A2D7-664E4A12D233} |
| 499 | 6.4.8 | **Test system controls** | 13d | 2005-04-11 | 2005-04-28 | 477SS | 2005-04-11 | 2005-04-28 | 13d | 49.5d |  | {1B63DC09-8847-4CD2-B4D6-D453952449B4} |
| 500 | 6.4.8.1 | Confirm controls test plans | 1d | 2005-04-11 | 2005-04-12 |  | 2005-04-11 | 2005-04-12 | 1d | 49.5d | 0d | {6C8C1805-8EEC-4552-B1B2-87266809E682} |
| 501 | 6.4.8.2 | Finalize controls test scripts | 1d | 2005-04-12 | 2005-04-13 | 500 | 2005-04-12 | 2005-04-13 | 1d | 49.5d | 0d | {26331ADE-1774-4551-B28B-252A53708EDE} |
| 502 | 6.4.8.3 | Finalize controls test data | 1d | 2005-04-13 | 2005-04-14 | 501 | 2005-04-13 | 2005-04-14 | 1d | 49.5d | 0d | {C6588D3A-55C5-4A7E-A495-892053489D84} |
| 503 | 6.4.8.4 | Conduct controls tests | 3d | 2005-04-14 | 2005-04-19 | 502 | 2005-04-14 | 2005-04-19 | 3d | 49.5d | 0d | {3CF75521-169B-4682-8810-351381D7D9DA} |
| 504 | 6.4.8.5 | Monitor & correct defects | 4d | 2005-04-14 | 2005-04-20 | 503SS | 2005-04-14 | 2005-04-20 | 4d | 49.5d | 0d | {2211203A-C16B-4CF1-99A2-39A5BF8B913C} |
| 505 | 6.4.8.6 | Prepare controls test report | 1d | 2005-04-20 | 2005-04-21 | 504 | 2005-04-20 | 2005-04-21 | 1d | 49.5d | 0d | {0B1E2D3C-6BED-4AEE-ACB9-3D3A2C1949CD} |
| 506 | 6.4.8.7 | Review controls test results | 1d | 2005-04-21 | 2005-04-22 | 505 | 2005-04-21 | 2005-04-22 | 1d | 49.5d | 0d | {57270DFF-E3C5-43E7-B0E9-FFF49E9FD8BF} |
| 507 | 6.4.8.8 | Revise & rerun identified tests | 2d | 2005-04-22 | 2005-04-26 | 506 | 2005-04-22 | 2005-04-26 | 2d | 49.5d | 0d | {A2C908BE-7B15-4EDB-A3C0-2ED5F2F9BAE7} |
| 508 | 6.4.8.9 | Finalize controls test results | 1d | 2005-04-26 | 2005-04-27 | 507 | 2005-04-26 | 2005-04-27 | 1d | 49.5d | 0d | {4896A88A-F211-47EE-B6F3-9736D1B6BE8A} |
| 509 | 6.4.8.10 | Approve controls test results | 1d | 2005-04-27 | 2005-04-28 | 508 | 2005-04-27 | 2005-04-28 | 1d | 49.5d |  | {621FB0BA-F53C-4659-8412-C9FC892D75A1} |

Notes:
- 477: Text3: <sync-guid>{4A2D3155-C310-4172-8626-FB84B8C89579}</sync-guid><sync-parentguid>{CEC90403-F9AB-4406-8038-2DF145BE3AC4}</sync-parentguid><sync-checksum>-1013795262</sync-checksum><sync-rootid>0</sync-rootid><sync-itemtype>0</sync-itemtype><sync-timestamp>12 / Text5: 30/2004 1:12:45 PM</sync-timestamp><sync-itemid>601</sync-itemid><sync-prioritymapping>0:0-0/1:700-1000/2:300-699/3:1-299</sync-prioritymapping>
- 478: Text3: <sync-guid>{0FC99675-D734-4953-81D5-B19E99C25F93}</sync-guid><sync-parentguid>{4A2D3155-C310-4172-8626-FB84B8C89579}</sync-parentguid><sync-checksum>-1141943488</sync-checksum><sync-rootid>0</sync-rootid><sync-itemtype>0</sync-itemtype><sync-timestamp>12 / Text5: 30/2004 1:12:43 PM</sync-timestamp><sync-itemid>634</sync-itemid><sync-prioritymapping>0:0-0/1:700-1000/2:300-699/3:1-299</sync-prioritymapping>
- 479: Text3: <sync-guid>{6DA58A14-1E18-440E-9B72-564480A79565}</sync-guid><sync-parentguid>{4A2D3155-C310-4172-8626-FB84B8C89579}</sync-parentguid><sync-checksum>-115181802</sync-checksum><sync-rootid>0</sync-rootid><sync-itemtype>0</sync-itemtype><sync-timestamp>12/3 / Text5: 0/2004 1:12:43 PM</sync-timestamp><sync-itemid>633</sync-itemid><sync-prioritymapping>0:0-0/1:700-1000/2:300-699/3:1-299</sync-prioritymapping>
- 480: Text3: <sync-guid>{509A299F-3289-4E4E-BD3A-FE76FFE194A4}</sync-guid><sync-parentguid>{4A2D3155-C310-4172-8626-FB84B8C89579}</sync-parentguid><sync-checksum>-1510933385</sync-checksum><sync-rootid>0</sync-rootid><sync-itemtype>0</sync-itemtype><sync-timestamp>12 / Text5: 30/2004 1:12:43 PM</sync-timestamp><sync-itemid>632</sync-itemid><sync-prioritymapping>0:0-0/1:700-1000/2:300-699/3:1-299</sync-prioritymapping>
- 481: Text3: <sync-guid>{CCBEF9FE-1787-422A-B682-4175F81B249D}</sync-guid><sync-parentguid>{4A2D3155-C310-4172-8626-FB84B8C89579}</sync-parentguid><sync-checksum>1033707195</sync-checksum><sync-rootid>0</sync-rootid><sync-itemtype>0</sync-itemtype><sync-timestamp>12/3 / Text5: 0/2004 1:12:44 PM</sync-timestamp><sync-itemid>631</sync-itemid><sync-prioritymapping>0:0-0/1:700-1000/2:300-699/3:1-299</sync-prioritymapping>
- 482: Text3: <sync-guid>{BDA158C7-9C2B-4703-AC8D-526EEAD0FB19}</sync-guid><sync-parentguid>{4A2D3155-C310-4172-8626-FB84B8C89579}</sync-parentguid><sync-checksum>-1395736574</sync-checksum><sync-rootid>0</sync-rootid><sync-itemtype>0</sync-itemtype><sync-timestamp>12 / Text5: 30/2004 1:12:44 PM</sync-timestamp><sync-itemid>636</sync-itemid><sync-prioritymapping>0:0-0/1:700-1000/2:300-699/3:1-299</sync-prioritymapping>
- 483: Text3: <sync-guid>{0973CEA2-8FA6-4832-8332-4E2A2B2BC1B3}</sync-guid><sync-parentguid>{4A2D3155-C310-4172-8626-FB84B8C89579}</sync-parentguid><sync-checksum>-182144835</sync-checksum><sync-rootid>0</sync-rootid><sync-itemtype>0</sync-itemtype><sync-timestamp>12/3 / Text5: 0/2004 1:12:44 PM</sync-timestamp><sync-itemid>635</sync-itemid><sync-prioritymapping>0:0-0/1:700-1000/2:300-699/3:1-299</sync-prioritymapping>
- 484: Text3: <sync-guid>{D28CACE0-A757-4C5C-AC41-11968E5A98D0}</sync-guid><sync-parentguid>{4A2D3155-C310-4172-8626-FB84B8C89579}</sync-parentguid><sync-checksum>-1187410968</sync-checksum><sync-rootid>0</sync-rootid><sync-itemtype>0</sync-itemtype><sync-timestamp>12 / Text5: 30/2004 1:12:44 PM</sync-timestamp><sync-itemid>638</sync-itemid><sync-prioritymapping>0:0-0/1:700-1000/2:300-699/3:1-299</sync-prioritymapping>
- 485: Text3: <sync-guid>{6B13E324-3D93-4F7C-9EF4-73FF10987D02}</sync-guid><sync-parentguid>{4A2D3155-C310-4172-8626-FB84B8C89579}</sync-parentguid><sync-checksum>325013852</sync-checksum><sync-rootid>0</sync-rootid><sync-itemtype>0</sync-itemtype><sync-timestamp>12/30 / Text5: 2004 1:12:44 PM</sync-timestamp><sync-itemid>640</sync-itemid><sync-prioritymapping>0:0-0/1:700-1000/2:300-699/3:1-299</sync-prioritymapping>
- 486: Text3: <sync-guid>{BE2A33AF-D9DD-4BC5-BB71-F1CFA07253DA}</sync-guid><sync-parentguid>{4A2D3155-C310-4172-8626-FB84B8C89579}</sync-parentguid><sync-checksum>-402949703</sync-checksum><sync-rootid>0</sync-rootid><sync-itemtype>0</sync-itemtype><sync-timestamp>12/3 / Text5: 0/2004 1:12:44 PM</sync-timestamp><sync-itemid>639</sync-itemid><sync-prioritymapping>0:0-0/1:700-1000/2:300-699/3:1-299</sync-prioritymapping>
- 487: Text3: <sync-guid>{D27BFC0C-69BB-40A5-B295-313E978C61EE}</sync-guid><sync-parentguid>{4A2D3155-C310-4172-8626-FB84B8C89579}</sync-parentguid><sync-checksum>141339467</sync-checksum><sync-rootid>0</sync-rootid><sync-itemtype>0</sync-itemtype><sync-timestamp>12/30 / Text5: 2004 1:12:45 PM</sync-timestamp><sync-itemid>641</sync-itemid><sync-prioritymapping>0:0-0/1:700-1000/2:300-699/3:1-299</sync-prioritymapping>
- 488: Text3: <sync-guid>{2B251437-8D6F-4D5B-BF63-3FDF471DA01C}</sync-guid><sync-parentguid>{CEC90403-F9AB-4406-8038-2DF145BE3AC4}</sync-parentguid><sync-checksum>-1104556860</sync-checksum><sync-rootid>0</sync-rootid><sync-itemtype>0</sync-itemtype><sync-timestamp>12 / Text5: 30/2004 1:12:46 PM</sync-timestamp><sync-itemid>304</sync-itemid><sync-prioritymapping>0:0-0/1:700-1000/2:300-699/3:1-299</sync-prioritymapping>
- 489: Text3: <sync-guid>{6E3D43AB-55B6-4CA0-862D-9AC58505F684}</sync-guid><sync-parentguid>{2B251437-8D6F-4D5B-BF63-3FDF471DA01C}</sync-parentguid><sync-checksum>611022832</sync-checksum><sync-rootid>0</sync-rootid><sync-itemtype>0</sync-itemtype><sync-timestamp>12/30 / Text5: 2004 1:12:45 PM</sync-timestamp><sync-itemid>901</sync-itemid><sync-prioritymapping>0:0-0/1:700-1000/2:300-699/3:1-299</sync-prioritymapping>
- 490: Text3: <sync-guid>{225EB40D-2231-4D80-BDCA-183ED627B43C}</sync-guid><sync-parentguid>{2B251437-8D6F-4D5B-BF63-3FDF471DA01C}</sync-parentguid><sync-checksum>741705075</sync-checksum><sync-rootid>0</sync-rootid><sync-itemtype>0</sync-itemtype><sync-timestamp>12/30 / Text5: 2004 1:12:45 PM</sync-timestamp><sync-itemid>900</sync-itemid><sync-prioritymapping>0:0-0/1:700-1000/2:300-699/3:1-299</sync-prioritymapping>
- 491: Text3: <sync-guid>{BF49DC36-B2A2-4885-9E5A-92029E33F157}</sync-guid><sync-parentguid>{2B251437-8D6F-4D5B-BF63-3FDF471DA01C}</sync-parentguid><sync-checksum>357310544</sync-checksum><sync-rootid>0</sync-rootid><sync-itemtype>0</sync-itemtype><sync-timestamp>12/30 / Text5: 2004 1:12:45 PM</sync-timestamp><sync-itemid>899</sync-itemid><sync-prioritymapping>0:0-0/1:700-1000/2:300-699/3:1-299</sync-prioritymapping>
- 492: Text3: <sync-guid>{0333C95B-1FC9-4421-8952-4AFF59066737}</sync-guid><sync-parentguid>{2B251437-8D6F-4D5B-BF63-3FDF471DA01C}</sync-parentguid><sync-checksum>1442516981</sync-checksum><sync-rootid>0</sync-rootid><sync-itemtype>0</sync-itemtype><sync-timestamp>12/3 / Text5: 0/2004 1:12:45 PM</sync-timestamp><sync-itemid>898</sync-itemid><sync-prioritymapping>0:0-0/1:700-1000/2:300-699/3:1-299</sync-prioritymapping>
- 493: Text3: <sync-guid>{0E6078B2-3BF4-4D37-958F-A9771849E00D}</sync-guid><sync-parentguid>{2B251437-8D6F-4D5B-BF63-3FDF471DA01C}</sync-parentguid><sync-checksum>-192964042</sync-checksum><sync-rootid>0</sync-rootid><sync-itemtype>0</sync-itemtype><sync-timestamp>12/3 / Text5: 0/2004 1:12:46 PM</sync-timestamp><sync-itemid>903</sync-itemid><sync-prioritymapping>0:0-0/1:700-1000/2:300-699/3:1-299</sync-prioritymapping>
- 494: Text3: <sync-guid>{7F11B29F-D103-480D-AD48-FE9281761FD1}</sync-guid><sync-parentguid>{2B251437-8D6F-4D5B-BF63-3FDF471DA01C}</sync-parentguid><sync-checksum>529071178</sync-checksum><sync-rootid>0</sync-rootid><sync-itemtype>0</sync-itemtype><sync-timestamp>12/30 / Text5: 2004 1:12:46 PM</sync-timestamp><sync-itemid>902</sync-itemid><sync-prioritymapping>0:0-0/1:700-1000/2:300-699/3:1-299</sync-prioritymapping>
- 495: Text3: <sync-guid>{C1A83D68-8E99-40F2-93D3-6F1B4B91619E}</sync-guid><sync-parentguid>{2B251437-8D6F-4D5B-BF63-3FDF471DA01C}</sync-parentguid><sync-checksum>1478578340</sync-checksum><sync-rootid>0</sync-rootid><sync-itemtype>0</sync-itemtype><sync-timestamp>12/3 / Text5: 0/2004 1:12:46 PM</sync-timestamp><sync-itemid>906</sync-itemid><sync-prioritymapping>0:0-0/1:700-1000/2:300-699/3:1-299</sync-prioritymapping>
- 496: Text3: <sync-guid>{C003F923-157F-4682-9DE4-20B67188CBB1}</sync-guid><sync-parentguid>{2B251437-8D6F-4D5B-BF63-3FDF471DA01C}</sync-parentguid><sync-checksum>-336028715</sync-checksum><sync-rootid>0</sync-rootid><sync-itemtype>0</sync-itemtype><sync-timestamp>12/3 / Text5: 0/2004 1:12:46 PM</sync-timestamp><sync-itemid>905</sync-itemid><sync-prioritymapping>0:0-0/1:700-1000/2:300-699/3:1-299</sync-prioritymapping>
- 497: Text3: <sync-guid>{5FC2D111-4118-48DB-9D03-12CA4C7EF02B}</sync-guid><sync-parentguid>{2B251437-8D6F-4D5B-BF63-3FDF471DA01C}</sync-parentguid><sync-checksum>-1237672245</sync-checksum><sync-rootid>0</sync-rootid><sync-itemtype>0</sync-itemtype><sync-timestamp>12 / Text5: 30/2004 1:12:46 PM</sync-timestamp><sync-itemid>904</sync-itemid><sync-prioritymapping>0:0-0/1:700-1000/2:300-699/3:1-299</sync-prioritymapping>
- 498: Text3: <sync-guid>{2D971DAD-805B-4879-A2D7-664E4A12D233}</sync-guid><sync-parentguid>{2B251437-8D6F-4D5B-BF63-3FDF471DA01C}</sync-parentguid><sync-checksum>-602933160</sync-checksum><sync-rootid>0</sync-rootid><sync-itemtype>0</sync-itemtype><sync-timestamp>12/3 / Text5: 0/2004 1:12:46 PM</sync-timestamp><sync-itemid>907</sync-itemid><sync-prioritymapping>0:0-0/1:700-1000/2:300-699/3:1-299</sync-prioritymapping>
- 499: Text3: <sync-guid>{1B63DC09-8847-4CD2-B4D6-D453952449B4}</sync-guid><sync-parentguid>{CEC90403-F9AB-4406-8038-2DF145BE3AC4}</sync-parentguid><sync-checksum>216783933</sync-checksum><sync-rootid>0</sync-rootid><sync-itemtype>0</sync-itemtype><sync-timestamp>12/30 / Text5: 2004 1:12:48 PM</sync-timestamp><sync-itemid>604</sync-itemid><sync-prioritymapping>0:0-0/1:700-1000/2:300-699/3:1-299</sync-prioritymapping>
- 500: Text3: <sync-guid>{6C8C1805-8EEC-4552-B1B2-87266809E682}</sync-guid><sync-parentguid>{1B63DC09-8847-4CD2-B4D6-D453952449B4}</sync-parentguid><sync-checksum>-1998031787</sync-checksum><sync-rootid>0</sync-rootid><sync-itemtype>0</sync-itemtype><sync-timestamp>12 / Text5: 30/2004 1:12:47 PM</sync-timestamp><sync-itemid>917</sync-itemid><sync-prioritymapping>0:0-0/1:700-1000/2:300-699/3:1-299</sync-prioritymapping>
- 501: Text3: <sync-guid>{26331ADE-1774-4551-B28B-252A53708EDE}</sync-guid><sync-parentguid>{1B63DC09-8847-4CD2-B4D6-D453952449B4}</sync-parentguid><sync-checksum>-409721281</sync-checksum><sync-rootid>0</sync-rootid><sync-itemtype>0</sync-itemtype><sync-timestamp>12/3 / Text5: 0/2004 1:12:47 PM</sync-timestamp><sync-itemid>916</sync-itemid><sync-prioritymapping>0:0-0/1:700-1000/2:300-699/3:1-299</sync-prioritymapping>
- 502: Text3: <sync-guid>{C6588D3A-55C5-4A7E-A495-892053489D84}</sync-guid><sync-parentguid>{1B63DC09-8847-4CD2-B4D6-D453952449B4}</sync-parentguid><sync-checksum>-1289945026</sync-checksum><sync-rootid>0</sync-rootid><sync-itemtype>0</sync-itemtype><sync-timestamp>12 / Text5: 30/2004 1:12:47 PM</sync-timestamp><sync-itemid>915</sync-itemid><sync-prioritymapping>0:0-0/1:700-1000/2:300-699/3:1-299</sync-prioritymapping>
- 503: Text3: <sync-guid>{3CF75521-169B-4682-8810-351381D7D9DA}</sync-guid><sync-parentguid>{1B63DC09-8847-4CD2-B4D6-D453952449B4}</sync-parentguid><sync-checksum>-672635891</sync-checksum><sync-rootid>0</sync-rootid><sync-itemtype>0</sync-itemtype><sync-timestamp>12/3 / Text5: 0/2004 1:12:47 PM</sync-timestamp><sync-itemid>914</sync-itemid><sync-prioritymapping>0:0-0/1:700-1000/2:300-699/3:1-299</sync-prioritymapping>
- 504: Text3: <sync-guid>{2211203A-C16B-4CF1-99A2-39A5BF8B913C}</sync-guid><sync-parentguid>{1B63DC09-8847-4CD2-B4D6-D453952449B4}</sync-parentguid><sync-checksum>-192964042</sync-checksum><sync-rootid>0</sync-rootid><sync-itemtype>0</sync-itemtype><sync-timestamp>12/3 / Text5: 0/2004 1:12:47 PM</sync-timestamp><sync-itemid>913</sync-itemid><sync-prioritymapping>0:0-0/1:700-1000/2:300-699/3:1-299</sync-prioritymapping>
- 505: Text3: <sync-guid>{0B1E2D3C-6BED-4AEE-ACB9-3D3A2C1949CD}</sync-guid><sync-parentguid>{1B63DC09-8847-4CD2-B4D6-D453952449B4}</sync-parentguid><sync-checksum>-832438194</sync-checksum><sync-rootid>0</sync-rootid><sync-itemtype>0</sync-itemtype><sync-timestamp>12/3 / Text5: 0/2004 1:12:47 PM</sync-timestamp><sync-itemid>912</sync-itemid><sync-prioritymapping>0:0-0/1:700-1000/2:300-699/3:1-299</sync-prioritymapping>
- 506: Text3: <sync-guid>{57270DFF-E3C5-43E7-B0E9-FFF49E9FD8BF}</sync-guid><sync-parentguid>{1B63DC09-8847-4CD2-B4D6-D453952449B4}</sync-parentguid><sync-checksum>2076166893</sync-checksum><sync-rootid>0</sync-rootid><sync-itemtype>0</sync-itemtype><sync-timestamp>12/3 / Text5: 0/2004 1:12:48 PM</sync-timestamp><sync-itemid>911</sync-itemid><sync-prioritymapping>0:0-0/1:700-1000/2:300-699/3:1-299</sync-prioritymapping>
- 507: Text3: <sync-guid>{A2C908BE-7B15-4EDB-A3C0-2ED5F2F9BAE7}</sync-guid><sync-parentguid>{1B63DC09-8847-4CD2-B4D6-D453952449B4}</sync-parentguid><sync-checksum>-336028715</sync-checksum><sync-rootid>0</sync-rootid><sync-itemtype>0</sync-itemtype><sync-timestamp>12/3 / Text5: 0/2004 1:12:48 PM</sync-timestamp><sync-itemid>910</sync-itemid><sync-prioritymapping>0:0-0/1:700-1000/2:300-699/3:1-299</sync-prioritymapping>
- 508: Text3: <sync-guid>{4896A88A-F211-47EE-B6F3-9736D1B6BE8A}</sync-guid><sync-parentguid>{1B63DC09-8847-4CD2-B4D6-D453952449B4}</sync-parentguid><sync-checksum>2107325831</sync-checksum><sync-rootid>0</sync-rootid><sync-itemtype>0</sync-itemtype><sync-timestamp>12/3 / Text5: 0/2004 1:12:48 PM</sync-timestamp><sync-itemid>909</sync-itemid><sync-prioritymapping>0:0-0/1:700-1000/2:300-699/3:1-299</sync-prioritymapping>
- 509: Text3: <sync-guid>{621FB0BA-F53C-4659-8412-C9FC892D75A1}</sync-guid><sync-parentguid>{1B63DC09-8847-4CD2-B4D6-D453952449B4}</sync-parentguid><sync-checksum>-714523129</sync-checksum><sync-rootid>0</sync-rootid><sync-itemtype>0</sync-itemtype><sync-timestamp>12/3 / Text5: 0/2004 1:12:48 PM</sync-timestamp><sync-itemid>908</sync-itemid><sync-prioritymapping>0:0-0/1:700-1000/2:300-699/3:1-299</sync-prioritymapping>

| ID | WBS | Task | Type | Duration | Start | Finish | Predecessors | Baseline start | Baseline finish | Baseline duration | Total slack | Free slack | Text4 |
| --- | --- | --- | --- | --- | --- | --- | --- | --- | --- | --- | --- | --- | --- |
| 510 | 6.4.9 | **Test conversion/cutover mechanisms** |  | 13d | 2005-04-11 | 2005-04-28 | 477SS | 2005-04-11 | 2005-04-28 | 13d | 39.5d |  | {D87E9B0B-5438-41FE-94BC-A8B8AAD27E46} |
| 511 | 6.4.9.1 | Confirm conversion test plans |  | 1d | 2005-04-11 | 2005-04-12 |  | 2005-04-11 | 2005-04-12 | 1d | 39.5d | 0d | {2F7AE61A-C12F-4F05-BAF3-BC5736A223C3} |
| 512 | 6.4.9.2 | Finalize conversion test scripts |  | 1d | 2005-04-12 | 2005-04-13 | 511 | 2005-04-12 | 2005-04-13 | 1d | 39.5d | 0d | {390E1E5F-6AB5-45F6-ADC4-F76BA56CD840} |
| 513 | 6.4.9.3 | Finalize conversion test data |  | 1d | 2005-04-13 | 2005-04-14 | 512 | 2005-04-13 | 2005-04-14 | 1d | 39.5d | 0d | {0E6EE4F4-4B38-45B8-BA42-B52AB1473CCA} |
| 514 | 6.4.9.4 | Conduct conversion tests |  | 3d | 2005-04-14 | 2005-04-19 | 513 | 2005-04-14 | 2005-04-19 | 3d | 39.5d | 0d | {37F445AC-A9D6-485D-91B8-3849CA1B4AD5} |
| 515 | 6.4.9.5 | Monitor & correct defects |  | 4d | 2005-04-14 | 2005-04-20 | 514SS | 2005-04-14 | 2005-04-20 | 4d | 39.5d | 0d | {122863FF-5A6F-4D8A-A981-959DFF3CDA89} |
| 516 | 6.4.9.6 | Prepare conversion test report |  | 1d | 2005-04-20 | 2005-04-21 | 515 | 2005-04-20 | 2005-04-21 | 1d | 39.5d | 0d | {80FA37D1-2959-4A07-9CBB-3AD73A65E610} |
| 517 | 6.4.9.7 | Review conversion test results |  | 1d | 2005-04-21 | 2005-04-22 | 516 | 2005-04-21 | 2005-04-22 | 1d | 39.5d | 0d | {B125848E-77E4-4EB5-B9FE-6ACBC2E78569} |
| 518 | 6.4.9.8 | Revise & rerun identified tests |  | 2d | 2005-04-22 | 2005-04-26 | 517 | 2005-04-22 | 2005-04-26 | 2d | 39.5d | 0d | {5A95CAE7-2C90-41DD-BE1C-4A3CAE470D06} |
| 519 | 6.4.9.9 | Finalize conversion test results |  | 1d | 2005-04-26 | 2005-04-27 | 518 | 2005-04-26 | 2005-04-27 | 1d | 39.5d | 0d | {FDB7A41E-11FB-4692-A264-715D062622C9} |
| 520 | 6.4.9.10 | Approve conversion test results |  | 1d | 2005-04-27 | 2005-04-28 | 519 | 2005-04-27 | 2005-04-28 | 1d | 39.5d | 0d | {80FA548E-10D8-4ACA-9A91-2D5A41C11BE9} |
| 521 | 6.4.10 | **Evaluate testing results** |  | 4d | 2005-04-28 | 2005-05-04 | 520 | 2005-04-28 | 2005-05-04 | 4d | 39.5d | 0d | {493C1072-E8D0-46CE-A813-59E3B87641EA} |
| 522 | 6.4.10.1 | Consolidate test results |  | 1d | 2005-04-28 | 2005-04-29 |  | 2005-04-28 | 2005-04-29 | 1d | 39.5d | 0d | {BB35610C-DD2A-463D-B664-EE8AECC82EC4} |
| 523 | 6.4.10.2 | Plan follow-on testing |  | 1d | 2005-04-29 | 2005-05-02 | 522 | 2005-04-29 | 2005-05-02 | 1d | 39.5d | 0d | {C4EDA90F-07FC-4DD4-9888-2DD9B1CF4339} |
| 524 | 6.4.10.3 | Finalize implementation planning |  | 1d | 2005-05-02 | 2005-05-03 | 523 | 2005-05-02 | 2005-05-03 | 1d | 39.5d | 0d | {11423069-EC41-415A-A202-D5B2DA40216D} |
| 525 | 6.4.10.4 | Review test results & plans |  | 1d | 2005-05-03 | 2005-05-04 | 524 | 2005-05-03 | 2005-05-04 | 1d | 39.5d | 0d | {7568F192-13A3-4487-B0F6-0C4BAFDF1DFB} |
| 526 | 6.4.10.5 | Approve system for implementation | milestone | 0d | 2005-05-04 | 2005-05-04 | 525 | 2005-05-04 | 2005-05-04 | 0d | 39.5d |  | {A6FA1B94-0F80-4275-9C28-01AF680214E3} |
| 527 | 6.4.11 | **Update subproject plan** |  | 4d | 2005-05-04 | 2005-05-10 | 521 | 2005-05-04 | 2005-05-10 | 4d | 39.5d | 0d | {A18E502D-3304-4499-ABC6-3A737A53C8AE} |
| 528 | 6.4.11.1 | Review project status and milestones |  | 1d | 2005-05-04 | 2005-05-05 |  | 2005-05-04 | 2005-05-05 | 1d | 39.5d | 0d | {7828CFA9-3682-4B3A-8E99-A5A4434C3B95} |
| 529 | 6.4.11.2 | Revise plan schedule & assignments |  | 1d | 2005-05-05 | 2005-05-06 | 528 | 2005-05-05 | 2005-05-06 | 1d | 39.5d | 0d | {AB20ABB9-CAEF-42EA-9602-2A688E3B720A} |
| 530 | 6.4.11.3 | Review charter & plan with stakeholders |  | 1d | 2005-05-06 | 2005-05-09 | 529 | 2005-05-06 | 2005-05-09 | 1d | 39.5d | 0d | {E8F14CF4-AC6D-4B89-9D08-1D17B81C1A95} |
| 531 | 6.4.11.4 | Finalize plan revisions |  | 1d | 2005-05-09 | 2005-05-10 | 530 | 2005-05-09 | 2005-05-10 | 1d | 39.5d | 0d | {C34A16B5-6418-47E6-B21C-C47B48F75FCA} |
| 532 | 6.4.11.5 | Approve revised subproject plan | milestone | 0d | 2005-05-10 | 2005-05-10 | 531 | 2005-05-10 | 2005-05-10 | 0d | 39.5d |  | {246D354C-0883-4113-B9FC-630C68503FB6} |
| 533 | 6.4.12 | **Conduct phase QA assessment** |  | 2d | 2005-05-10 | 2005-05-12 | 527 | 2005-05-10 | 2005-05-12 | 2d | 39.5d |  | {14F28554-D6F7-40A1-91EC-9AC8FB21AC69} |
| 534 | 6.4.12.1 | Consolidate phase results |  | 0.5d | 2005-05-10 | 2005-05-10 |  | 2005-05-10 | 2005-05-10 | 0.5d | 39.5d | 0d | {58C98F3E-AD15-49A1-8D78-6A232B009B42} |
| 535 | 6.4.12.2 | Conduct phase self-assessment |  | 0.25d | 2005-05-11 | 2005-05-11 | 534 | 2005-05-11 | 2005-05-11 | 0.25d | 39.5d | 0d | {5EFD5BE9-6EFF-4801-B6CC-08E155DE6A24} |
| 536 | 6.4.12.3 | Conduct QA assessment |  | 0.5d | 2005-05-11 | 2005-05-11 | 535 | 2005-05-11 | 2005-05-11 | 0.5d | 39.5d | 0d | {EB99B56A-D509-4F02-B2D2-BBA9A330D5D1} |
| 537 | 6.4.12.4 | Review assessment feedback |  | 0.25d | 2005-05-11 | 2005-05-11 | 536 | 2005-05-11 | 2005-05-11 | 0.25d | 39.5d | 0d | {03C57F50-DD85-4C53-95D3-501D67D3E16D} |
| 538 | 6.4.12.5 | Implement QA feedback |  | 0.5d | 2005-05-12 | 2005-05-12 | 537 | 2005-05-12 | 2005-05-12 | 0.5d | 39.5d |  | {3E66F0D5-68E2-4BD2-9D91-C77B89CBCAAB} |

Notes:
- 510: Text3: <sync-guid>{D87E9B0B-5438-41FE-94BC-A8B8AAD27E46}</sync-guid><sync-parentguid>{CEC90403-F9AB-4406-8038-2DF145BE3AC4}</sync-parentguid><sync-checksum>-1817026967</sync-checksum><sync-rootid>0</sync-rootid><sync-itemtype>0</sync-itemtype><sync-timestamp>12 / Text5: 30/2004 1:12:50 PM</sync-timestamp><sync-itemid>603</sync-itemid><sync-prioritymapping>0:0-0/1:700-1000/2:300-699/3:1-299</sync-prioritymapping>
- 511: Text3: <sync-guid>{2F7AE61A-C12F-4F05-BAF3-BC5736A223C3}</sync-guid><sync-parentguid>{D87E9B0B-5438-41FE-94BC-A8B8AAD27E46}</sync-parentguid><sync-checksum>52561107</sync-checksum><sync-rootid>0</sync-rootid><sync-itemtype>0</sync-itemtype><sync-timestamp>12/30 / Text5: 2004 1:12:49 PM</sync-timestamp><sync-itemid>927</sync-itemid><sync-prioritymapping>0:0-0/1:700-1000/2:300-699/3:1-299</sync-prioritymapping>
- 512: Text3: <sync-guid>{390E1E5F-6AB5-45F6-ADC4-F76BA56CD840}</sync-guid><sync-parentguid>{D87E9B0B-5438-41FE-94BC-A8B8AAD27E46}</sync-parentguid><sync-checksum>2120657371</sync-checksum><sync-rootid>0</sync-rootid><sync-itemtype>0</sync-itemtype><sync-timestamp>12/3 / Text5: 0/2004 1:12:49 PM</sync-timestamp><sync-itemid>926</sync-itemid><sync-prioritymapping>0:0-0/1:700-1000/2:300-699/3:1-299</sync-prioritymapping>
- 513: Text3: <sync-guid>{0E6EE4F4-4B38-45B8-BA42-B52AB1473CCA}</sync-guid><sync-parentguid>{D87E9B0B-5438-41FE-94BC-A8B8AAD27E46}</sync-parentguid><sync-checksum>-1579845456</sync-checksum><sync-rootid>0</sync-rootid><sync-itemtype>0</sync-itemtype><sync-timestamp>12 / Text5: 30/2004 1:12:49 PM</sync-timestamp><sync-itemid>925</sync-itemid><sync-prioritymapping>0:0-0/1:700-1000/2:300-699/3:1-299</sync-prioritymapping>
- 514: Text3: <sync-guid>{37F445AC-A9D6-485D-91B8-3849CA1B4AD5}</sync-guid><sync-parentguid>{D87E9B0B-5438-41FE-94BC-A8B8AAD27E46}</sync-parentguid><sync-checksum>993269121</sync-checksum><sync-rootid>0</sync-rootid><sync-itemtype>0</sync-itemtype><sync-timestamp>12/30 / Text5: 2004 1:12:49 PM</sync-timestamp><sync-itemid>924</sync-itemid><sync-prioritymapping>0:0-0/1:700-1000/2:300-699/3:1-299</sync-prioritymapping>
- 515: Text3: <sync-guid>{122863FF-5A6F-4D8A-A981-959DFF3CDA89}</sync-guid><sync-parentguid>{D87E9B0B-5438-41FE-94BC-A8B8AAD27E46}</sync-parentguid><sync-checksum>-192964042</sync-checksum><sync-rootid>0</sync-rootid><sync-itemtype>0</sync-itemtype><sync-timestamp>12/3 / Text5: 0/2004 1:12:49 PM</sync-timestamp><sync-itemid>923</sync-itemid><sync-prioritymapping>0:0-0/1:700-1000/2:300-699/3:1-299</sync-prioritymapping>
- 516: Text3: <sync-guid>{80FA37D1-2959-4A07-9CBB-3AD73A65E610}</sync-guid><sync-parentguid>{D87E9B0B-5438-41FE-94BC-A8B8AAD27E46}</sync-parentguid><sync-checksum>-1703257972</sync-checksum><sync-rootid>0</sync-rootid><sync-itemtype>0</sync-itemtype><sync-timestamp>12 / Text5: 30/2004 1:12:49 PM</sync-timestamp><sync-itemid>922</sync-itemid><sync-prioritymapping>0:0-0/1:700-1000/2:300-699/3:1-299</sync-prioritymapping>
- 517: Text3: <sync-guid>{B125848E-77E4-4EB5-B9FE-6ACBC2E78569}</sync-guid><sync-parentguid>{D87E9B0B-5438-41FE-94BC-A8B8AAD27E46}</sync-parentguid><sync-checksum>-1069559429</sync-checksum><sync-rootid>0</sync-rootid><sync-itemtype>0</sync-itemtype><sync-timestamp>12 / Text5: 30/2004 1:12:49 PM</sync-timestamp><sync-itemid>921</sync-itemid><sync-prioritymapping>0:0-0/1:700-1000/2:300-699/3:1-299</sync-prioritymapping>
- 518: Text3: <sync-guid>{5A95CAE7-2C90-41DD-BE1C-4A3CAE470D06}</sync-guid><sync-parentguid>{D87E9B0B-5438-41FE-94BC-A8B8AAD27E46}</sync-parentguid><sync-checksum>-336028715</sync-checksum><sync-rootid>0</sync-rootid><sync-itemtype>0</sync-itemtype><sync-timestamp>12/3 / Text5: 0/2004 1:12:50 PM</sync-timestamp><sync-itemid>920</sync-itemid><sync-prioritymapping>0:0-0/1:700-1000/2:300-699/3:1-299</sync-prioritymapping>
- 519: Text3: <sync-guid>{FDB7A41E-11FB-4692-A264-715D062622C9}</sync-guid><sync-parentguid>{D87E9B0B-5438-41FE-94BC-A8B8AAD27E46}</sync-parentguid><sync-checksum>-462835101</sync-checksum><sync-rootid>0</sync-rootid><sync-itemtype>0</sync-itemtype><sync-timestamp>12/3 / Text5: 0/2004 1:12:50 PM</sync-timestamp><sync-itemid>919</sync-itemid><sync-prioritymapping>0:0-0/1:700-1000/2:300-699/3:1-299</sync-prioritymapping>
- 520: Text3: <sync-guid>{80FA548E-10D8-4ACA-9A91-2D5A41C11BE9}</sync-guid><sync-parentguid>{D87E9B0B-5438-41FE-94BC-A8B8AAD27E46}</sync-parentguid><sync-checksum>279750497</sync-checksum><sync-rootid>0</sync-rootid><sync-itemtype>0</sync-itemtype><sync-timestamp>12/30 / Text5: 2004 1:12:50 PM</sync-timestamp><sync-itemid>918</sync-itemid><sync-prioritymapping>0:0-0/1:700-1000/2:300-699/3:1-299</sync-prioritymapping>
- 521: Text3: <sync-guid>{493C1072-E8D0-46CE-A813-59E3B87641EA}</sync-guid><sync-parentguid>{CEC90403-F9AB-4406-8038-2DF145BE3AC4}</sync-parentguid><sync-checksum>245129541</sync-checksum><sync-rootid>0</sync-rootid><sync-itemtype>0</sync-itemtype><sync-timestamp>12/30 / Text5: 2004 1:12:51 PM</sync-timestamp><sync-itemid>602</sync-itemid><sync-prioritymapping>0:0-0/1:700-1000/2:300-699/3:1-299</sync-prioritymapping>
- 522: Text3: <sync-guid>{BB35610C-DD2A-463D-B664-EE8AECC82EC4}</sync-guid><sync-parentguid>{493C1072-E8D0-46CE-A813-59E3B87641EA}</sync-parentguid><sync-checksum>842338485</sync-checksum><sync-rootid>0</sync-rootid><sync-itemtype>0</sync-itemtype><sync-timestamp>12/30 / Text5: 2004 1:12:50 PM</sync-timestamp><sync-itemid>606</sync-itemid><sync-prioritymapping>0:0-0/1:700-1000/2:300-699/3:1-299</sync-prioritymapping>
- 523: Text3: <sync-guid>{C4EDA90F-07FC-4DD4-9888-2DD9B1CF4339}</sync-guid><sync-parentguid>{493C1072-E8D0-46CE-A813-59E3B87641EA}</sync-parentguid><sync-checksum>-1509547301</sync-checksum><sync-rootid>0</sync-rootid><sync-itemtype>0</sync-itemtype><sync-timestamp>12 / Text5: 30/2004 1:12:50 PM</sync-timestamp><sync-itemid>609</sync-itemid><sync-prioritymapping>0:0-0/1:700-1000/2:300-699/3:1-299</sync-prioritymapping>
- 524: Text3: <sync-guid>{11423069-EC41-415A-A202-D5B2DA40216D}</sync-guid><sync-parentguid>{493C1072-E8D0-46CE-A813-59E3B87641EA}</sync-parentguid><sync-checksum>-1034509326</sync-checksum><sync-rootid>0</sync-rootid><sync-itemtype>0</sync-itemtype><sync-timestamp>12 / Text5: 30/2004 1:12:51 PM</sync-timestamp><sync-itemid>608</sync-itemid><sync-prioritymapping>0:0-0/1:700-1000/2:300-699/3:1-299</sync-prioritymapping>
- 525: Text3: <sync-guid>{7568F192-13A3-4487-B0F6-0C4BAFDF1DFB}</sync-guid><sync-parentguid>{493C1072-E8D0-46CE-A813-59E3B87641EA}</sync-parentguid><sync-checksum>-100430667</sync-checksum><sync-rootid>0</sync-rootid><sync-itemtype>0</sync-itemtype><sync-timestamp>12/3 / Text5: 0/2004 1:12:51 PM</sync-timestamp><sync-itemid>607</sync-itemid><sync-prioritymapping>0:0-0/1:700-1000/2:300-699/3:1-299</sync-prioritymapping>
- 526: Text3: <sync-guid>{A6FA1B94-0F80-4275-9C28-01AF680214E3}</sync-guid><sync-parentguid>{493C1072-E8D0-46CE-A813-59E3B87641EA}</sync-parentguid><sync-checksum>410665162</sync-checksum><sync-rootid>0</sync-rootid><sync-itemtype>0</sync-itemtype><sync-timestamp>12/30 / Text5: 2004 1:12:51 PM</sync-timestamp><sync-itemid>605</sync-itemid><sync-prioritymapping>0:0-0/1:700-1000/2:300-699/3:1-299</sync-prioritymapping>
- 527: Text3: <sync-guid>{A18E502D-3304-4499-ABC6-3A737A53C8AE}</sync-guid><sync-parentguid>{CEC90403-F9AB-4406-8038-2DF145BE3AC4}</sync-parentguid><sync-checksum>727546072</sync-checksum><sync-rootid>0</sync-rootid><sync-itemtype>0</sync-itemtype><sync-timestamp>12/30 / Text5: 2004 1:12:52 PM</sync-timestamp><sync-itemid>675</sync-itemid><sync-prioritymapping>0:0-0/1:700-1000/2:300-699/3:1-299</sync-prioritymapping>
- 528: Text3: <sync-guid>{7828CFA9-3682-4B3A-8E99-A5A4434C3B95}</sync-guid><sync-parentguid>{A18E502D-3304-4499-ABC6-3A737A53C8AE}</sync-parentguid><sync-checksum>2072256968</sync-checksum><sync-rootid>0</sync-rootid><sync-itemtype>0</sync-itemtype><sync-timestamp>12/3 / Text5: 0/2004 1:12:51 PM</sync-timestamp><sync-itemid>674</sync-itemid><sync-prioritymapping>0:0-0/1:700-1000/2:300-699/3:1-299</sync-prioritymapping>
- 529: Text3: <sync-guid>{AB20ABB9-CAEF-42EA-9602-2A688E3B720A}</sync-guid><sync-parentguid>{A18E502D-3304-4499-ABC6-3A737A53C8AE}</sync-parentguid><sync-checksum>851713127</sync-checksum><sync-rootid>0</sync-rootid><sync-itemtype>0</sync-itemtype><sync-timestamp>12/30 / Text5: 2004 1:12:51 PM</sync-timestamp><sync-itemid>673</sync-itemid><sync-prioritymapping>0:0-0/1:700-1000/2:300-699/3:1-299</sync-prioritymapping>
- 530: Text3: <sync-guid>{E8F14CF4-AC6D-4B89-9D08-1D17B81C1A95}</sync-guid><sync-parentguid>{A18E502D-3304-4499-ABC6-3A737A53C8AE}</sync-parentguid><sync-checksum>-1489857064</sync-checksum><sync-rootid>0</sync-rootid><sync-itemtype>0</sync-itemtype><sync-timestamp>12 / Text5: 30/2004 1:12:52 PM</sync-timestamp><sync-itemid>672</sync-itemid><sync-prioritymapping>0:0-0/1:700-1000/2:300-699/3:1-299</sync-prioritymapping>
- 531: Text3: <sync-guid>{C34A16B5-6418-47E6-B21C-C47B48F75FCA}</sync-guid><sync-parentguid>{A18E502D-3304-4499-ABC6-3A737A53C8AE}</sync-parentguid><sync-checksum>-802072422</sync-checksum><sync-rootid>0</sync-rootid><sync-itemtype>0</sync-itemtype><sync-timestamp>12/3 / Text5: 0/2004 1:12:52 PM</sync-timestamp><sync-itemid>671</sync-itemid><sync-prioritymapping>0:0-0/1:700-1000/2:300-699/3:1-299</sync-prioritymapping>
- 532: Text3: <sync-guid>{246D354C-0883-4113-B9FC-630C68503FB6}</sync-guid><sync-parentguid>{A18E502D-3304-4499-ABC6-3A737A53C8AE}</sync-parentguid><sync-checksum>-1488867702</sync-checksum><sync-rootid>0</sync-rootid><sync-itemtype>0</sync-itemtype><sync-timestamp>12 / Text5: 30/2004 1:12:52 PM</sync-timestamp><sync-itemid>670</sync-itemid><sync-prioritymapping>0:0-0/1:700-1000/2:300-699/3:1-299</sync-prioritymapping>
- 533: Text3: <sync-guid>{14F28554-D6F7-40A1-91EC-9AC8FB21AC69}</sync-guid><sync-parentguid>{CEC90403-F9AB-4406-8038-2DF145BE3AC4}</sync-parentguid><sync-checksum>-334428633</sync-checksum><sync-rootid>0</sync-rootid><sync-itemtype>0</sync-itemtype><sync-timestamp>12/3 / Text5: 0/2004 1:12:53 PM</sync-timestamp><sync-itemid>372</sync-itemid><sync-prioritymapping>0:0-0/1:700-1000/2:300-699/3:1-299</sync-prioritymapping>
- 534: Text3: <sync-guid>{58C98F3E-AD15-49A1-8D78-6A232B009B42}</sync-guid><sync-parentguid>{14F28554-D6F7-40A1-91EC-9AC8FB21AC69}</sync-parentguid><sync-checksum>832864713</sync-checksum><sync-rootid>0</sync-rootid><sync-itemtype>0</sync-itemtype><sync-timestamp>12/30 / Text5: 2004 1:12:52 PM</sync-timestamp><sync-itemid>1103</sync-itemid><sync-prioritymapping>0:0-0/1:700-1000/2:300-699/3:1-299</sync-prioritymapping>
- 535: Text3: <sync-guid>{5EFD5BE9-6EFF-4801-B6CC-08E155DE6A24}</sync-guid><sync-parentguid>{14F28554-D6F7-40A1-91EC-9AC8FB21AC69}</sync-parentguid><sync-checksum>533208345</sync-checksum><sync-rootid>0</sync-rootid><sync-itemtype>0</sync-itemtype><sync-timestamp>12/30 / Text5: 2004 1:12:52 PM</sync-timestamp><sync-itemid>1102</sync-itemid><sync-prioritymapping>0:0-0/1:700-1000/2:300-699/3:1-299</sync-prioritymapping>
- 536: Text3: <sync-guid>{EB99B56A-D509-4F02-B2D2-BBA9A330D5D1}</sync-guid><sync-parentguid>{14F28554-D6F7-40A1-91EC-9AC8FB21AC69}</sync-parentguid><sync-checksum>-2099010785</sync-checksum><sync-rootid>0</sync-rootid><sync-itemtype>0</sync-itemtype><sync-timestamp>12 / Text5: 30/2004 1:12:52 PM</sync-timestamp><sync-itemid>1101</sync-itemid><sync-prioritymapping>0:0-0/1:700-1000/2:300-699/3:1-299</sync-prioritymapping>
- 537: Text3: <sync-guid>{03C57F50-DD85-4C53-95D3-501D67D3E16D}</sync-guid><sync-parentguid>{14F28554-D6F7-40A1-91EC-9AC8FB21AC69}</sync-parentguid><sync-checksum>-766512336</sync-checksum><sync-rootid>0</sync-rootid><sync-itemtype>0</sync-itemtype><sync-timestamp>12/3 / Text5: 0/2004 1:12:53 PM</sync-timestamp><sync-itemid>1100</sync-itemid><sync-prioritymapping>0:0-0/1:700-1000/2:300-699/3:1-299</sync-prioritymapping>
- 538: Text3: <sync-guid>{3E66F0D5-68E2-4BD2-9D91-C77B89CBCAAB}</sync-guid><sync-parentguid>{14F28554-D6F7-40A1-91EC-9AC8FB21AC69}</sync-parentguid><sync-checksum>-182726984</sync-checksum><sync-rootid>0</sync-rootid><sync-itemtype>0</sync-itemtype><sync-timestamp>12/3 / Text5: 0/2004 1:12:53 PM</sync-timestamp><sync-itemid>1099</sync-itemid><sync-prioritymapping>0:0-0/1:700-1000/2:300-699/3:1-299</sync-prioritymapping>

| ID | WBS | Task | Duration | Start | Finish | Predecessors | Baseline start | Baseline finish | Baseline duration | Total slack | Free slack | Text4 |
| --- | --- | --- | --- | --- | --- | --- | --- | --- | --- | --- | --- | --- |
| 539 | 6.5 | **ACCEPT & IMPLEMENT** | 34d | 2005-05-12 | 2005-06-29 | 430 | 2005-05-12 | 2005-06-29 | 34d | 39.5d |  | {B572D7F3-0630-41BE-A63B-C425E92F4460} |
| 540 | 6.5.1 | **Implement tested system** | 31d | 2005-05-12 | 2005-06-24 |  | 2005-05-12 | 2005-06-24 | 31d | 39.5d |  | {4ACF3A3D-37FB-42F6-90DB-920A0B75F72F} |
| 541 | 6.5.1.1 | Commmunicate implementation | 1d | 2005-05-12 | 2005-05-13 |  | 2005-05-12 | 2005-05-13 | 1d | 39.5d | 0d | {0EBA64A7-C40E-4A8F-BA41-91DBCB5BA571} |
| 542 | 6.5.1.2 | Respond to exceptions | 30d | 2005-05-13 | 2005-06-24 | 541 | 2005-05-13 | 2005-06-24 | 30d | 42.5d |  | {3FD26125-CB0D-4FFB-B431-7153D8F300ED} |
| 543 | 6.5.2 | **Conduct user training** | 17.5d | 2005-05-13 | 2005-06-07 | 541 | 2005-05-13 | 2005-06-07 | 17.5d | 39.5d |  | {DE1D41B6-69B0-4EA9-A852-ABBE17AF4AE4} |
| 544 | 6.5.2.1 | Finalize training procedures | 0.5d | 2005-05-13 | 2005-05-13 |  | 2005-05-13 | 2005-05-13 | 0.5d | 39.5d | 0d | {2085DA50-C71E-4805-8A09-97B85865F841} |
| 545 | 6.5.2.2 | Execute training procedures | 2d | 2005-05-16 | 2005-05-17 | 544 | 2005-05-16 | 2005-05-17 | 2d | 39.5d | 0d | {6D8A83B4-0DD4-471D-917D-1FA97FEEC87A} |
| 546 | 6.5.2.3 | Evaluate training effectiveness | 0.5d | 2005-05-18 | 2005-05-18 | 545 | 2005-05-18 | 2005-05-18 | 0.5d | 55d | 0d | {830A09A8-C4AC-4D03-8F6F-FB770FF2846C} |
| 547 | 6.5.2.4 | Provide initial support | 15d | 2005-05-18 | 2005-06-07 | 546SS | 2005-05-18 | 2005-06-07 | 15d | 55d |  | {6F9CE0B1-925C-4E03-9DF3-570846E23E89} |
| 548 | 6.5.3 | **Convert/cutover systems** | 17.5d | 2005-05-18 | 2005-06-10 | 545 | 2005-05-18 | 2005-06-10 | 17.5d | 39.5d | 0d | {5FECDB87-5922-4D53-B51B-7C9E52587BDF} |
| 549 | 6.5.3.1 | Finalize cut-over procedures | 0.5d | 2005-05-18 | 2005-05-18 |  | 2005-05-18 | 2005-05-18 | 0.5d | 39.5d | 0d | {E59AB2FE-C901-4975-8F7E-0925FD7206EF} |
| 550 | 6.5.3.2 | Execute cut-over procedures | 2d | 2005-05-18 | 2005-05-20 | 549 | 2005-05-18 | 2005-05-20 | 2d | 39.5d | 0d | {C1F1BA18-CB9C-4128-9ACE-ACD4BFFBADC6} |
| 551 | 6.5.3.3 | Evaluate cut-over effectiveness | 0.5d | 2005-05-20 | 2005-05-20 | 550 | 2005-05-20 | 2005-05-20 | 0.5d | 46.5d | 0d | {46E5C11D-9F15-41DC-88A3-E6D067DFF289} |
| 552 | 6.5.3.4 | Monitor cut-over exceptions | 15d | 2005-05-20 | 2005-06-10 | 550 | 2005-05-20 | 2005-06-10 | 15d | 39.5d |  | {FF25CB52-61BB-4EF8-A7AF-6CFB22683730} |
| 553 | 6.5.4 | **Conduct user acceptance testing** | 13d | 2005-05-20 | 2005-06-08 | 551SS | 2005-05-20 | 2005-06-08 | 13d | 46.5d |  | {CED5E167-735F-40DE-A294-DEF36EC1AF48} |
| 554 | 6.5.4.1 | Confirm acceptance test plans | 1d | 2005-05-20 | 2005-05-23 |  | 2005-05-20 | 2005-05-23 | 1d | 46.5d | 0d | {5C2EDDDB-EA7E-41E5-9B00-4637A6C23D8B} |
| 555 | 6.5.4.2 | Finalize conversion test scripts | 1d | 2005-05-23 | 2005-05-24 | 554 | 2005-05-23 | 2005-05-24 | 1d | 46.5d | 0d | {48D6D1E9-CA72-48E0-A80B-CA09D25245CE} |
| 556 | 6.5.4.3 | Finalize acceptance test data | 1d | 2005-05-24 | 2005-05-25 | 555 | 2005-05-24 | 2005-05-25 | 1d | 46.5d | 0d | {83651683-BD94-44AB-AE97-17A990DB5A38} |
| 557 | 6.5.4.4 | Conduct acceptance tests | 3d | 2005-05-25 | 2005-05-30 | 556 | 2005-05-25 | 2005-05-30 | 3d | 46.5d | 0d | {6B713AD7-0E96-46BD-A7A0-D4BD57768E0A} |
| 558 | 6.5.4.5 | Monitor & correct defects | 4d | 2005-05-25 | 2005-05-31 | 557SS | 2005-05-25 | 2005-05-31 | 4d | 46.5d | 0d | {DD274536-CDB9-4141-9565-70295940B114} |
| 559 | 6.5.4.6 | Prepare acceptance test report | 1d | 2005-05-31 | 2005-06-01 | 558 | 2005-05-31 | 2005-06-01 | 1d | 46.5d | 0d | {995C0421-0163-4979-B89C-D61D4713808E} |
| 560 | 6.5.4.7 | Review acceptance test results | 1d | 2005-06-01 | 2005-06-02 | 559 | 2005-06-01 | 2005-06-02 | 1d | 46.5d | 0d | {558EA645-CF15-4A65-A132-851DE20AFA2E} |
| 561 | 6.5.4.8 | Revise & rerun identified tests | 2d | 2005-06-02 | 2005-06-06 | 560 | 2005-06-02 | 2005-06-06 | 2d | 46.5d | 0d | {4FFE3286-B231-485B-8822-BE81425BC037} |
| 562 | 6.5.4.9 | Finalize acceptance test results | 1d | 2005-06-06 | 2005-06-07 | 561 | 2005-06-06 | 2005-06-07 | 1d | 46.5d | 0d | {E5D49573-A3F9-42B1-8F3C-B2C5E58BA323} |
| 563 | 6.5.4.10 | Approve acceptance test results | 1d | 2005-06-07 | 2005-06-08 | 562 | 2005-06-07 | 2005-06-08 | 1d | 46.5d | 0d | {977456EB-216F-48AD-8898-95701D7A8E80} |

Notes:
- 539: Text3: <sync-guid>{B572D7F3-0630-41BE-A63B-C425E92F4460}</sync-guid><sync-parentguid>{2B2817F9-76F5-4CDD-8182-CF152760D6BB}</sync-parentguid><sync-checksum>-1745904270</sync-checksum><sync-rootid>0</sync-rootid><sync-itemtype>0</sync-itemtype><sync-timestamp>12 / Text5: 30/2004 1:13:02 PM</sync-timestamp><sync-itemid>305</sync-itemid><sync-prioritymapping>0:0-0/1:700-1000/2:300-699/3:1-299</sync-prioritymapping>
- 540: Text3: <sync-guid>{4ACF3A3D-37FB-42F6-90DB-920A0B75F72F}</sync-guid><sync-parentguid>{B572D7F3-0630-41BE-A63B-C425E92F4460}</sync-parentguid><sync-checksum>1282252118</sync-checksum><sync-rootid>0</sync-rootid><sync-itemtype>0</sync-itemtype><sync-timestamp>12/3 / Text5: 0/2004 1:12:53 PM</sync-timestamp><sync-itemid>611</sync-itemid><sync-prioritymapping>0:0-0/1:700-1000/2:300-699/3:1-299</sync-prioritymapping>
- 541: Text3: <sync-guid>{0EBA64A7-C40E-4A8F-BA41-91DBCB5BA571}</sync-guid><sync-parentguid>{4ACF3A3D-37FB-42F6-90DB-920A0B75F72F}</sync-parentguid><sync-checksum>-1434486954</sync-checksum><sync-rootid>0</sync-rootid><sync-itemtype>0</sync-itemtype><sync-timestamp>12 / Text5: 30/2004 1:12:53 PM</sync-timestamp><sync-itemid>1172</sync-itemid><sync-prioritymapping>0:0-0/1:700-1000/2:300-699/3:1-299</sync-prioritymapping>
- 542: Text3: <sync-guid>{3FD26125-CB0D-4FFB-B431-7153D8F300ED}</sync-guid><sync-parentguid>{4ACF3A3D-37FB-42F6-90DB-920A0B75F72F}</sync-parentguid><sync-checksum>1952859228</sync-checksum><sync-rootid>0</sync-rootid><sync-itemtype>0</sync-itemtype><sync-timestamp>12/3 / Text5: 0/2004 1:12:53 PM</sync-timestamp><sync-itemid>1171</sync-itemid><sync-prioritymapping>0:0-0/1:700-1000/2:300-699/3:1-299</sync-prioritymapping>
- 543: Text3: <sync-guid>{DE1D41B6-69B0-4EA9-A852-ABBE17AF4AE4}</sync-guid><sync-parentguid>{B572D7F3-0630-41BE-A63B-C425E92F4460}</sync-parentguid><sync-checksum>-1538201947</sync-checksum><sync-rootid>0</sync-rootid><sync-itemtype>0</sync-itemtype><sync-timestamp>12 / Text5: 30/2004 1:12:54 PM</sync-timestamp><sync-itemid>311</sync-itemid><sync-prioritymapping>0:0-0/1:700-1000/2:300-699/3:1-299</sync-prioritymapping>
- 544: Text3: <sync-guid>{2085DA50-C71E-4805-8A09-97B85865F841}</sync-guid><sync-parentguid>{DE1D41B6-69B0-4EA9-A852-ABBE17AF4AE4}</sync-parentguid><sync-checksum>-1908966778</sync-checksum><sync-rootid>0</sync-rootid><sync-itemtype>0</sync-itemtype><sync-timestamp>12 / Text5: 30/2004 1:12:54 PM</sync-timestamp><sync-itemid>1167</sync-itemid><sync-prioritymapping>0:0-0/1:700-1000/2:300-699/3:1-299</sync-prioritymapping>
- 545: Text3: <sync-guid>{6D8A83B4-0DD4-471D-917D-1FA97FEEC87A}</sync-guid><sync-parentguid>{DE1D41B6-69B0-4EA9-A852-ABBE17AF4AE4}</sync-parentguid><sync-checksum>-1031323094</sync-checksum><sync-rootid>0</sync-rootid><sync-itemtype>0</sync-itemtype><sync-timestamp>12 / Text5: 30/2004 1:12:54 PM</sync-timestamp><sync-itemid>1166</sync-itemid><sync-prioritymapping>0:0-0/1:700-1000/2:300-699/3:1-299</sync-prioritymapping>
- 546: Text3: <sync-guid>{830A09A8-C4AC-4D03-8F6F-FB770FF2846C}</sync-guid><sync-parentguid>{DE1D41B6-69B0-4EA9-A852-ABBE17AF4AE4}</sync-parentguid><sync-checksum>756260516</sync-checksum><sync-rootid>0</sync-rootid><sync-itemtype>0</sync-itemtype><sync-timestamp>12/30 / Text5: 2004 1:12:54 PM</sync-timestamp><sync-itemid>1165</sync-itemid><sync-prioritymapping>0:0-0/1:700-1000/2:300-699/3:1-299</sync-prioritymapping>
- 547: Text3: <sync-guid>{6F9CE0B1-925C-4E03-9DF3-570846E23E89}</sync-guid><sync-parentguid>{DE1D41B6-69B0-4EA9-A852-ABBE17AF4AE4}</sync-parentguid><sync-checksum>-1544795027</sync-checksum><sync-rootid>0</sync-rootid><sync-itemtype>0</sync-itemtype><sync-timestamp>12 / Text5: 30/2004 1:12:54 PM</sync-timestamp><sync-itemid>1164</sync-itemid><sync-prioritymapping>0:0-0/1:700-1000/2:300-699/3:1-299</sync-prioritymapping>
- 548: Text3: <sync-guid>{5FECDB87-5922-4D53-B51B-7C9E52587BDF}</sync-guid><sync-parentguid>{B572D7F3-0630-41BE-A63B-C425E92F4460}</sync-parentguid><sync-checksum>1141014745</sync-checksum><sync-rootid>0</sync-rootid><sync-itemtype>0</sync-itemtype><sync-timestamp>12/3 / Text5: 0/2004 1:12:55 PM</sync-timestamp><sync-itemid>610</sync-itemid><sync-prioritymapping>0:0-0/1:700-1000/2:300-699/3:1-299</sync-prioritymapping>
- 549: Text3: <sync-guid>{E59AB2FE-C901-4975-8F7E-0925FD7206EF}</sync-guid><sync-parentguid>{5FECDB87-5922-4D53-B51B-7C9E52587BDF}</sync-parentguid><sync-checksum>436904143</sync-checksum><sync-rootid>0</sync-rootid><sync-itemtype>0</sync-itemtype><sync-timestamp>12/30 / Text5: 2004 1:12:54 PM</sync-timestamp><sync-itemid>1161</sync-itemid><sync-prioritymapping>0:0-0/1:700-1000/2:300-699/3:1-299</sync-prioritymapping>
- 550: Text3: <sync-guid>{C1F1BA18-CB9C-4128-9ACE-ACD4BFFBADC6}</sync-guid><sync-parentguid>{5FECDB87-5922-4D53-B51B-7C9E52587BDF}</sync-parentguid><sync-checksum>-974100173</sync-checksum><sync-rootid>0</sync-rootid><sync-itemtype>0</sync-itemtype><sync-timestamp>12/3 / Text5: 0/2004 1:12:55 PM</sync-timestamp><sync-itemid>1160</sync-itemid><sync-prioritymapping>0:0-0/1:700-1000/2:300-699/3:1-299</sync-prioritymapping>
- 551: Text3: <sync-guid>{46E5C11D-9F15-41DC-88A3-E6D067DFF289}</sync-guid><sync-parentguid>{5FECDB87-5922-4D53-B51B-7C9E52587BDF}</sync-parentguid><sync-checksum>-2075337857</sync-checksum><sync-rootid>0</sync-rootid><sync-itemtype>0</sync-itemtype><sync-timestamp>12 / Text5: 30/2004 1:12:55 PM</sync-timestamp><sync-itemid>1163</sync-itemid><sync-prioritymapping>0:0-0/1:700-1000/2:300-699/3:1-299</sync-prioritymapping>
- 552: Text3: <sync-guid>{FF25CB52-61BB-4EF8-A7AF-6CFB22683730}</sync-guid><sync-parentguid>{5FECDB87-5922-4D53-B51B-7C9E52587BDF}</sync-parentguid><sync-checksum>-2000112732</sync-checksum><sync-rootid>0</sync-rootid><sync-itemtype>0</sync-itemtype><sync-timestamp>12 / Text5: 30/2004 1:12:55 PM</sync-timestamp><sync-itemid>1162</sync-itemid><sync-prioritymapping>0:0-0/1:700-1000/2:300-699/3:1-299</sync-prioritymapping>
- 553: Text3: <sync-guid>{CED5E167-735F-40DE-A294-DEF36EC1AF48}</sync-guid><sync-parentguid>{B572D7F3-0630-41BE-A63B-C425E92F4460}</sync-parentguid><sync-checksum>-1237601336</sync-checksum><sync-rootid>0</sync-rootid><sync-itemtype>0</sync-itemtype><sync-timestamp>12 / Text5: 30/2004 1:12:57 PM</sync-timestamp><sync-itemid>312</sync-itemid><sync-prioritymapping>0:0-0/1:700-1000/2:300-699/3:1-299</sync-prioritymapping>
- 554: Text3: <sync-guid>{5C2EDDDB-EA7E-41E5-9B00-4637A6C23D8B}</sync-guid><sync-parentguid>{CED5E167-735F-40DE-A294-DEF36EC1AF48}</sync-parentguid><sync-checksum>-491673480</sync-checksum><sync-rootid>0</sync-rootid><sync-itemtype>0</sync-itemtype><sync-timestamp>12/3 / Text5: 0/2004 1:12:55 PM</sync-timestamp><sync-itemid>937</sync-itemid><sync-prioritymapping>0:0-0/1:700-1000/2:300-699/3:1-299</sync-prioritymapping>
- 555: Text3: <sync-guid>{48D6D1E9-CA72-48E0-A80B-CA09D25245CE}</sync-guid><sync-parentguid>{CED5E167-735F-40DE-A294-DEF36EC1AF48}</sync-parentguid><sync-checksum>-1445115680</sync-checksum><sync-rootid>0</sync-rootid><sync-itemtype>0</sync-itemtype><sync-timestamp>12 / Text5: 30/2004 1:12:55 PM</sync-timestamp><sync-itemid>936</sync-itemid><sync-prioritymapping>0:0-0/1:700-1000/2:300-699/3:1-299</sync-prioritymapping>
- 556: Text3: <sync-guid>{83651683-BD94-44AB-AE97-17A990DB5A38}</sync-guid><sync-parentguid>{CED5E167-735F-40DE-A294-DEF36EC1AF48}</sync-parentguid><sync-checksum>-557707945</sync-checksum><sync-rootid>0</sync-rootid><sync-itemtype>0</sync-itemtype><sync-timestamp>12/3 / Text5: 0/2004 1:12:55 PM</sync-timestamp><sync-itemid>935</sync-itemid><sync-prioritymapping>0:0-0/1:700-1000/2:300-699/3:1-299</sync-prioritymapping>
- 557: Text3: <sync-guid>{6B713AD7-0E96-46BD-A7A0-D4BD57768E0A}</sync-guid><sync-parentguid>{CED5E167-735F-40DE-A294-DEF36EC1AF48}</sync-parentguid><sync-checksum>1814380795</sync-checksum><sync-rootid>0</sync-rootid><sync-itemtype>0</sync-itemtype><sync-timestamp>12/3 / Text5: 0/2004 1:12:56 PM</sync-timestamp><sync-itemid>934</sync-itemid><sync-prioritymapping>0:0-0/1:700-1000/2:300-699/3:1-299</sync-prioritymapping>
- 558: Text3: <sync-guid>{DD274536-CDB9-4141-9565-70295940B114}</sync-guid><sync-parentguid>{CED5E167-735F-40DE-A294-DEF36EC1AF48}</sync-parentguid><sync-checksum>69784451</sync-checksum><sync-rootid>0</sync-rootid><sync-itemtype>0</sync-itemtype><sync-timestamp>12/30 / Text5: 2004 1:12:56 PM</sync-timestamp><sync-itemid>933</sync-itemid><sync-prioritymapping>0:0-0/1:700-1000/2:300-699/3:1-299</sync-prioritymapping>
- 559: Text3: <sync-guid>{995C0421-0163-4979-B89C-D61D4713808E}</sync-guid><sync-parentguid>{CED5E167-735F-40DE-A294-DEF36EC1AF48}</sync-parentguid><sync-checksum>-1142925545</sync-checksum><sync-rootid>0</sync-rootid><sync-itemtype>0</sync-itemtype><sync-timestamp>12 / Text5: 30/2004 1:12:56 PM</sync-timestamp><sync-itemid>932</sync-itemid><sync-prioritymapping>0:0-0/1:700-1000/2:300-699/3:1-299</sync-prioritymapping>
- 560: Text3: <sync-guid>{558EA645-CF15-4A65-A132-851DE20AFA2E}</sync-guid><sync-parentguid>{CED5E167-735F-40DE-A294-DEF36EC1AF48}</sync-parentguid><sync-checksum>-999812006</sync-checksum><sync-rootid>0</sync-rootid><sync-itemtype>0</sync-itemtype><sync-timestamp>12/3 / Text5: 0/2004 1:12:56 PM</sync-timestamp><sync-itemid>931</sync-itemid><sync-prioritymapping>0:0-0/1:700-1000/2:300-699/3:1-299</sync-prioritymapping>
- 561: Text3: <sync-guid>{4FFE3286-B231-485B-8822-BE81425BC037}</sync-guid><sync-parentguid>{CED5E167-735F-40DE-A294-DEF36EC1AF48}</sync-parentguid><sync-checksum>1849791581</sync-checksum><sync-rootid>0</sync-rootid><sync-itemtype>0</sync-itemtype><sync-timestamp>12/3 / Text5: 0/2004 1:12:56 PM</sync-timestamp><sync-itemid>930</sync-itemid><sync-prioritymapping>0:0-0/1:700-1000/2:300-699/3:1-299</sync-prioritymapping>
- 562: Text3: <sync-guid>{E5D49573-A3F9-42B1-8F3C-B2C5E58BA323}</sync-guid><sync-parentguid>{CED5E167-735F-40DE-A294-DEF36EC1AF48}</sync-parentguid><sync-checksum>-532777150</sync-checksum><sync-rootid>0</sync-rootid><sync-itemtype>0</sync-itemtype><sync-timestamp>12/3 / Text5: 0/2004 1:12:56 PM</sync-timestamp><sync-itemid>929</sync-itemid><sync-prioritymapping>0:0-0/1:700-1000/2:300-699/3:1-299</sync-prioritymapping>
- 563: Text3: <sync-guid>{977456EB-216F-48AD-8898-95701D7A8E80}</sync-guid><sync-parentguid>{CED5E167-735F-40DE-A294-DEF36EC1AF48}</sync-parentguid><sync-checksum>352019008</sync-checksum><sync-rootid>0</sync-rootid><sync-itemtype>0</sync-itemtype><sync-timestamp>12/30 / Text5: 2004 1:12:57 PM</sync-timestamp><sync-itemid>928</sync-itemid><sync-prioritymapping>0:0-0/1:700-1000/2:300-699/3:1-299</sync-prioritymapping>

| ID | WBS | Task | Type | Duration | Start | Finish | Predecessors | Baseline start | Baseline finish | Baseline duration | Total slack | Free slack | Text4 |
| --- | --- | --- | --- | --- | --- | --- | --- | --- | --- | --- | --- | --- | --- |
| 564 | 6.5.5 | **Conduct regression testing** |  | 13d | 2005-06-10 | 2005-06-29 | 548 | 2005-06-10 | 2005-06-29 | 13d | 39.5d |  | {AF8AF87F-C26C-4E6B-B5BD-C452D2024B55} |
| 565 | 6.5.5.1 | Confirm regression test plans |  | 1d | 2005-06-10 | 2005-06-13 |  | 2005-06-10 | 2005-06-13 | 1d | 39.5d | 0d | {F5F13616-23F8-4DE4-AAB3-31BCFEC68665} |
| 566 | 6.5.5.2 | Finalize regression test scripts |  | 1d | 2005-06-13 | 2005-06-14 | 565 | 2005-06-13 | 2005-06-14 | 1d | 39.5d | 0d | {A217D6ED-4B90-4ABD-B50F-F499F6768152} |
| 567 | 6.5.5.3 | Finalize regression test data |  | 1d | 2005-06-14 | 2005-06-15 | 566 | 2005-06-14 | 2005-06-15 | 1d | 39.5d | 0d | {DB1A96C2-BB8D-492E-BA7A-1862CCBEBBD2} |
| 568 | 6.5.5.4 | Conduct regression tests |  | 3d | 2005-06-15 | 2005-06-20 | 567 | 2005-06-15 | 2005-06-20 | 3d | 39.5d | 0d | {268437AE-C0C3-4CF0-8D4B-0A86541D20D4} |
| 569 | 6.5.5.5 | Monitor & correct defects |  | 4d | 2005-06-15 | 2005-06-21 | 568SS | 2005-06-15 | 2005-06-21 | 4d | 39.5d | 0d | {EB096FFE-B67D-4873-A1F4-E1833F9195E5} |
| 570 | 6.5.5.6 | Prepare regression test report |  | 1d | 2005-06-21 | 2005-06-22 | 569 | 2005-06-21 | 2005-06-22 | 1d | 39.5d | 0d | {0F287D56-CCC9-4F56-8FD0-9C7AC4D9FA0D} |
| 571 | 6.5.5.7 | Review regression test results |  | 1d | 2005-06-22 | 2005-06-23 | 570 | 2005-06-22 | 2005-06-23 | 1d | 39.5d | 0d | {6BF2832D-D214-4182-84CB-4318618CDF81} |
| 572 | 6.5.5.8 | Revise & rerun identified tests |  | 2d | 2005-06-23 | 2005-06-27 | 571 | 2005-06-23 | 2005-06-27 | 2d | 39.5d | 0d | {F5489C97-ED20-45C5-B599-2DA6E1899BD0} |
| 573 | 6.5.5.9 | Finalize regression test results |  | 1d | 2005-06-27 | 2005-06-28 | 572 | 2005-06-27 | 2005-06-28 | 1d | 39.5d | 0d | {14E647BD-3E8F-4C3C-97E7-456A5D43C54D} |
| 574 | 6.5.5.10 | Approve regression test results |  | 1d | 2005-06-28 | 2005-06-29 | 573 | 2005-06-28 | 2005-06-29 | 1d | 39.5d |  | {E56CCFF6-76E4-4EA9-9643-889A6133C834} |
| 575 | 6.5.6 | **Finalize implementation** |  | 5d | 2005-06-08 | 2005-06-15 | 563 | 2005-06-08 | 2005-06-15 | 5d | 46.5d | 20.5d | {905944E9-D015-4853-9041-B2E6E8BEA9EF} |
| 576 | 6.5.6.1 | Consolidate testing results |  | 1d | 2005-06-08 | 2005-06-09 |  | 2005-06-08 | 2005-06-09 | 1d | 46.5d | 0d | {47246C99-7173-4685-B9DE-FC67311496DB} |
| 577 | 6.5.6.2 | Consolidate process step approvals |  | 1d | 2005-06-08 | 2005-06-09 |  | 2005-06-08 | 2005-06-09 | 1d | 46.5d | 0d | {95B981BE-F76D-4CFC-B894-8D42B74EC01F} |
| 578 | 6.5.6.3 | Build defect Pareto |  | 1d | 2005-06-08 | 2005-06-09 |  | 2005-06-08 | 2005-06-09 | 1d | 46.5d | 0d | {F5E1EFC7-708C-49CE-BDD1-F773DD874500} |
| 579 | 6.5.6.4 | Build issues Pareto |  | 1d | 2005-06-08 | 2005-06-09 |  | 2005-06-08 | 2005-06-09 | 1d | 46.5d | 0d | {CD9B59C3-20EF-48EC-8232-907FAA8E00E9} |
| 580 | 6.5.6.5 | Update risk assessment |  | 1d | 2005-06-08 | 2005-06-09 |  | 2005-06-08 | 2005-06-09 | 1d | 46.5d | 0d | {8BF80EE7-FC7D-4237-B935-25378B252116} |
| 581 | 6.5.6.6 | Conduct implementation peer review |  | 1d | 2005-06-09 | 2005-06-10 | 576, 577, 578, 579, 580 | 2005-06-09 | 2005-06-10 | 1d | 46.5d | 0d | {0CE5B580-8D60-448E-8641-9AF40411EC17} |
| 582 | 6.5.6.7 | Finalize implementation punch list |  | 1d | 2005-06-10 | 2005-06-13 | 581 | 2005-06-10 | 2005-06-13 | 1d | 46.5d | 0d | {866D2A78-C709-4B21-882F-201EDB5558A3} |
| 583 | 6.5.6.8 | Conduct customer implementation review |  | 1d | 2005-06-13 | 2005-06-14 | 582 | 2005-06-13 | 2005-06-14 | 1d | 46.5d | 0d | {79AB8128-8A62-46EC-AABB-65DB4DCA2873} |
| 584 | 6.5.6.9 | Document agreed closeout plan |  | 1d | 2005-06-14 | 2005-06-15 | 583 | 2005-06-14 | 2005-06-15 | 1d | 46.5d | 0d | {70C0CF38-E228-4F95-935E-EDDE1311597B} |
| 585 | 6.5.6.10 | Approve final implementation | milestone | 0d | 2005-06-15 | 2005-06-15 | 584 | 2005-06-15 | 2005-06-15 | 0d | 46.5d |  | {9E2B9009-C64B-42AA-A135-2C0DDB59B03C} |
| 586 | 6.5.7 | **Conduct phase QA assessment** |  | 2d | 2005-06-09 | 2005-06-13 | 576 | 2005-06-09 | 2005-06-13 | 2d | 49d |  | {D8CE74FC-B81B-4DA1-B427-5CC8E6FE6E7B} |
| 587 | 6.5.7.1 | Consolidate phase results |  | 0.5d | 2005-06-09 | 2005-06-09 |  | 2005-06-09 | 2005-06-09 | 0.5d | 49d | 0d | {788CC470-38D2-4FDA-A7FE-4B4335BC0B23} |
| 588 | 6.5.7.2 | Conduct phase self-assessment |  | 0.25d | 2005-06-10 | 2005-06-10 | 587 | 2005-06-10 | 2005-06-10 | 0.25d | 49d | 0d | {20F08743-AFC6-4A3D-9FA6-AB2CE27C81AE} |
| 589 | 6.5.7.3 | Conduct QA assessment |  | 0.5d | 2005-06-10 | 2005-06-10 | 588 | 2005-06-10 | 2005-06-10 | 0.5d | 49d | 0d | {E8B50133-219D-4908-94A6-52169AD4E4E2} |
| 590 | 6.5.7.4 | Review assessment feedback |  | 0.25d | 2005-06-10 | 2005-06-10 | 589 | 2005-06-10 | 2005-06-10 | 0.25d | 49d | 0d | {401866AF-E88E-41FA-B0E4-36653CEEB150} |
| 591 | 6.5.7.5 | Implement QA feedback |  | 0.5d | 2005-06-13 | 2005-06-13 | 590 | 2005-06-13 | 2005-06-13 | 0.5d | 49d | 0d | {1FFF58BD-5B56-4597-A705-94AD3DA51193} |

Notes:
- 564: Text3: <sync-guid>{AF8AF87F-C26C-4E6B-B5BD-C452D2024B55}</sync-guid><sync-parentguid>{B572D7F3-0630-41BE-A63B-C425E92F4460}</sync-parentguid><sync-checksum>75453221</sync-checksum><sync-rootid>0</sync-rootid><sync-itemtype>0</sync-itemtype><sync-timestamp>12/30 / Text5: 2004 1:12:58 PM</sync-timestamp><sync-itemid>1057</sync-itemid><sync-prioritymapping>0:0-0/1:700-1000/2:300-699/3:1-299</sync-prioritymapping>
- 565: Text3: <sync-guid>{F5F13616-23F8-4DE4-AAB3-31BCFEC68665}</sync-guid><sync-parentguid>{AF8AF87F-C26C-4E6B-B5BD-C452D2024B55}</sync-parentguid><sync-checksum>-595938679</sync-checksum><sync-rootid>0</sync-rootid><sync-itemtype>0</sync-itemtype><sync-timestamp>12/3 / Text5: 0/2004 1:12:57 PM</sync-timestamp><sync-itemid>1056</sync-itemid><sync-prioritymapping>0:0-0/1:700-1000/2:300-699/3:1-299</sync-prioritymapping>
- 566: Text3: <sync-guid>{A217D6ED-4B90-4ABD-B50F-F499F6768152}</sync-guid><sync-parentguid>{AF8AF87F-C26C-4E6B-B5BD-C452D2024B55}</sync-parentguid><sync-checksum>-1606627018</sync-checksum><sync-rootid>0</sync-rootid><sync-itemtype>0</sync-itemtype><sync-timestamp>12 / Text5: 30/2004 1:12:57 PM</sync-timestamp><sync-itemid>1055</sync-itemid><sync-prioritymapping>0:0-0/1:700-1000/2:300-699/3:1-299</sync-prioritymapping>
- 567: Text3: <sync-guid>{DB1A96C2-BB8D-492E-BA7A-1862CCBEBBD2}</sync-guid><sync-parentguid>{AF8AF87F-C26C-4E6B-B5BD-C452D2024B55}</sync-parentguid><sync-checksum>250238855</sync-checksum><sync-rootid>0</sync-rootid><sync-itemtype>0</sync-itemtype><sync-timestamp>12/30 / Text5: 2004 1:12:57 PM</sync-timestamp><sync-itemid>1054</sync-itemid><sync-prioritymapping>0:0-0/1:700-1000/2:300-699/3:1-299</sync-prioritymapping>
- 568: Text3: <sync-guid>{268437AE-C0C3-4CF0-8D4B-0A86541D20D4}</sync-guid><sync-parentguid>{AF8AF87F-C26C-4E6B-B5BD-C452D2024B55}</sync-parentguid><sync-checksum>376908664</sync-checksum><sync-rootid>0</sync-rootid><sync-itemtype>0</sync-itemtype><sync-timestamp>12/30 / Text5: 2004 1:12:57 PM</sync-timestamp><sync-itemid>1053</sync-itemid><sync-prioritymapping>0:0-0/1:700-1000/2:300-699/3:1-299</sync-prioritymapping>
- 569: Text3: <sync-guid>{EB096FFE-B67D-4873-A1F4-E1833F9195E5}</sync-guid><sync-parentguid>{AF8AF87F-C26C-4E6B-B5BD-C452D2024B55}</sync-parentguid><sync-checksum>-1695842531</sync-checksum><sync-rootid>0</sync-rootid><sync-itemtype>0</sync-itemtype><sync-timestamp>12 / Text5: 30/2004 1:12:57 PM</sync-timestamp><sync-itemid>1052</sync-itemid><sync-prioritymapping>0:0-0/1:700-1000/2:300-699/3:1-299</sync-prioritymapping>
- 570: Text3: <sync-guid>{0F287D56-CCC9-4F56-8FD0-9C7AC4D9FA0D}</sync-guid><sync-parentguid>{AF8AF87F-C26C-4E6B-B5BD-C452D2024B55}</sync-parentguid><sync-checksum>1817645043</sync-checksum><sync-rootid>0</sync-rootid><sync-itemtype>0</sync-itemtype><sync-timestamp>12/3 / Text5: 0/2004 1:12:58 PM</sync-timestamp><sync-itemid>1051</sync-itemid><sync-prioritymapping>0:0-0/1:700-1000/2:300-699/3:1-299</sync-prioritymapping>
- 571: Text3: <sync-guid>{6BF2832D-D214-4182-84CB-4318618CDF81}</sync-guid><sync-parentguid>{AF8AF87F-C26C-4E6B-B5BD-C452D2024B55}</sync-parentguid><sync-checksum>999717626</sync-checksum><sync-rootid>0</sync-rootid><sync-itemtype>0</sync-itemtype><sync-timestamp>12/30 / Text5: 2004 1:12:58 PM</sync-timestamp><sync-itemid>1050</sync-itemid><sync-prioritymapping>0:0-0/1:700-1000/2:300-699/3:1-299</sync-prioritymapping>
- 572: Text3: <sync-guid>{F5489C97-ED20-45C5-B599-2DA6E1899BD0}</sync-guid><sync-parentguid>{AF8AF87F-C26C-4E6B-B5BD-C452D2024B55}</sync-parentguid><sync-checksum>337336130</sync-checksum><sync-rootid>0</sync-rootid><sync-itemtype>0</sync-itemtype><sync-timestamp>12/30 / Text5: 2004 1:12:58 PM</sync-timestamp><sync-itemid>1049</sync-itemid><sync-prioritymapping>0:0-0/1:700-1000/2:300-699/3:1-299</sync-prioritymapping>
- 573: Text3: <sync-guid>{14E647BD-3E8F-4C3C-97E7-456A5D43C54D}</sync-guid><sync-parentguid>{AF8AF87F-C26C-4E6B-B5BD-C452D2024B55}</sync-parentguid><sync-checksum>1010809968</sync-checksum><sync-rootid>0</sync-rootid><sync-itemtype>0</sync-itemtype><sync-timestamp>12/3 / Text5: 0/2004 1:12:58 PM</sync-timestamp><sync-itemid>1048</sync-itemid><sync-prioritymapping>0:0-0/1:700-1000/2:300-699/3:1-299</sync-prioritymapping>
- 574: Text3: <sync-guid>{E56CCFF6-76E4-4EA9-9643-889A6133C834}</sync-guid><sync-parentguid>{AF8AF87F-C26C-4E6B-B5BD-C452D2024B55}</sync-parentguid><sync-checksum>942878987</sync-checksum><sync-rootid>0</sync-rootid><sync-itemtype>0</sync-itemtype><sync-timestamp>12/30 / Text5: 2004 1:12:58 PM</sync-timestamp><sync-itemid>1047</sync-itemid><sync-prioritymapping>0:0-0/1:700-1000/2:300-699/3:1-299</sync-prioritymapping>
- 575: Text3: <sync-guid>{905944E9-D015-4853-9041-B2E6E8BEA9EF}</sync-guid><sync-parentguid>{B572D7F3-0630-41BE-A63B-C425E92F4460}</sync-parentguid><sync-checksum>-2011242141</sync-checksum><sync-rootid>0</sync-rootid><sync-itemtype>0</sync-itemtype><sync-timestamp>12 / Text5: 30/2004 1:13:00 PM</sync-timestamp><sync-itemid>313</sync-itemid><sync-prioritymapping>0:0-0/1:700-1000/2:300-699/3:1-299</sync-prioritymapping>
- 576: Text3: <sync-guid>{47246C99-7173-4685-B9DE-FC67311496DB}</sync-guid><sync-parentguid>{905944E9-D015-4853-9041-B2E6E8BEA9EF}</sync-parentguid><sync-checksum>-1771469144</sync-checksum><sync-rootid>0</sync-rootid><sync-itemtype>0</sync-itemtype><sync-timestamp>12 / Text5: 30/2004 1:12:59 PM</sync-timestamp><sync-itemid>972</sync-itemid><sync-prioritymapping>0:0-0/1:700-1000/2:300-699/3:1-299</sync-prioritymapping>
- 577: Text3: <sync-guid>{95B981BE-F76D-4CFC-B894-8D42B74EC01F}</sync-guid><sync-parentguid>{905944E9-D015-4853-9041-B2E6E8BEA9EF}</sync-parentguid><sync-checksum>626251667</sync-checksum><sync-rootid>0</sync-rootid><sync-itemtype>0</sync-itemtype><sync-timestamp>12/30 / Text5: 2004 1:12:59 PM</sync-timestamp><sync-itemid>971</sync-itemid><sync-prioritymapping>0:0-0/1:700-1000/2:300-699/3:1-299</sync-prioritymapping>
- 578: Text3: <sync-guid>{F5E1EFC7-708C-49CE-BDD1-F773DD874500}</sync-guid><sync-parentguid>{905944E9-D015-4853-9041-B2E6E8BEA9EF}</sync-parentguid><sync-checksum>-1600041466</sync-checksum><sync-rootid>0</sync-rootid><sync-itemtype>0</sync-itemtype><sync-timestamp>12 / Text5: 30/2004 1:12:59 PM</sync-timestamp><sync-itemid>974</sync-itemid><sync-prioritymapping>0:0-0/1:700-1000/2:300-699/3:1-299</sync-prioritymapping>
- 579: Text3: <sync-guid>{CD9B59C3-20EF-48EC-8232-907FAA8E00E9}</sync-guid><sync-parentguid>{905944E9-D015-4853-9041-B2E6E8BEA9EF}</sync-parentguid><sync-checksum>-1895953803</sync-checksum><sync-rootid>0</sync-rootid><sync-itemtype>0</sync-itemtype><sync-timestamp>12 / Text5: 30/2004 1:12:59 PM</sync-timestamp><sync-itemid>973</sync-itemid><sync-prioritymapping>0:0-0/1:700-1000/2:300-699/3:1-299</sync-prioritymapping>
- 580: Text3: <sync-guid>{8BF80EE7-FC7D-4237-B935-25378B252116}</sync-guid><sync-parentguid>{905944E9-D015-4853-9041-B2E6E8BEA9EF}</sync-parentguid><sync-checksum>-2031393085</sync-checksum><sync-rootid>0</sync-rootid><sync-itemtype>0</sync-itemtype><sync-timestamp>12 / Text5: 30/2004 1:12:59 PM</sync-timestamp><sync-itemid>970</sync-itemid><sync-prioritymapping>0:0-0/1:700-1000/2:300-699/3:1-299</sync-prioritymapping>
- 581: Text3: <sync-guid>{0CE5B580-8D60-448E-8641-9AF40411EC17}</sync-guid><sync-parentguid>{905944E9-D015-4853-9041-B2E6E8BEA9EF}</sync-parentguid><sync-checksum>-748389548</sync-checksum><sync-rootid>0</sync-rootid><sync-itemtype>0</sync-itemtype><sync-timestamp>12/3 / Text5: 0/2004 1:12:59 PM</sync-timestamp><sync-itemid>978</sync-itemid><sync-prioritymapping>0:0-0/1:700-1000/2:300-699/3:1-299</sync-prioritymapping>
- 582: Text3: <sync-guid>{866D2A78-C709-4B21-882F-201EDB5558A3}</sync-guid><sync-parentguid>{905944E9-D015-4853-9041-B2E6E8BEA9EF}</sync-parentguid><sync-checksum>208706315</sync-checksum><sync-rootid>0</sync-rootid><sync-itemtype>0</sync-itemtype><sync-timestamp>12/30 / Text5: 2004 1:13:00 PM</sync-timestamp><sync-itemid>977</sync-itemid><sync-prioritymapping>0:0-0/1:700-1000/2:300-699/3:1-299</sync-prioritymapping>
- 583: Text3: <sync-guid>{79AB8128-8A62-46EC-AABB-65DB4DCA2873}</sync-guid><sync-parentguid>{905944E9-D015-4853-9041-B2E6E8BEA9EF}</sync-parentguid><sync-checksum>175198179</sync-checksum><sync-rootid>0</sync-rootid><sync-itemtype>0</sync-itemtype><sync-timestamp>12/30 / Text5: 2004 1:13:00 PM</sync-timestamp><sync-itemid>979</sync-itemid><sync-prioritymapping>0:0-0/1:700-1000/2:300-699/3:1-299</sync-prioritymapping>
- 584: Text3: <sync-guid>{70C0CF38-E228-4F95-935E-EDDE1311597B}</sync-guid><sync-parentguid>{905944E9-D015-4853-9041-B2E6E8BEA9EF}</sync-parentguid><sync-checksum>1852407345</sync-checksum><sync-rootid>0</sync-rootid><sync-itemtype>0</sync-itemtype><sync-timestamp>12/3 / Text5: 0/2004 1:13:00 PM</sync-timestamp><sync-itemid>980</sync-itemid><sync-prioritymapping>0:0-0/1:700-1000/2:300-699/3:1-299</sync-prioritymapping>
- 585: Text3: <sync-guid>{9E2B9009-C64B-42AA-A135-2C0DDB59B03C}</sync-guid><sync-parentguid>{905944E9-D015-4853-9041-B2E6E8BEA9EF}</sync-parentguid><sync-checksum>-1766280922</sync-checksum><sync-rootid>0</sync-rootid><sync-itemtype>0</sync-itemtype><sync-timestamp>12 / Text5: 30/2004 1:13:00 PM</sync-timestamp><sync-itemid>976</sync-itemid><sync-prioritymapping>0:0-0/1:700-1000/2:300-699/3:1-299</sync-prioritymapping>
- 586: Text3: <sync-guid>{D8CE74FC-B81B-4DA1-B427-5CC8E6FE6E7B}</sync-guid><sync-parentguid>{B572D7F3-0630-41BE-A63B-C425E92F4460}</sync-parentguid><sync-checksum>291717699</sync-checksum><sync-rootid>0</sync-rootid><sync-itemtype>0</sync-itemtype><sync-timestamp>12/30 / Text5: 2004 1:13:01 PM</sync-timestamp><sync-itemid>373</sync-itemid><sync-prioritymapping>0:0-0/1:700-1000/2:300-699/3:1-299</sync-prioritymapping>
- 587: Text3: <sync-guid>{788CC470-38D2-4FDA-A7FE-4B4335BC0B23}</sync-guid><sync-parentguid>{D8CE74FC-B81B-4DA1-B427-5CC8E6FE6E7B}</sync-parentguid><sync-checksum>390884054</sync-checksum><sync-rootid>0</sync-rootid><sync-itemtype>0</sync-itemtype><sync-timestamp>12/30 / Text5: 2004 1:13:00 PM</sync-timestamp><sync-itemid>1108</sync-itemid><sync-prioritymapping>0:0-0/1:700-1000/2:300-699/3:1-299</sync-prioritymapping>
- 588: Text3: <sync-guid>{20F08743-AFC6-4A3D-9FA6-AB2CE27C81AE}</sync-guid><sync-parentguid>{D8CE74FC-B81B-4DA1-B427-5CC8E6FE6E7B}</sync-parentguid><sync-checksum>-524612527</sync-checksum><sync-rootid>0</sync-rootid><sync-itemtype>0</sync-itemtype><sync-timestamp>12/3 / Text5: 0/2004 1:13:01 PM</sync-timestamp><sync-itemid>1107</sync-itemid><sync-prioritymapping>0:0-0/1:700-1000/2:300-699/3:1-299</sync-prioritymapping>
- 589: Text3: <sync-guid>{E8B50133-219D-4908-94A6-52169AD4E4E2}</sync-guid><sync-parentguid>{D8CE74FC-B81B-4DA1-B427-5CC8E6FE6E7B}</sync-parentguid><sync-checksum>2106634839</sync-checksum><sync-rootid>0</sync-rootid><sync-itemtype>0</sync-itemtype><sync-timestamp>12/3 / Text5: 0/2004 1:13:01 PM</sync-timestamp><sync-itemid>1106</sync-itemid><sync-prioritymapping>0:0-0/1:700-1000/2:300-699/3:1-299</sync-prioritymapping>
- 590: Text3: <sync-guid>{401866AF-E88E-41FA-B0E4-36653CEEB150}</sync-guid><sync-parentguid>{D8CE74FC-B81B-4DA1-B427-5CC8E6FE6E7B}</sync-parentguid><sync-checksum>758964856</sync-checksum><sync-rootid>0</sync-rootid><sync-itemtype>0</sync-itemtype><sync-timestamp>12/30 / Text5: 2004 1:13:01 PM</sync-timestamp><sync-itemid>1105</sync-itemid><sync-prioritymapping>0:0-0/1:700-1000/2:300-699/3:1-299</sync-prioritymapping>
- 591: Text3: <sync-guid>{1FFF58BD-5B56-4597-A705-94AD3DA51193}</sync-guid><sync-parentguid>{D8CE74FC-B81B-4DA1-B427-5CC8E6FE6E7B}</sync-parentguid><sync-checksum>174645232</sync-checksum><sync-rootid>0</sync-rootid><sync-itemtype>0</sync-itemtype><sync-timestamp>12/30 / Text5: 2004 1:13:01 PM</sync-timestamp><sync-itemid>1104</sync-itemid><sync-prioritymapping>0:0-0/1:700-1000/2:300-699/3:1-299</sync-prioritymapping>

| ID | WBS | Task | Type | Duration | Start | Finish | Predecessors | Baseline start | Baseline finish | Baseline duration | Total slack | Free slack | Constraint | Text4 |
| --- | --- | --- | --- | --- | --- | --- | --- | --- | --- | --- | --- | --- | --- | --- |
| 592 | 6.5.8 | **Post-Implementation** |  | 2.5d | 2005-06-13 | 2005-06-15 | 591 | 2005-06-13 | 2005-06-15 | 2.5d | 49d |  |  | {B60551D7-BC89-498B-8C24-616471D3737B} |
| 593 | 6.5.8.1 | Lessons learned |  | 1d | 2005-06-13 | 2005-06-14 |  | 2005-06-13 | 2005-06-14 | 1d | 49d | 0d |  | {9411F628-A22B-430D-AE01-59CE49D2BC1A} |
| 594 | 6.5.8.2 | Follow-on planning |  | 1d | 2005-06-14 | 2005-06-15 | 593 | 2005-06-14 | 2005-06-15 | 1d | 49d | 0d |  | {4F600391-2BD7-4D9C-9007-5E0689E6372F} |
| 595 | 6.5.8.3 | Recognize team members |  | 1d | 2005-06-13 | 2005-06-14 |  | 2005-06-13 | 2005-06-14 | 1d | 50.5d |  |  | {C356DDEA-58B0-4A3A-BD70-854B8CDD77C3} |
| 596 | 6.5.8.4 | Archive subproject records |  | 0.5d | 2005-06-15 | 2005-06-15 | 593, 594 | 2005-06-15 | 2005-06-15 | 0.5d | 49d | 0d |  | {9D4343B0-644C-4EF4-8F46-2152F7853CFA} |
| 597 | 6.5.8.5 | Subproject shut-down | milestone | 0d | 2005-06-15 | 2005-06-15 | 594, 596 | 2005-06-15 | 2005-06-15 | 0d | 49d |  |  | {CAA64EEC-8C43-41BB-BD69-85BD1B9C6308} |
| 598 | 7 | **Project Administration** |  | 166d | 2005-01-03 | 2005-08-22 |  | 2005-01-03 | 2005-08-22 | 166d | 1d |  |  | {9E55DC8E-FCA4-4D95-BBCF-9F2DDD4601DA} |
| 599 | 7.1 | **Project Startup** |  | 3d | 2005-01-03 | 2005-01-05 |  | 2005-01-03 | 2005-01-05 | 3d | 163d | 0d |  | {E11E90AB-D4F8-4519-B28E-0A612553867B} |
| 600 | 7.1.1 | Initialize project control files | milestone | 0d | 2005-01-03 | 2005-01-03 |  | 2005-01-03 | 2005-01-03 | 0d | 163d | 0d |  | {EC86F6D2-76F8-4A37-8ACF-E8D50C117ADC} |
| 601 | 7.1.2 | Initialize risk management logs |  | 3d | 2005-01-03 | 2005-01-05 | 600 | 2005-01-03 | 2005-01-05 | 3d | 163d |  |  | {BAF91F3A-5443-4ABA-BC57-AF46B2B53BA0} |
| 602 | 7.1.3 | Initialize issue management logs |  | 3d | 2005-01-03 | 2005-01-05 | 600 | 2005-01-03 | 2005-01-05 | 3d | 163d |  |  | {C29C04A7-4CF1-4EC2-ADB9-36290453737F} |
| 603 | 7.1.4 | Initialize defect logs |  | 1d | 2005-01-03 | 2005-01-03 | 600 | 2005-01-03 | 2005-01-03 | 1d | 165d |  |  | {D56B3CB6-771E-4D5D-907D-9B907C6A15B2} |
| 604 | 7.1.5 | Initialize change log |  | 1d | 2005-01-03 | 2005-01-03 | 600 | 2005-01-03 | 2005-01-03 | 1d | 165d |  |  | {8B3D79D4-8C75-4B66-9355-5D52ECF1F42E} |
| 605 | 7.2 | **Project Execution** |  | 163d | 2005-01-06 | 2005-08-22 | 599 | 2005-01-06 | 2005-08-22 | 163d | 1d | 0d |  | {55A6A8DD-D0E3-4E39-AE60-4750F7DD10C2} |
| 606 | 7.2.1 | **Maintain risk management logs** |  | 163d | 2005-01-06 | 2005-08-22 |  | 2005-01-06 | 2005-08-22 | 163d | 1d |  |  | {2D0FA5E4-D704-4262-A8D0-656CB6F204A5} |
| 607 | 7.2.1.1 | Maintain risk management logs 1 |  | 1d | 2005-01-06 | 2005-01-06 |  | 2005-01-06 | 2005-01-06 | 1d | 163d |  | start no earlier than 2005-01-03 | {D40EAED1-C008-4164-B88C-E8D34F133167} |
| 608 | 7.2.1.2 | Maintain risk management logs 2 |  | 1d | 2005-01-10 | 2005-01-10 |  | 2005-01-10 | 2005-01-10 | 1d | 161d |  | start no earlier than 2005-01-10 | {E1E2AC1D-178D-483E-9B80-3718429A680D} |
| 609 | 7.2.1.3 | Maintain risk management logs 3 |  | 1d | 2005-01-17 | 2005-01-17 |  | 2005-01-17 | 2005-01-17 | 1d | 156d |  | start no earlier than 2005-01-17 | {27598E5B-00A1-4DF2-86CC-10E904118E01} |
| 610 | 7.2.1.4 | Maintain risk management logs 4 |  | 1d | 2005-01-24 | 2005-01-24 |  | 2005-01-24 | 2005-01-24 | 1d | 151d |  | start no earlier than 2005-01-24 | {52BE302C-3B0A-4BA8-9051-8C976CB298A9} |
| 611 | 7.2.1.5 | Maintain risk management logs 5 |  | 1d | 2005-01-31 | 2005-01-31 |  | 2005-01-31 | 2005-01-31 | 1d | 146d |  | start no earlier than 2005-01-31 | {F43B3A27-2673-4088-981B-49890630F900} |
| 612 | 7.2.1.6 | Maintain risk management logs 6 |  | 1d | 2005-02-07 | 2005-02-07 |  | 2005-02-07 | 2005-02-07 | 1d | 141d |  | start no earlier than 2005-02-07 | {87D29803-A380-4682-8CB0-60C462B2B7A5} |
| 613 | 7.2.1.7 | Maintain risk management logs 7 |  | 1d | 2005-02-14 | 2005-02-14 |  | 2005-02-14 | 2005-02-14 | 1d | 136d |  | start no earlier than 2005-02-14 | {5E6A107C-9A0B-4A69-8338-BDD0E06E6029} |
| 614 | 7.2.1.8 | Maintain risk management logs 8 |  | 1d | 2005-02-21 | 2005-02-21 |  | 2005-02-21 | 2005-02-21 | 1d | 131d |  | start no earlier than 2005-02-21 | {7B0B7555-978E-4CCA-8D3F-23985A143286} |
| 615 | 7.2.1.9 | Maintain risk management logs 9 |  | 1d | 2005-02-28 | 2005-02-28 |  | 2005-02-28 | 2005-02-28 | 1d | 126d |  | start no earlier than 2005-02-28 | {DAA88C56-CA3E-439A-90A5-C9BAD9C9D6CA} |
| 616 | 7.2.1.10 | Maintain risk management logs 10 |  | 1d | 2005-03-07 | 2005-03-07 |  | 2005-03-07 | 2005-03-07 | 1d | 121d |  | start no earlier than 2005-03-07 | {BE4F6468-9AF9-4E4F-880E-4C294697B450} |
| 617 | 7.2.1.11 | Maintain risk management logs 11 |  | 1d | 2005-03-14 | 2005-03-14 |  | 2005-03-14 | 2005-03-14 | 1d | 116d |  | start no earlier than 2005-03-14 | {87C24808-DEE0-4E83-824D-0CD961D240EF} |
| 618 | 7.2.1.12 | Maintain risk management logs 12 |  | 1d | 2005-03-21 | 2005-03-21 |  | 2005-03-21 | 2005-03-21 | 1d | 111d |  | start no earlier than 2005-03-21 | {5BE7C598-A22E-4936-A1BC-B6EA8E3BAFF4} |
| 619 | 7.2.1.13 | Maintain risk management logs 13 |  | 1d | 2005-03-28 | 2005-03-28 |  | 2005-03-28 | 2005-03-28 | 1d | 106d |  | start no earlier than 2005-03-28 | {F48CB5DF-6396-427D-BD90-F9D2CB825F62} |
| 620 | 7.2.1.14 | Maintain risk management logs 14 |  | 1d | 2005-04-04 | 2005-04-04 |  | 2005-04-04 | 2005-04-04 | 1d | 101d |  | start no earlier than 2005-04-04 | {7CC463B0-D792-490D-8EAF-EE5DA2D7D3CA} |
| 621 | 7.2.1.15 | Maintain risk management logs 15 |  | 1d | 2005-04-11 | 2005-04-11 |  | 2005-04-11 | 2005-04-11 | 1d | 96d |  | start no earlier than 2005-04-11 | {2C5161F2-038B-45F4-9B13-E4105763EE14} |
| 622 | 7.2.1.16 | Maintain risk management logs 16 |  | 1d | 2005-04-18 | 2005-04-18 |  | 2005-04-18 | 2005-04-18 | 1d | 91d |  | start no earlier than 2005-04-18 | {14BE52D8-5756-462F-B5D2-673FA780FDF4} |
| 623 | 7.2.1.17 | Maintain risk management logs 17 |  | 1d | 2005-04-25 | 2005-04-25 |  | 2005-04-25 | 2005-04-25 | 1d | 86d |  | start no earlier than 2005-04-25 | {448EBE16-8914-4DBF-95CC-20403EC0D6F8} |
| 624 | 7.2.1.18 | Maintain risk management logs 18 |  | 1d | 2005-05-02 | 2005-05-02 |  | 2005-05-02 | 2005-05-02 | 1d | 81d |  | start no earlier than 2005-05-02 | {39CDA1F8-AE12-46C9-9413-D871202409CC} |
| 625 | 7.2.1.19 | Maintain risk management logs 19 |  | 1d | 2005-05-09 | 2005-05-09 |  | 2005-05-09 | 2005-05-09 | 1d | 76d |  | start no earlier than 2005-05-09 | {020F0C2E-AC4D-4915-B625-06CABA3A8B93} |
| 626 | 7.2.1.20 | Maintain risk management logs 20 |  | 1d | 2005-05-16 | 2005-05-16 |  | 2005-05-16 | 2005-05-16 | 1d | 71d |  | start no earlier than 2005-05-16 | {8D747043-07D8-4D0C-8706-1C7393CD819C} |
| 627 | 7.2.1.21 | Maintain risk management logs 21 |  | 1d | 2005-05-23 | 2005-05-23 |  | 2005-05-23 | 2005-05-23 | 1d | 66d |  | start no earlier than 2005-05-23 | {0768316B-3E6E-4CBF-9061-69C3B0FC5B59} |
| 628 | 7.2.1.22 | Maintain risk management logs 22 |  | 1d | 2005-05-30 | 2005-05-30 |  | 2005-05-30 | 2005-05-30 | 1d | 61d |  | start no earlier than 2005-05-30 | {16BA0753-D7D2-4703-81B5-09643ACD692F} |
| 629 | 7.2.1.23 | Maintain risk management logs 23 |  | 1d | 2005-06-06 | 2005-06-06 |  | 2005-06-06 | 2005-06-06 | 1d | 56d |  | start no earlier than 2005-06-06 | {6EA22B61-9171-4D51-898F-85FC52A37ECD} |
| 630 | 7.2.1.24 | Maintain risk management logs 24 |  | 1d | 2005-06-13 | 2005-06-13 |  | 2005-06-13 | 2005-06-13 | 1d | 51d |  | start no earlier than 2005-06-13 | {39ED89E8-AFC6-4AD0-8AA3-B48EB7337B09} |
| 631 | 7.2.1.25 | Maintain risk management logs 25 |  | 1d | 2005-06-20 | 2005-06-20 |  | 2005-06-20 | 2005-06-20 | 1d | 46d |  | start no earlier than 2005-06-20 | {00068DAA-CF65-4B3C-AA29-BF0B89148E95} |
| 632 | 7.2.1.26 | Maintain risk management logs 26 |  | 1d | 2005-06-27 | 2005-06-27 |  | 2005-06-27 | 2005-06-27 | 1d | 41d |  | start no earlier than 2005-06-27 | {A233679F-2691-4290-8D8A-5ADFF8737C65} |
| 633 | 7.2.1.27 | Maintain risk management logs 27 |  | 1d | 2005-07-04 | 2005-07-04 |  | 2005-07-04 | 2005-07-04 | 1d | 36d |  | start no earlier than 2005-07-04 | {663694D0-47DA-4F72-9DCA-5336FE7DAC78} |
| 634 | 7.2.1.28 | Maintain risk management logs 28 |  | 1d | 2005-07-11 | 2005-07-11 |  | 2005-07-11 | 2005-07-11 | 1d | 31d |  | start no earlier than 2005-07-11 | {BBE702E0-CFFB-455C-A6AD-2081B64340A6} |
| 635 | 7.2.1.29 | Maintain risk management logs 29 |  | 1d | 2005-07-18 | 2005-07-18 |  | 2005-07-18 | 2005-07-18 | 1d | 26d |  | start no earlier than 2005-07-18 | {5AD96266-1F29-4F25-8F51-EA1710490107} |
| 636 | 7.2.1.30 | Maintain risk management logs 30 |  | 1d | 2005-07-25 | 2005-07-25 |  | 2005-07-25 | 2005-07-25 | 1d | 21d |  | start no earlier than 2005-07-25 | {202C08D8-5411-4978-89BA-46143FED585D} |
| 637 | 7.2.1.31 | Maintain risk management logs 31 |  | 1d | 2005-08-01 | 2005-08-01 |  | 2005-08-01 | 2005-08-01 | 1d | 16d |  | start no earlier than 2005-08-01 | {D43C6E42-55A6-4C9A-ABA0-8A96E5CD29ED} |
| 638 | 7.2.1.32 | Maintain risk management logs 32 |  | 1d | 2005-08-08 | 2005-08-08 |  | 2005-08-08 | 2005-08-08 | 1d | 11d |  | start no earlier than 2005-08-08 | {6B086E84-FC74-4C18-891B-F44B87826408} |
| 639 | 7.2.1.33 | Maintain risk management logs 33 |  | 1d | 2005-08-15 | 2005-08-15 |  | 2005-08-15 | 2005-08-15 | 1d | 6d |  | start no earlier than 2005-08-15 | {D3CE1344-79FD-4275-86A9-6E0CA79968AD} |
| 640 | 7.2.1.34 | Maintain risk management logs 34 |  | 1d | 2005-08-22 | 2005-08-22 |  | 2005-08-22 | 2005-08-22 | 1d | 1d |  | start no earlier than 2005-08-22 | {59A9A1F8-D307-4556-A5D7-6F3AC1A8FFE4} |

Notes:
- 592: Text3: <sync-guid>{B60551D7-BC89-498B-8C24-616471D3737B}</sync-guid><sync-parentguid>{B572D7F3-0630-41BE-A63B-C425E92F4460}</sync-parentguid><sync-checksum>-816588070</sync-checksum><sync-rootid>0</sync-rootid><sync-itemtype>0</sync-itemtype><sync-timestamp>12/3 / Text5: 0/2004 1:13:02 PM</sync-timestamp><sync-itemid>314</sync-itemid><sync-prioritymapping>0:0-0/1:700-1000/2:300-699/3:1-299</sync-prioritymapping>
- 593: Text3: <sync-guid>{9411F628-A22B-430D-AE01-59CE49D2BC1A}</sync-guid><sync-parentguid>{B60551D7-BC89-498B-8C24-616471D3737B}</sync-parentguid><sync-checksum>-908611354</sync-checksum><sync-rootid>0</sync-rootid><sync-itemtype>0</sync-itemtype><sync-timestamp>12/3 / Text5: 0/2004 1:13:01 PM</sync-timestamp><sync-itemid>315</sync-itemid><sync-prioritymapping>0:0-0/1:700-1000/2:300-699/3:1-299</sync-prioritymapping>
- 594: Text3: <sync-guid>{4F600391-2BD7-4D9C-9007-5E0689E6372F}</sync-guid><sync-parentguid>{B60551D7-BC89-498B-8C24-616471D3737B}</sync-parentguid><sync-checksum>1919490806</sync-checksum><sync-rootid>0</sync-rootid><sync-itemtype>0</sync-itemtype><sync-timestamp>12/3 / Text5: 0/2004 1:13:01 PM</sync-timestamp><sync-itemid>316</sync-itemid><sync-prioritymapping>0:0-0/1:700-1000/2:300-699/3:1-299</sync-prioritymapping>
- 595: Text3: <sync-guid>{C356DDEA-58B0-4A3A-BD70-854B8CDD77C3}</sync-guid><sync-parentguid>{B60551D7-BC89-498B-8C24-616471D3737B}</sync-parentguid><sync-checksum>-481484328</sync-checksum><sync-rootid>0</sync-rootid><sync-itemtype>0</sync-itemtype><sync-timestamp>12/3 / Text5: 0/2004 1:13:02 PM</sync-timestamp><sync-itemid>321</sync-itemid><sync-prioritymapping>0:0-0/1:700-1000/2:300-699/3:1-299</sync-prioritymapping>
- 596: Text3: <sync-guid>{9D4343B0-644C-4EF4-8F46-2152F7853CFA}</sync-guid><sync-parentguid>{B60551D7-BC89-498B-8C24-616471D3737B}</sync-parentguid><sync-checksum>1887076482</sync-checksum><sync-rootid>0</sync-rootid><sync-itemtype>0</sync-itemtype><sync-timestamp>12/3 / Text5: 0/2004 1:13:02 PM</sync-timestamp><sync-itemid>317</sync-itemid><sync-prioritymapping>0:0-0/1:700-1000/2:300-699/3:1-299</sync-prioritymapping>
- 597: Text3: <sync-guid>{CAA64EEC-8C43-41BB-BD69-85BD1B9C6308}</sync-guid><sync-parentguid>{B60551D7-BC89-498B-8C24-616471D3737B}</sync-parentguid><sync-checksum>-782558549</sync-checksum><sync-rootid>0</sync-rootid><sync-itemtype>0</sync-itemtype><sync-timestamp>12/3 / Text5: 0/2004 1:13:02 PM</sync-timestamp><sync-itemid>318</sync-itemid><sync-prioritymapping>0:0-0/1:700-1000/2:300-699/3:1-299</sync-prioritymapping>
- 598: Text3: <sync-guid>{9E55DC8E-FCA4-4D95-BBCF-9F2DDD4601DA}</sync-guid><sync-parentguid>{69CAB05D-8790-4A69-A093-1D8EDB5A2679}</sync-parentguid><sync-checksum>-1204232924</sync-checksum><sync-rootid>0</sync-rootid><sync-itemtype>0</sync-itemtype><sync-timestamp>12 / Text5: 30/2004 1:13:44 PM</sync-timestamp><sync-itemid>707</sync-itemid><sync-prioritymapping>0:0-0/1:700-1000/2:300-699/3:1-299</sync-prioritymapping>
- 599: Text3: <sync-guid>{E11E90AB-D4F8-4519-B28E-0A612553867B}</sync-guid><sync-parentguid>{9E55DC8E-FCA4-4D95-BBCF-9F2DDD4601DA}</sync-parentguid><sync-checksum>391534731</sync-checksum><sync-rootid>0</sync-rootid><sync-itemtype>0</sync-itemtype><sync-timestamp>12/30 / Text5: 2004 1:13:03 PM</sync-timestamp><sync-itemid>708</sync-itemid><sync-prioritymapping>0:0-0/1:700-1000/2:300-699/3:1-299</sync-prioritymapping>
- 600: Text3: <sync-guid>{EC86F6D2-76F8-4A37-8ACF-E8D50C117ADC}</sync-guid><sync-parentguid>{E11E90AB-D4F8-4519-B28E-0A612553867B}</sync-parentguid><sync-checksum>1809325481</sync-checksum><sync-rootid>0</sync-rootid><sync-itemtype>0</sync-itemtype><sync-timestamp>12/3 / Text5: 0/2004 1:13:02 PM</sync-timestamp><sync-itemid>711</sync-itemid><sync-prioritymapping>0:0-0/1:700-1000/2:300-699/3:1-299</sync-prioritymapping>
- 601: Text3: <sync-guid>{BAF91F3A-5443-4ABA-BC57-AF46B2B53BA0}</sync-guid><sync-parentguid>{E11E90AB-D4F8-4519-B28E-0A612553867B}</sync-parentguid><sync-checksum>1041256171</sync-checksum><sync-rootid>0</sync-rootid><sync-itemtype>0</sync-itemtype><sync-timestamp>12/3 / Text5: 0/2004 1:13:02 PM</sync-timestamp><sync-itemid>713</sync-itemid><sync-prioritymapping>0:0-0/1:700-1000/2:300-699/3:1-299</sync-prioritymapping>
- 602: Text3: <sync-guid>{C29C04A7-4CF1-4EC2-ADB9-36290453737F}</sync-guid><sync-parentguid>{E11E90AB-D4F8-4519-B28E-0A612553867B}</sync-parentguid><sync-checksum>-747785302</sync-checksum><sync-rootid>0</sync-rootid><sync-itemtype>0</sync-itemtype><sync-timestamp>12/3 / Text5: 0/2004 1:13:03 PM</sync-timestamp><sync-itemid>714</sync-itemid><sync-prioritymapping>0:0-0/1:700-1000/2:300-699/3:1-299</sync-prioritymapping>
- 603: Text3: <sync-guid>{D56B3CB6-771E-4D5D-907D-9B907C6A15B2}</sync-guid><sync-parentguid>{E11E90AB-D4F8-4519-B28E-0A612553867B}</sync-parentguid><sync-checksum>-817295090</sync-checksum><sync-rootid>0</sync-rootid><sync-itemtype>0</sync-itemtype><sync-timestamp>12/3 / Text5: 0/2004 1:13:03 PM</sync-timestamp><sync-itemid>938</sync-itemid><sync-prioritymapping>0:0-0/1:700-1000/2:300-699/3:1-299</sync-prioritymapping>
- 604: Text3: <sync-guid>{8B3D79D4-8C75-4B66-9355-5D52ECF1F42E}</sync-guid><sync-parentguid>{E11E90AB-D4F8-4519-B28E-0A612553867B}</sync-parentguid><sync-checksum>1816247989</sync-checksum><sync-rootid>0</sync-rootid><sync-itemtype>0</sync-itemtype><sync-timestamp>12/3 / Text5: 0/2004 1:13:03 PM</sync-timestamp><sync-itemid>830</sync-itemid><sync-prioritymapping>0:0-0/1:700-1000/2:300-699/3:1-299</sync-prioritymapping>
- 605: Text3: <sync-guid>{55A6A8DD-D0E3-4E39-AE60-4750F7DD10C2}</sync-guid><sync-parentguid>{9E55DC8E-FCA4-4D95-BBCF-9F2DDD4601DA}</sync-parentguid><sync-checksum>-370431666</sync-checksum><sync-rootid>0</sync-rootid><sync-itemtype>0</sync-itemtype><sync-timestamp>12/3 / Text5: 0/2004 1:13:44 PM</sync-timestamp><sync-itemid>709</sync-itemid><sync-prioritymapping>0:0-0/1:700-1000/2:300-699/3:1-299</sync-prioritymapping>
- 606: Text3: <sync-guid>{2D0FA5E4-D704-4262-A8D0-656CB6F204A5}</sync-guid><sync-parentguid>{55A6A8DD-D0E3-4E39-AE60-4750F7DD10C2}</sync-parentguid><sync-checksum>-535153123</sync-checksum><sync-rootid>0</sync-rootid><sync-itemtype>0</sync-itemtype><sync-timestamp>12/3 / Text5: 0/2004 1:13:07 PM</sync-timestamp><sync-itemid>717</sync-itemid><sync-prioritymapping>0:0-0/1:700-1000/2:300-699/3:1-299</sync-prioritymapping>
- 607: Text3: <sync-guid>{D40EAED1-C008-4164-B88C-E8D34F133167}</sync-guid><sync-parentguid>{2D0FA5E4-D704-4262-A8D0-656CB6F204A5}</sync-parentguid><sync-checksum>-2146246685</sync-checksum><sync-rootid>0</sync-rootid><sync-itemtype>0</sync-itemtype><sync-timestamp>12 / Text5: 30/2004 1:13:03 PM</sync-timestamp><sync-itemid>718</sync-itemid><sync-prioritymapping>0:0-0/1:700-1000/2:300-699/3:1-299</sync-prioritymapping>
- 608: Text3: <sync-guid>{E1E2AC1D-178D-483E-9B80-3718429A680D}</sync-guid><sync-parentguid>{2D0FA5E4-D704-4262-A8D0-656CB6F204A5}</sync-parentguid><sync-checksum>-1875373939</sync-checksum><sync-rootid>0</sync-rootid><sync-itemtype>0</sync-itemtype><sync-timestamp>12 / Text5: 21/2004 9:45:15 AM</sync-timestamp><sync-itemid>719</sync-itemid><sync-prioritymapping>0:0-0/1:700-1000/2:300-699/3:1-299</sync-prioritymapping>
- 609: Text3: <sync-guid>{27598E5B-00A1-4DF2-86CC-10E904118E01}</sync-guid><sync-parentguid>{2D0FA5E4-D704-4262-A8D0-656CB6F204A5}</sync-parentguid><sync-checksum>315374417</sync-checksum><sync-rootid>0</sync-rootid><sync-itemtype>0</sync-itemtype><sync-timestamp>12/21 / Text5: 2004 9:45:15 AM</sync-timestamp><sync-itemid>720</sync-itemid><sync-prioritymapping>0:0-0/1:700-1000/2:300-699/3:1-299</sync-prioritymapping>
- 610: Text3: <sync-guid>{52BE302C-3B0A-4BA8-9051-8C976CB298A9}</sync-guid><sync-parentguid>{2D0FA5E4-D704-4262-A8D0-656CB6F204A5}</sync-parentguid><sync-checksum>1777759238</sync-checksum><sync-rootid>0</sync-rootid><sync-itemtype>0</sync-itemtype><sync-timestamp>12/2 / Text5: 1/2004 9:45:15 AM</sync-timestamp><sync-itemid>721</sync-itemid><sync-prioritymapping>0:0-0/1:700-1000/2:300-699/3:1-299</sync-prioritymapping>
- 611: Text3: <sync-guid>{F43B3A27-2673-4088-981B-49890630F900}</sync-guid><sync-parentguid>{2D0FA5E4-D704-4262-A8D0-656CB6F204A5}</sync-parentguid><sync-checksum>-1883509294</sync-checksum><sync-rootid>0</sync-rootid><sync-itemtype>0</sync-itemtype><sync-timestamp>12 / Text5: 21/2004 9:45:15 AM</sync-timestamp><sync-itemid>722</sync-itemid><sync-prioritymapping>0:0-0/1:700-1000/2:300-699/3:1-299</sync-prioritymapping>
- 612: Text3: <sync-guid>{87D29803-A380-4682-8CB0-60C462B2B7A5}</sync-guid><sync-parentguid>{2D0FA5E4-D704-4262-A8D0-656CB6F204A5}</sync-parentguid><sync-checksum>448327915</sync-checksum><sync-rootid>0</sync-rootid><sync-itemtype>0</sync-itemtype><sync-timestamp>12/21 / Text5: 2004 9:45:15 AM</sync-timestamp><sync-itemid>723</sync-itemid><sync-prioritymapping>0:0-0/1:700-1000/2:300-699/3:1-299</sync-prioritymapping>
- 613: Text3: <sync-guid>{5E6A107C-9A0B-4A69-8338-BDD0E06E6029}</sync-guid><sync-parentguid>{2D0FA5E4-D704-4262-A8D0-656CB6F204A5}</sync-parentguid><sync-checksum>-1746185974</sync-checksum><sync-rootid>0</sync-rootid><sync-itemtype>0</sync-itemtype><sync-timestamp>12 / Text5: 21/2004 9:45:15 AM</sync-timestamp><sync-itemid>724</sync-itemid><sync-prioritymapping>0:0-0/1:700-1000/2:300-699/3:1-299</sync-prioritymapping>
- 614: Text3: <sync-guid>{7B0B7555-978E-4CCA-8D3F-23985A143286}</sync-guid><sync-parentguid>{2D0FA5E4-D704-4262-A8D0-656CB6F204A5}</sync-parentguid><sync-checksum>1049362536</sync-checksum><sync-rootid>0</sync-rootid><sync-itemtype>0</sync-itemtype><sync-timestamp>12/2 / Text5: 1/2004 9:45:15 AM</sync-timestamp><sync-itemid>725</sync-itemid><sync-prioritymapping>0:0-0/1:700-1000/2:300-699/3:1-299</sync-prioritymapping>
- 615: Text3: <sync-guid>{DAA88C56-CA3E-439A-90A5-C9BAD9C9D6CA}</sync-guid><sync-parentguid>{2D0FA5E4-D704-4262-A8D0-656CB6F204A5}</sync-parentguid><sync-checksum>1286714317</sync-checksum><sync-rootid>0</sync-rootid><sync-itemtype>0</sync-itemtype><sync-timestamp>12/2 / Text5: 1/2004 9:45:15 AM</sync-timestamp><sync-itemid>726</sync-itemid><sync-prioritymapping>0:0-0/1:700-1000/2:300-699/3:1-299</sync-prioritymapping>
- 616: Text3: <sync-guid>{BE4F6468-9AF9-4E4F-880E-4C294697B450}</sync-guid><sync-parentguid>{2D0FA5E4-D704-4262-A8D0-656CB6F204A5}</sync-parentguid><sync-checksum>-1569572384</sync-checksum><sync-rootid>0</sync-rootid><sync-itemtype>0</sync-itemtype><sync-timestamp>12 / Text5: 21/2004 9:45:15 AM</sync-timestamp><sync-itemid>727</sync-itemid><sync-prioritymapping>0:0-0/1:700-1000/2:300-699/3:1-299</sync-prioritymapping>
- 617: Text3: <sync-guid>{87C24808-DEE0-4E83-824D-0CD961D240EF}</sync-guid><sync-parentguid>{2D0FA5E4-D704-4262-A8D0-656CB6F204A5}</sync-parentguid><sync-checksum>790730753</sync-checksum><sync-rootid>0</sync-rootid><sync-itemtype>0</sync-itemtype><sync-timestamp>12/21 / Text5: 2004 9:45:15 AM</sync-timestamp><sync-itemid>728</sync-itemid><sync-prioritymapping>0:0-0/1:700-1000/2:300-699/3:1-299</sync-prioritymapping>
- 618: Text3: <sync-guid>{5BE7C598-A22E-4936-A1BC-B6EA8E3BAFF4}</sync-guid><sync-parentguid>{2D0FA5E4-D704-4262-A8D0-656CB6F204A5}</sync-parentguid><sync-checksum>1671724131</sync-checksum><sync-rootid>0</sync-rootid><sync-itemtype>0</sync-itemtype><sync-timestamp>12/2 / Text5: 1/2004 9:45:15 AM</sync-timestamp><sync-itemid>729</sync-itemid><sync-prioritymapping>0:0-0/1:700-1000/2:300-699/3:1-299</sync-prioritymapping>
- 619: Text3: <sync-guid>{F48CB5DF-6396-427D-BD90-F9D2CB825F62}</sync-guid><sync-parentguid>{2D0FA5E4-D704-4262-A8D0-656CB6F204A5}</sync-parentguid><sync-checksum>295292870</sync-checksum><sync-rootid>0</sync-rootid><sync-itemtype>0</sync-itemtype><sync-timestamp>12/21 / Text5: 2004 9:45:16 AM</sync-timestamp><sync-itemid>730</sync-itemid><sync-prioritymapping>0:0-0/1:700-1000/2:300-699/3:1-299</sync-prioritymapping>
- 620: Text3: <sync-guid>{7CC463B0-D792-490D-8EAF-EE5DA2D7D3CA}</sync-guid><sync-parentguid>{2D0FA5E4-D704-4262-A8D0-656CB6F204A5}</sync-parentguid><sync-checksum>622208199</sync-checksum><sync-rootid>0</sync-rootid><sync-itemtype>0</sync-itemtype><sync-timestamp>12/21 / Text5: 2004 9:45:16 AM</sync-timestamp><sync-itemid>731</sync-itemid><sync-prioritymapping>0:0-0/1:700-1000/2:300-699/3:1-299</sync-prioritymapping>
- 621: Text3: <sync-guid>{2C5161F2-038B-45F4-9B13-E4105763EE14}</sync-guid><sync-parentguid>{2D0FA5E4-D704-4262-A8D0-656CB6F204A5}</sync-parentguid><sync-checksum>-1017397997</sync-checksum><sync-rootid>0</sync-rootid><sync-itemtype>0</sync-itemtype><sync-timestamp>12 / Text5: 21/2004 9:45:16 AM</sync-timestamp><sync-itemid>732</sync-itemid><sync-prioritymapping>0:0-0/1:700-1000/2:300-699/3:1-299</sync-prioritymapping>
- 622: Text3: <sync-guid>{14BE52D8-5756-462F-B5D2-673FA780FDF4}</sync-guid><sync-parentguid>{2D0FA5E4-D704-4262-A8D0-656CB6F204A5}</sync-parentguid><sync-checksum>-1623800010</sync-checksum><sync-rootid>0</sync-rootid><sync-itemtype>0</sync-itemtype><sync-timestamp>12 / Text5: 21/2004 9:45:16 AM</sync-timestamp><sync-itemid>733</sync-itemid><sync-prioritymapping>0:0-0/1:700-1000/2:300-699/3:1-299</sync-prioritymapping>
- 623: Text3: <sync-guid>{448EBE16-8914-4DBF-95CC-20403EC0D6F8}</sync-guid><sync-parentguid>{2D0FA5E4-D704-4262-A8D0-656CB6F204A5}</sync-parentguid><sync-checksum>1714703000</sync-checksum><sync-rootid>0</sync-rootid><sync-itemtype>0</sync-itemtype><sync-timestamp>12/2 / Text5: 1/2004 9:45:16 AM</sync-timestamp><sync-itemid>734</sync-itemid><sync-prioritymapping>0:0-0/1:700-1000/2:300-699/3:1-299</sync-prioritymapping>
- 624: Text3: <sync-guid>{39CDA1F8-AE12-46C9-9413-D871202409CC}</sync-guid><sync-parentguid>{2D0FA5E4-D704-4262-A8D0-656CB6F204A5}</sync-parentguid><sync-checksum>-1418038227</sync-checksum><sync-rootid>0</sync-rootid><sync-itemtype>0</sync-itemtype><sync-timestamp>12 / Text5: 21/2004 9:45:16 AM</sync-timestamp><sync-itemid>735</sync-itemid><sync-prioritymapping>0:0-0/1:700-1000/2:300-699/3:1-299</sync-prioritymapping>
- 625: Text3: <sync-guid>{020F0C2E-AC4D-4915-B625-06CABA3A8B93}</sync-guid><sync-parentguid>{2D0FA5E4-D704-4262-A8D0-656CB6F204A5}</sync-parentguid><sync-checksum>-5099621</sync-checksum><sync-rootid>0</sync-rootid><sync-itemtype>0</sync-itemtype><sync-timestamp>12/21 / Text5: 2004 9:45:16 AM</sync-timestamp><sync-itemid>736</sync-itemid><sync-prioritymapping>0:0-0/1:700-1000/2:300-699/3:1-299</sync-prioritymapping>
- 626: Text3: <sync-guid>{8D747043-07D8-4D0C-8706-1C7393CD819C}</sync-guid><sync-parentguid>{2D0FA5E4-D704-4262-A8D0-656CB6F204A5}</sync-parentguid><sync-checksum>1803280685</sync-checksum><sync-rootid>0</sync-rootid><sync-itemtype>0</sync-itemtype><sync-timestamp>12/2 / Text5: 1/2004 9:45:16 AM</sync-timestamp><sync-itemid>737</sync-itemid><sync-prioritymapping>0:0-0/1:700-1000/2:300-699/3:1-299</sync-prioritymapping>
- 627: Text3: <sync-guid>{0768316B-3E6E-4CBF-9061-69C3B0FC5B59}</sync-guid><sync-parentguid>{2D0FA5E4-D704-4262-A8D0-656CB6F204A5}</sync-parentguid><sync-checksum>162450639</sync-checksum><sync-rootid>0</sync-rootid><sync-itemtype>0</sync-itemtype><sync-timestamp>12/21 / Text5: 2004 9:45:16 AM</sync-timestamp><sync-itemid>738</sync-itemid><sync-prioritymapping>0:0-0/1:700-1000/2:300-699/3:1-299</sync-prioritymapping>
- 628: Text3: <sync-guid>{16BA0753-D7D2-4703-81B5-09643ACD692F}</sync-guid><sync-parentguid>{2D0FA5E4-D704-4262-A8D0-656CB6F204A5}</sync-parentguid><sync-checksum>-1431460690</sync-checksum><sync-rootid>0</sync-rootid><sync-itemtype>0</sync-itemtype><sync-timestamp>12 / Text5: 21/2004 9:45:16 AM</sync-timestamp><sync-itemid>739</sync-itemid><sync-prioritymapping>0:0-0/1:700-1000/2:300-699/3:1-299</sync-prioritymapping>
- 629: Text3: <sync-guid>{6EA22B61-9171-4D51-898F-85FC52A37ECD}</sync-guid><sync-parentguid>{2D0FA5E4-D704-4262-A8D0-656CB6F204A5}</sync-parentguid><sync-checksum>301887511</sync-checksum><sync-rootid>0</sync-rootid><sync-itemtype>0</sync-itemtype><sync-timestamp>12/21 / Text5: 2004 9:45:16 AM</sync-timestamp><sync-itemid>740</sync-itemid><sync-prioritymapping>0:0-0/1:700-1000/2:300-699/3:1-299</sync-prioritymapping>
- 630: Text3: <sync-guid>{39ED89E8-AFC6-4AD0-8AA3-B48EB7337B09}</sync-guid><sync-parentguid>{2D0FA5E4-D704-4262-A8D0-656CB6F204A5}</sync-parentguid><sync-checksum>-2059226301</sync-checksum><sync-rootid>0</sync-rootid><sync-itemtype>0</sync-itemtype><sync-timestamp>12 / Text5: 21/2004 9:45:17 AM</sync-timestamp><sync-itemid>888</sync-itemid><sync-prioritymapping>0:0-0/1:700-1000/2:300-699/3:1-299</sync-prioritymapping>
- 631: Text3: <sync-guid>{00068DAA-CF65-4B3C-AA29-BF0B89148E95}</sync-guid><sync-parentguid>{2D0FA5E4-D704-4262-A8D0-656CB6F204A5}</sync-parentguid><sync-checksum>-1937135980</sync-checksum><sync-rootid>0</sync-rootid><sync-itemtype>0</sync-itemtype><sync-timestamp>12 / Text5: 21/2004 9:45:17 AM</sync-timestamp><sync-itemid>889</sync-itemid><sync-prioritymapping>0:0-0/1:700-1000/2:300-699/3:1-299</sync-prioritymapping>
- 632: Text3: <sync-guid>{A233679F-2691-4290-8D8A-5ADFF8737C65}</sync-guid><sync-parentguid>{2D0FA5E4-D704-4262-A8D0-656CB6F204A5}</sync-parentguid><sync-checksum>539837640</sync-checksum><sync-rootid>0</sync-rootid><sync-itemtype>0</sync-itemtype><sync-timestamp>12/30 / Text5: 2004 1:09:40 PM</sync-timestamp><sync-itemid>1109</sync-itemid><sync-prioritymapping>0:0-0/1:700-1000/2:300-699/3:1-299</sync-prioritymapping>
- 633: Text3: <sync-guid>{663694D0-47DA-4F72-9DCA-5336FE7DAC78}</sync-guid><sync-parentguid>{2D0FA5E4-D704-4262-A8D0-656CB6F204A5}</sync-parentguid><sync-checksum>1799018203</sync-checksum><sync-rootid>0</sync-rootid><sync-itemtype>0</sync-itemtype><sync-timestamp>12/3 / Text5: 0/2004 1:09:41 PM</sync-timestamp><sync-itemid>1110</sync-itemid><sync-prioritymapping>0:0-0/1:700-1000/2:300-699/3:1-299</sync-prioritymapping>
- 634: Text3: <sync-guid>{BBE702E0-CFFB-455C-A6AD-2081B64340A6}</sync-guid><sync-parentguid>{2D0FA5E4-D704-4262-A8D0-656CB6F204A5}</sync-parentguid><sync-checksum>1187328911</sync-checksum><sync-rootid>0</sync-rootid><sync-itemtype>0</sync-itemtype><sync-timestamp>12/3 / Text5: 0/2004 1:09:41 PM</sync-timestamp><sync-itemid>1111</sync-itemid><sync-prioritymapping>0:0-0/1:700-1000/2:300-699/3:1-299</sync-prioritymapping>
- 635: Text3: <sync-guid>{5AD96266-1F29-4F25-8F51-EA1710490107}</sync-guid><sync-parentguid>{2D0FA5E4-D704-4262-A8D0-656CB6F204A5}</sync-parentguid><sync-checksum>888700970</sync-checksum><sync-rootid>0</sync-rootid><sync-itemtype>0</sync-itemtype><sync-timestamp>12/30 / Text5: 2004 1:09:42 PM</sync-timestamp><sync-itemid>1173</sync-itemid><sync-prioritymapping>0:0-0/1:700-1000/2:300-699/3:1-299</sync-prioritymapping>
- 636: Text3: <sync-guid>{202C08D8-5411-4978-89BA-46143FED585D}</sync-guid><sync-parentguid>{2D0FA5E4-D704-4262-A8D0-656CB6F204A5}</sync-parentguid><sync-checksum>-271924912</sync-checksum><sync-rootid>0</sync-rootid><sync-itemtype>0</sync-itemtype><sync-timestamp>12/3 / Text5: 0/2004 1:09:42 PM</sync-timestamp><sync-itemid>1174</sync-itemid><sync-prioritymapping>0:0-0/1:700-1000/2:300-699/3:1-299</sync-prioritymapping>
- 637: Text3: <sync-guid>{D43C6E42-55A6-4C9A-ABA0-8A96E5CD29ED}</sync-guid><sync-parentguid>{2D0FA5E4-D704-4262-A8D0-656CB6F204A5}</sync-parentguid><sync-checksum>920993381</sync-checksum><sync-rootid>0</sync-rootid><sync-itemtype>0</sync-itemtype><sync-timestamp>12/30 / Text5: 2004 1:09:42 PM</sync-timestamp><sync-itemid>1175</sync-itemid><sync-prioritymapping>0:0-0/1:700-1000/2:300-699/3:1-299</sync-prioritymapping>
- 638: Text3: <sync-guid>{6B086E84-FC74-4C18-891B-F44B87826408}</sync-guid><sync-parentguid>{2D0FA5E4-D704-4262-A8D0-656CB6F204A5}</sync-parentguid><sync-checksum>1787315264</sync-checksum><sync-rootid>0</sync-rootid><sync-itemtype>0</sync-itemtype><sync-timestamp>12/3 / Text5: 0/2004 1:09:43 PM</sync-timestamp><sync-itemid>1270</sync-itemid><sync-prioritymapping>0:0-0/1:700-1000/2:300-699/3:1-299</sync-prioritymapping>
- 639: Text3: <sync-guid>{D3CE1344-79FD-4275-86A9-6E0CA79968AD}</sync-guid><sync-parentguid>{2D0FA5E4-D704-4262-A8D0-656CB6F204A5}</sync-parentguid><sync-checksum>387087832</sync-checksum><sync-rootid>0</sync-rootid><sync-itemtype>0</sync-itemtype><sync-timestamp>12/30 / Text5: 2004 1:09:43 PM</sync-timestamp><sync-itemid>1271</sync-itemid><sync-prioritymapping>0:0-0/1:700-1000/2:300-699/3:1-299</sync-prioritymapping>
- 640: Text3: <sync-guid>{59A9A1F8-D307-4556-A5D7-6F3AC1A8FFE4}</sync-guid><sync-parentguid>{2D0FA5E4-D704-4262-A8D0-656CB6F204A5}</sync-parentguid><sync-checksum>566485673</sync-checksum><sync-rootid>0</sync-rootid><sync-itemtype>0</sync-itemtype><sync-timestamp>12/30 / Text5: 2004 1:09:43 PM</sync-timestamp><sync-itemid>1272</sync-itemid><sync-prioritymapping>0:0-0/1:700-1000/2:300-699/3:1-299</sync-prioritymapping>

| ID | WBS | Task | Duration | Start | Finish | Baseline start | Baseline finish | Baseline duration | Total slack | Constraint | Text4 |
| --- | --- | --- | --- | --- | --- | --- | --- | --- | --- | --- | --- |
| 641 | 7.2.2 | **Maintain issue management logs** | 163d | 2005-01-06 | 2005-08-22 | 2005-01-06 | 2005-08-22 | 163d | 1d |  | {090F6D65-4FDF-4A8A-956F-F83710F62CBC} |
| 642 | 7.2.2.1 | Maintain issue management logs 1 | 1d | 2005-01-06 | 2005-01-06 | 2005-01-06 | 2005-01-06 | 1d | 163d | start no earlier than 2005-01-03 | {720773BE-803E-43BE-BB68-98E9D2990B18} |
| 643 | 7.2.2.2 | Maintain issue management logs 2 | 1d | 2005-01-10 | 2005-01-10 | 2005-01-10 | 2005-01-10 | 1d | 161d | start no earlier than 2005-01-10 | {B577CC30-E607-44FD-B247-4270B288B91E} |
| 644 | 7.2.2.3 | Maintain issue management logs 3 | 1d | 2005-01-17 | 2005-01-17 | 2005-01-17 | 2005-01-17 | 1d | 156d | start no earlier than 2005-01-17 | {2AB9B46F-4558-441A-B9BA-884C5602D697} |
| 645 | 7.2.2.4 | Maintain issue management logs 4 | 1d | 2005-01-24 | 2005-01-24 | 2005-01-24 | 2005-01-24 | 1d | 151d | start no earlier than 2005-01-24 | {52C13301-5D23-400A-A73E-A7E551FC48F0} |
| 646 | 7.2.2.5 | Maintain issue management logs 5 | 1d | 2005-01-31 | 2005-01-31 | 2005-01-31 | 2005-01-31 | 1d | 146d | start no earlier than 2005-01-31 | {406208EB-D767-40B7-B9D0-3036B299A197} |
| 647 | 7.2.2.6 | Maintain issue management logs 6 | 1d | 2005-02-07 | 2005-02-07 | 2005-02-07 | 2005-02-07 | 1d | 141d | start no earlier than 2005-02-07 | {0FEDF510-0871-4DFD-811E-263BC574730F} |
| 648 | 7.2.2.7 | Maintain issue management logs 7 | 1d | 2005-02-14 | 2005-02-14 | 2005-02-14 | 2005-02-14 | 1d | 136d | start no earlier than 2005-02-14 | {9B4A5F6B-56BC-4221-90C0-53872890E5B2} |
| 649 | 7.2.2.8 | Maintain issue management logs 8 | 1d | 2005-02-21 | 2005-02-21 | 2005-02-21 | 2005-02-21 | 1d | 131d | start no earlier than 2005-02-21 | {C5191B07-3405-4000-9E22-E11486103E30} |
| 650 | 7.2.2.9 | Maintain issue management logs 9 | 1d | 2005-02-28 | 2005-02-28 | 2005-02-28 | 2005-02-28 | 1d | 126d | start no earlier than 2005-02-28 | {339511D4-EEE2-4470-AC2B-805BCB1FB2A1} |
| 651 | 7.2.2.10 | Maintain issue management logs 10 | 1d | 2005-03-07 | 2005-03-07 | 2005-03-07 | 2005-03-07 | 1d | 121d | start no earlier than 2005-03-07 | {AEA089CC-B055-48B5-BBC6-89C742ECFBB0} |
| 652 | 7.2.2.11 | Maintain issue management logs 11 | 1d | 2005-03-14 | 2005-03-14 | 2005-03-14 | 2005-03-14 | 1d | 116d | start no earlier than 2005-03-14 | {9826CA55-18C1-4114-AEF8-8BB0CC44E086} |
| 653 | 7.2.2.12 | Maintain issue management logs 12 | 1d | 2005-03-21 | 2005-03-21 | 2005-03-21 | 2005-03-21 | 1d | 111d | start no earlier than 2005-03-21 | {7B29F685-62D7-4B97-968A-5FAAD32A2C69} |
| 654 | 7.2.2.13 | Maintain issue management logs 13 | 1d | 2005-03-28 | 2005-03-28 | 2005-03-28 | 2005-03-28 | 1d | 106d | start no earlier than 2005-03-28 | {2A42875E-3DB9-4D38-9BD6-41E005B239B4} |
| 655 | 7.2.2.14 | Maintain issue management logs 14 | 1d | 2005-04-04 | 2005-04-04 | 2005-04-04 | 2005-04-04 | 1d | 101d | start no earlier than 2005-04-04 | {B2216BA8-98C8-4315-A101-D181B6A1AB7B} |
| 656 | 7.2.2.15 | Maintain issue management logs 15 | 1d | 2005-04-11 | 2005-04-11 | 2005-04-11 | 2005-04-11 | 1d | 96d | start no earlier than 2005-04-11 | {941796B3-0E20-4393-8E75-DDB0884FB244} |
| 657 | 7.2.2.16 | Maintain issue management logs 16 | 1d | 2005-04-18 | 2005-04-18 | 2005-04-18 | 2005-04-18 | 1d | 91d | start no earlier than 2005-04-18 | {E523B191-CCD7-4065-8994-A0F6292ED9A1} |
| 658 | 7.2.2.17 | Maintain issue management logs 17 | 1d | 2005-04-25 | 2005-04-25 | 2005-04-25 | 2005-04-25 | 1d | 86d | start no earlier than 2005-04-25 | {C3CA86D8-919C-4EB2-8A42-560784484563} |
| 659 | 7.2.2.18 | Maintain issue management logs 18 | 1d | 2005-05-02 | 2005-05-02 | 2005-05-02 | 2005-05-02 | 1d | 81d | start no earlier than 2005-05-02 | {58DBC5CA-F613-46CF-BE24-F29A742C7D8E} |
| 660 | 7.2.2.19 | Maintain issue management logs 19 | 1d | 2005-05-09 | 2005-05-09 | 2005-05-09 | 2005-05-09 | 1d | 76d | start no earlier than 2005-05-09 | {F9C198E8-4FD1-4419-B083-2A517B562333} |
| 661 | 7.2.2.20 | Maintain issue management logs 20 | 1d | 2005-05-16 | 2005-05-16 | 2005-05-16 | 2005-05-16 | 1d | 71d | start no earlier than 2005-05-16 | {37DABF99-0DDF-4D19-A6BE-C9C1C264F3B3} |
| 662 | 7.2.2.21 | Maintain issue management logs 21 | 1d | 2005-05-23 | 2005-05-23 | 2005-05-23 | 2005-05-23 | 1d | 66d | start no earlier than 2005-05-23 | {B2722673-8803-4267-893E-E519EECC8621} |
| 663 | 7.2.2.22 | Maintain issue management logs 22 | 1d | 2005-05-30 | 2005-05-30 | 2005-05-30 | 2005-05-30 | 1d | 61d | start no earlier than 2005-05-30 | {19A671B1-1DE6-4B06-8F8F-C90187350D65} |
| 664 | 7.2.2.23 | Maintain issue management logs 23 | 1d | 2005-06-06 | 2005-06-06 | 2005-06-06 | 2005-06-06 | 1d | 56d | start no earlier than 2005-06-06 | {C3651966-58CA-42FD-8922-48C53A84F0B5} |
| 665 | 7.2.2.24 | Maintain issue management logs 24 | 1d | 2005-06-13 | 2005-06-13 | 2005-06-13 | 2005-06-13 | 1d | 51d | start no earlier than 2005-06-13 | {BC213B23-CBF0-48BE-95B3-EE6A545CF8EA} |
| 666 | 7.2.2.25 | Maintain issue management logs 25 | 1d | 2005-06-20 | 2005-06-20 | 2005-06-20 | 2005-06-20 | 1d | 46d | start no earlier than 2005-06-20 | {C4E6DC27-CAA9-4E6F-8C0D-0B3FF54C2505} |
| 667 | 7.2.2.26 | Maintain issue management logs 26 | 1d | 2005-06-27 | 2005-06-27 | 2005-06-27 | 2005-06-27 | 1d | 41d | start no earlier than 2005-06-27 | {1CFD24E3-313C-4BDF-AF51-E09B1BFA06A2} |
| 668 | 7.2.2.27 | Maintain issue management logs 27 | 1d | 2005-07-04 | 2005-07-04 | 2005-07-04 | 2005-07-04 | 1d | 36d | start no earlier than 2005-07-04 | {217D24F4-438B-4CA9-9C6D-31E873444EA5} |
| 669 | 7.2.2.28 | Maintain issue management logs 28 | 1d | 2005-07-11 | 2005-07-11 | 2005-07-11 | 2005-07-11 | 1d | 31d | start no earlier than 2005-07-11 | {A3BAC69D-E407-4441-B9BC-40BB6CA4CAA8} |
| 670 | 7.2.2.29 | Maintain issue management logs 29 | 1d | 2005-07-18 | 2005-07-18 | 2005-07-18 | 2005-07-18 | 1d | 26d | start no earlier than 2005-07-18 | {11A9ACDC-E5F8-4139-945C-3E9E952E52E8} |
| 671 | 7.2.2.30 | Maintain issue management logs 30 | 1d | 2005-07-25 | 2005-07-25 | 2005-07-25 | 2005-07-25 | 1d | 21d | start no earlier than 2005-07-25 | {426EB099-722C-48AB-BA57-CCBA5979035C} |
| 672 | 7.2.2.31 | Maintain issue management logs 31 | 1d | 2005-08-01 | 2005-08-01 | 2005-08-01 | 2005-08-01 | 1d | 16d | start no earlier than 2005-08-01 | {5AA5B8F9-1FD6-455A-AB47-61FCE2261006} |
| 673 | 7.2.2.32 | Maintain issue management logs 32 | 1d | 2005-08-08 | 2005-08-08 | 2005-08-08 | 2005-08-08 | 1d | 11d | start no earlier than 2005-08-08 | {1F020799-0671-4DC4-AC5F-9FA4DC80D095} |
| 674 | 7.2.2.33 | Maintain issue management logs 33 | 1d | 2005-08-15 | 2005-08-15 | 2005-08-15 | 2005-08-15 | 1d | 6d | start no earlier than 2005-08-15 | {D0F340F9-C3DE-4582-817C-6DE4705380B3} |
| 675 | 7.2.2.34 | Maintain issue management logs 34 | 1d | 2005-08-22 | 2005-08-22 | 2005-08-22 | 2005-08-22 | 1d | 1d | start no earlier than 2005-08-22 | {10F72EA1-D3EF-4149-8653-E6A5371E25C8} |

Notes:
- 641: Text3: <sync-guid>{090F6D65-4FDF-4A8A-956F-F83710F62CBC}</sync-guid><sync-parentguid>{55A6A8DD-D0E3-4E39-AE60-4750F7DD10C2}</sync-parentguid><sync-checksum>21136550</sync-checksum><sync-rootid>0</sync-rootid><sync-itemtype>0</sync-itemtype><sync-timestamp>12/30 / Text5: 2004 1:13:12 PM</sync-timestamp><sync-itemid>741</sync-itemid><sync-prioritymapping>0:0-0/1:700-1000/2:300-699/3:1-299</sync-prioritymapping>
- 642: Text3: <sync-guid>{720773BE-803E-43BE-BB68-98E9D2990B18}</sync-guid><sync-parentguid>{090F6D65-4FDF-4A8A-956F-F83710F62CBC}</sync-parentguid><sync-checksum>1632267608</sync-checksum><sync-rootid>0</sync-rootid><sync-itemtype>0</sync-itemtype><sync-timestamp>12/3 / Text5: 0/2004 1:13:08 PM</sync-timestamp><sync-itemid>742</sync-itemid><sync-prioritymapping>0:0-0/1:700-1000/2:300-699/3:1-299</sync-prioritymapping>
- 643: Text3: <sync-guid>{B577CC30-E607-44FD-B247-4270B288B91E}</sync-guid><sync-parentguid>{090F6D65-4FDF-4A8A-956F-F83710F62CBC}</sync-parentguid><sync-checksum>1902158390</sync-checksum><sync-rootid>0</sync-rootid><sync-itemtype>0</sync-itemtype><sync-timestamp>12/2 / Text5: 1/2004 9:45:17 AM</sync-timestamp><sync-itemid>743</sync-itemid><sync-prioritymapping>0:0-0/1:700-1000/2:300-699/3:1-299</sync-prioritymapping>
- 644: Text3: <sync-guid>{2AB9B46F-4558-441A-B9BA-884C5602D697}</sync-guid><sync-parentguid>{090F6D65-4FDF-4A8A-956F-F83710F62CBC}</sync-parentguid><sync-checksum>-208369174</sync-checksum><sync-rootid>0</sync-rootid><sync-itemtype>0</sync-itemtype><sync-timestamp>12/2 / Text5: 1/2004 9:45:17 AM</sync-timestamp><sync-itemid>744</sync-itemid><sync-prioritymapping>0:0-0/1:700-1000/2:300-699/3:1-299</sync-prioritymapping>
- 645: Text3: <sync-guid>{52C13301-5D23-400A-A73E-A7E551FC48F0}</sync-guid><sync-parentguid>{090F6D65-4FDF-4A8A-956F-F83710F62CBC}</sync-parentguid><sync-checksum>-2001811779</sync-checksum><sync-rootid>0</sync-rootid><sync-itemtype>0</sync-itemtype><sync-timestamp>12 / Text5: 21/2004 9:45:17 AM</sync-timestamp><sync-itemid>745</sync-itemid><sync-prioritymapping>0:0-0/1:700-1000/2:300-699/3:1-299</sync-prioritymapping>
- 646: Text3: <sync-guid>{406208EB-D767-40B7-B9D0-3036B299A197}</sync-guid><sync-parentguid>{090F6D65-4FDF-4A8A-956F-F83710F62CBC}</sync-parentguid><sync-checksum>1860394857</sync-checksum><sync-rootid>0</sync-rootid><sync-itemtype>0</sync-itemtype><sync-timestamp>12/2 / Text5: 1/2004 9:45:17 AM</sync-timestamp><sync-itemid>746</sync-itemid><sync-prioritymapping>0:0-0/1:700-1000/2:300-699/3:1-299</sync-prioritymapping>
- 647: Text3: <sync-guid>{0FEDF510-0871-4DFD-811E-263BC574730F}</sync-guid><sync-parentguid>{090F6D65-4FDF-4A8A-956F-F83710F62CBC}</sync-parentguid><sync-checksum>-69189040</sync-checksum><sync-rootid>0</sync-rootid><sync-itemtype>0</sync-itemtype><sync-timestamp>12/21 / Text5: 2004 9:45:17 AM</sync-timestamp><sync-itemid>747</sync-itemid><sync-prioritymapping>0:0-0/1:700-1000/2:300-699/3:1-299</sync-prioritymapping>
- 648: Text3: <sync-guid>{9B4A5F6B-56BC-4221-90C0-53872890E5B2}</sync-guid><sync-parentguid>{090F6D65-4FDF-4A8A-956F-F83710F62CBC}</sync-parentguid><sync-checksum>1991500721</sync-checksum><sync-rootid>0</sync-rootid><sync-itemtype>0</sync-itemtype><sync-timestamp>12/2 / Text5: 1/2004 9:45:17 AM</sync-timestamp><sync-itemid>748</sync-itemid><sync-prioritymapping>0:0-0/1:700-1000/2:300-699/3:1-299</sync-prioritymapping>
- 649: Text3: <sync-guid>{C5191B07-3405-4000-9E22-E11486103E30}</sync-guid><sync-parentguid>{090F6D65-4FDF-4A8A-956F-F83710F62CBC}</sync-parentguid><sync-checksum>-539708717</sync-checksum><sync-rootid>0</sync-rootid><sync-itemtype>0</sync-itemtype><sync-timestamp>12/2 / Text5: 1/2004 9:45:17 AM</sync-timestamp><sync-itemid>749</sync-itemid><sync-prioritymapping>0:0-0/1:700-1000/2:300-699/3:1-299</sync-prioritymapping>
- 650: Text3: <sync-guid>{339511D4-EEE2-4470-AC2B-805BCB1FB2A1}</sync-guid><sync-parentguid>{090F6D65-4FDF-4A8A-956F-F83710F62CBC}</sync-parentguid><sync-checksum>-1377238666</sync-checksum><sync-rootid>0</sync-rootid><sync-itemtype>0</sync-itemtype><sync-timestamp>12 / Text5: 21/2004 9:45:18 AM</sync-timestamp><sync-itemid>750</sync-itemid><sync-prioritymapping>0:0-0/1:700-1000/2:300-699/3:1-299</sync-prioritymapping>
- 651: Text3: <sync-guid>{AEA089CC-B055-48B5-BBC6-89C742ECFBB0}</sync-guid><sync-parentguid>{090F6D65-4FDF-4A8A-956F-F83710F62CBC}</sync-parentguid><sync-checksum>-31454378</sync-checksum><sync-rootid>0</sync-rootid><sync-itemtype>0</sync-itemtype><sync-timestamp>12/21 / Text5: 2004 9:45:18 AM</sync-timestamp><sync-itemid>751</sync-itemid><sync-prioritymapping>0:0-0/1:700-1000/2:300-699/3:1-299</sync-prioritymapping>
- 652: Text3: <sync-guid>{9826CA55-18C1-4114-AEF8-8BB0CC44E086}</sync-guid><sync-parentguid>{090F6D65-4FDF-4A8A-956F-F83710F62CBC}</sync-parentguid><sync-checksum>1936960183</sync-checksum><sync-rootid>0</sync-rootid><sync-itemtype>0</sync-itemtype><sync-timestamp>12/2 / Text5: 1/2004 9:45:18 AM</sync-timestamp><sync-itemid>752</sync-itemid><sync-prioritymapping>0:0-0/1:700-1000/2:300-699/3:1-299</sync-prioritymapping>
- 653: Text3: <sync-guid>{7B29F685-62D7-4B97-968A-5FAAD32A2C69}</sync-guid><sync-parentguid>{090F6D65-4FDF-4A8A-956F-F83710F62CBC}</sync-parentguid><sync-checksum>1073106645</sync-checksum><sync-rootid>0</sync-rootid><sync-itemtype>0</sync-itemtype><sync-timestamp>12/2 / Text5: 1/2004 9:45:18 AM</sync-timestamp><sync-itemid>753</sync-itemid><sync-prioritymapping>0:0-0/1:700-1000/2:300-699/3:1-299</sync-prioritymapping>
- 654: Text3: <sync-guid>{2A42875E-3DB9-4D38-9BD6-41E005B239B4}</sync-guid><sync-parentguid>{090F6D65-4FDF-4A8A-956F-F83710F62CBC}</sync-parentguid><sync-checksum>1305214320</sync-checksum><sync-rootid>0</sync-rootid><sync-itemtype>0</sync-itemtype><sync-timestamp>12/2 / Text5: 1/2004 9:45:18 AM</sync-timestamp><sync-itemid>754</sync-itemid><sync-prioritymapping>0:0-0/1:700-1000/2:300-699/3:1-299</sync-prioritymapping>
- 655: Text3: <sync-guid>{B2216BA8-98C8-4315-A101-D181B6A1AB7B}</sync-guid><sync-parentguid>{090F6D65-4FDF-4A8A-956F-F83710F62CBC}</sync-parentguid><sync-checksum>2034505329</sync-checksum><sync-rootid>0</sync-rootid><sync-itemtype>0</sync-itemtype><sync-timestamp>12/2 / Text5: 1/2004 9:45:18 AM</sync-timestamp><sync-itemid>755</sync-itemid><sync-prioritymapping>0:0-0/1:700-1000/2:300-699/3:1-299</sync-prioritymapping>
- 656: Text3: <sync-guid>{941796B3-0E20-4393-8E75-DDB0884FB244}</sync-guid><sync-parentguid>{090F6D65-4FDF-4A8A-956F-F83710F62CBC}</sync-parentguid><sync-checksum>-1626763355</sync-checksum><sync-rootid>0</sync-rootid><sync-itemtype>0</sync-itemtype><sync-timestamp>12 / Text5: 21/2004 9:45:18 AM</sync-timestamp><sync-itemid>756</sync-itemid><sync-prioritymapping>0:0-0/1:700-1000/2:300-699/3:1-299</sync-prioritymapping>
- 657: Text3: <sync-guid>{E523B191-CCD7-4065-8994-A0F6292ED9A1}</sync-guid><sync-parentguid>{090F6D65-4FDF-4A8A-956F-F83710F62CBC}</sync-parentguid><sync-checksum>-1016793728</sync-checksum><sync-rootid>0</sync-rootid><sync-itemtype>0</sync-itemtype><sync-timestamp>12 / Text5: 21/2004 9:45:18 AM</sync-timestamp><sync-itemid>757</sync-itemid><sync-prioritymapping>0:0-0/1:700-1000/2:300-699/3:1-299</sync-prioritymapping>
- 658: Text3: <sync-guid>{C3CA86D8-919C-4EB2-8A42-560784484563}</sync-guid><sync-parentguid>{090F6D65-4FDF-4A8A-956F-F83710F62CBC}</sync-parentguid><sync-checksum>979793966</sync-checksum><sync-rootid>0</sync-rootid><sync-itemtype>0</sync-itemtype><sync-timestamp>12/21 / Text5: 2004 9:45:18 AM</sync-timestamp><sync-itemid>758</sync-itemid><sync-prioritymapping>0:0-0/1:700-1000/2:300-699/3:1-299</sync-prioritymapping>
- 659: Text3: <sync-guid>{58DBC5CA-F613-46CF-BE24-F29A742C7D8E}</sync-guid><sync-parentguid>{090F6D65-4FDF-4A8A-956F-F83710F62CBC}</sync-parentguid><sync-checksum>-148355429</sync-checksum><sync-rootid>0</sync-rootid><sync-itemtype>0</sync-itemtype><sync-timestamp>12/2 / Text5: 1/2004 9:45:18 AM</sync-timestamp><sync-itemid>759</sync-itemid><sync-prioritymapping>0:0-0/1:700-1000/2:300-699/3:1-299</sync-prioritymapping>
- 660: Text3: <sync-guid>{F9C198E8-4FD1-4419-B083-2A517B562333}</sync-guid><sync-parentguid>{090F6D65-4FDF-4A8A-956F-F83710F62CBC}</sync-parentguid><sync-checksum>-1545593555</sync-checksum><sync-rootid>0</sync-rootid><sync-itemtype>0</sync-itemtype><sync-timestamp>12 / Text5: 21/2004 9:45:18 AM</sync-timestamp><sync-itemid>760</sync-itemid><sync-prioritymapping>0:0-0/1:700-1000/2:300-699/3:1-299</sync-prioritymapping>
- 661: Text3: <sync-guid>{37DABF99-0DDF-4D19-A6BE-C9C1C264F3B3}</sync-guid><sync-parentguid>{090F6D65-4FDF-4A8A-956F-F83710F62CBC}</sync-parentguid><sync-checksum>925488027</sync-checksum><sync-rootid>0</sync-rootid><sync-itemtype>0</sync-itemtype><sync-timestamp>12/21 / Text5: 2004 9:45:19 AM</sync-timestamp><sync-itemid>761</sync-itemid><sync-prioritymapping>0:0-0/1:700-1000/2:300-699/3:1-299</sync-prioritymapping>
- 662: Text3: <sync-guid>{B2722673-8803-4267-893E-E519EECC8621}</sync-guid><sync-parentguid>{090F6D65-4FDF-4A8A-956F-F83710F62CBC}</sync-parentguid><sync-checksum>1442643577</sync-checksum><sync-rootid>0</sync-rootid><sync-itemtype>0</sync-itemtype><sync-timestamp>12/2 / Text5: 1/2004 9:45:19 AM</sync-timestamp><sync-itemid>762</sync-itemid><sync-prioritymapping>0:0-0/1:700-1000/2:300-699/3:1-299</sync-prioritymapping>
- 663: Text3: <sync-guid>{19A671B1-1DE6-4B06-8F8F-C90187350D65}</sync-guid><sync-parentguid>{090F6D65-4FDF-4A8A-956F-F83710F62CBC}</sync-parentguid><sync-checksum>-151022056</sync-checksum><sync-rootid>0</sync-rootid><sync-itemtype>0</sync-itemtype><sync-timestamp>12/2 / Text5: 1/2004 9:45:19 AM</sync-timestamp><sync-itemid>763</sync-itemid><sync-prioritymapping>0:0-0/1:700-1000/2:300-699/3:1-299</sync-prioritymapping>
- 664: Text3: <sync-guid>{C3651966-58CA-42FD-8922-48C53A84F0B5}</sync-guid><sync-parentguid>{090F6D65-4FDF-4A8A-956F-F83710F62CBC}</sync-parentguid><sync-checksum>1303134881</sync-checksum><sync-rootid>0</sync-rootid><sync-itemtype>0</sync-itemtype><sync-timestamp>12/2 / Text5: 1/2004 9:45:19 AM</sync-timestamp><sync-itemid>764</sync-itemid><sync-prioritymapping>0:0-0/1:700-1000/2:300-699/3:1-299</sync-prioritymapping>
- 665: Text3: <sync-guid>{BC213B23-CBF0-48BE-95B3-EE6A545CF8EA}</sync-guid><sync-parentguid>{090F6D65-4FDF-4A8A-956F-F83710F62CBC}</sync-parentguid><sync-checksum>-653229579</sync-checksum><sync-rootid>0</sync-rootid><sync-itemtype>0</sync-itemtype><sync-timestamp>12/2 / Text5: 1/2004 9:45:19 AM</sync-timestamp><sync-itemid>890</sync-itemid><sync-prioritymapping>0:0-0/1:700-1000/2:300-699/3:1-299</sync-prioritymapping>
- 666: Text3: <sync-guid>{C4E6DC27-CAA9-4E6F-8C0D-0B3FF54C2505}</sync-guid><sync-parentguid>{090F6D65-4FDF-4A8A-956F-F83710F62CBC}</sync-parentguid><sync-checksum>-790916062</sync-checksum><sync-rootid>0</sync-rootid><sync-itemtype>0</sync-itemtype><sync-timestamp>12/2 / Text5: 1/2004 9:45:19 AM</sync-timestamp><sync-itemid>891</sync-itemid><sync-prioritymapping>0:0-0/1:700-1000/2:300-699/3:1-299</sync-prioritymapping>
- 667: Text3: <sync-guid>{1CFD24E3-313C-4BDF-AF51-E09B1BFA06A2}</sync-guid><sync-parentguid>{090F6D65-4FDF-4A8A-956F-F83710F62CBC}</sync-parentguid><sync-checksum>2088728190</sync-checksum><sync-rootid>0</sync-rootid><sync-itemtype>0</sync-itemtype><sync-timestamp>12/3 / Text5: 0/2004 1:09:47 PM</sync-timestamp><sync-itemid>1112</sync-itemid><sync-prioritymapping>0:0-0/1:700-1000/2:300-699/3:1-299</sync-prioritymapping>
- 668: Text3: <sync-guid>{217D24F4-438B-4CA9-9C6D-31E873444EA5}</sync-guid><sync-parentguid>{090F6D65-4FDF-4A8A-956F-F83710F62CBC}</sync-parentguid><sync-checksum>929621101</sync-checksum><sync-rootid>0</sync-rootid><sync-itemtype>0</sync-itemtype><sync-timestamp>12/30 / Text5: 2004 1:09:47 PM</sync-timestamp><sync-itemid>1113</sync-itemid><sync-prioritymapping>0:0-0/1:700-1000/2:300-699/3:1-299</sync-prioritymapping>
- 669: Text3: <sync-guid>{A3BAC69D-E407-4441-B9BC-40BB6CA4CAA8}</sync-guid><sync-parentguid>{090F6D65-4FDF-4A8A-956F-F83710F62CBC}</sync-parentguid><sync-checksum>446103865</sync-checksum><sync-rootid>0</sync-rootid><sync-itemtype>0</sync-itemtype><sync-timestamp>12/30 / Text5: 2004 1:09:48 PM</sync-timestamp><sync-itemid>1114</sync-itemid><sync-prioritymapping>0:0-0/1:700-1000/2:300-699/3:1-299</sync-prioritymapping>
- 670: Text3: <sync-guid>{11A9ACDC-E5F8-4139-945C-3E9E952E52E8}</sync-guid><sync-parentguid>{090F6D65-4FDF-4A8A-956F-F83710F62CBC}</sync-parentguid><sync-checksum>1756017308</sync-checksum><sync-rootid>0</sync-rootid><sync-itemtype>0</sync-itemtype><sync-timestamp>12/3 / Text5: 0/2004 1:09:48 PM</sync-timestamp><sync-itemid>1176</sync-itemid><sync-prioritymapping>0:0-0/1:700-1000/2:300-699/3:1-299</sync-prioritymapping>
- 671: Text3: <sync-guid>{426EB099-722C-48AB-BA57-CCBA5979035C}</sync-guid><sync-parentguid>{090F6D65-4FDF-4A8A-956F-F83710F62CBC}</sync-parentguid><sync-checksum>-1281821722</sync-checksum><sync-rootid>0</sync-rootid><sync-itemtype>0</sync-itemtype><sync-timestamp>12 / Text5: 30/2004 1:09:48 PM</sync-timestamp><sync-itemid>1177</sync-itemid><sync-prioritymapping>0:0-0/1:700-1000/2:300-699/3:1-299</sync-prioritymapping>
- 672: Text3: <sync-guid>{5AA5B8F9-1FD6-455A-AB47-61FCE2261006}</sync-guid><sync-parentguid>{090F6D65-4FDF-4A8A-956F-F83710F62CBC}</sync-parentguid><sync-checksum>1790381267</sync-checksum><sync-rootid>0</sync-rootid><sync-itemtype>0</sync-itemtype><sync-timestamp>12/3 / Text5: 0/2004 1:09:49 PM</sync-timestamp><sync-itemid>1178</sync-itemid><sync-prioritymapping>0:0-0/1:700-1000/2:300-699/3:1-299</sync-prioritymapping>
- 673: Text3: <sync-guid>{1F020799-0671-4DC4-AC5F-9FA4DC80D095}</sync-guid><sync-parentguid>{090F6D65-4FDF-4A8A-956F-F83710F62CBC}</sync-parentguid><sync-checksum>920286966</sync-checksum><sync-rootid>0</sync-rootid><sync-itemtype>0</sync-itemtype><sync-timestamp>12/30 / Text5: 2004 1:09:49 PM</sync-timestamp><sync-itemid>1273</sync-itemid><sync-prioritymapping>0:0-0/1:700-1000/2:300-699/3:1-299</sync-prioritymapping>
- 674: Text3: <sync-guid>{D0F340F9-C3DE-4582-817C-6DE4705380B3}</sync-guid><sync-parentguid>{090F6D65-4FDF-4A8A-956F-F83710F62CBC}</sync-parentguid><sync-checksum>1262505838</sync-checksum><sync-rootid>0</sync-rootid><sync-itemtype>0</sync-itemtype><sync-timestamp>12/3 / Text5: 0/2004 1:09:49 PM</sync-timestamp><sync-itemid>1274</sync-itemid><sync-prioritymapping>0:0-0/1:700-1000/2:300-699/3:1-299</sync-prioritymapping>
- 675: Text3: <sync-guid>{10F72EA1-D3EF-4149-8653-E6A5371E25C8}</sync-guid><sync-parentguid>{090F6D65-4FDF-4A8A-956F-F83710F62CBC}</sync-parentguid><sync-checksum>2106707999</sync-checksum><sync-rootid>0</sync-rootid><sync-itemtype>0</sync-itemtype><sync-timestamp>12/3 / Text5: 0/2004 1:09:50 PM</sync-timestamp><sync-itemid>1275</sync-itemid><sync-prioritymapping>0:0-0/1:700-1000/2:300-699/3:1-299</sync-prioritymapping>

| ID | WBS | Task | Duration | Start | Finish | Baseline start | Baseline finish | Baseline duration | Total slack | Constraint | Text4 |
| --- | --- | --- | --- | --- | --- | --- | --- | --- | --- | --- | --- |
| 676 | 7.2.3 | **Maintain change logs** | 163d | 2005-01-06 | 2005-08-22 | 2005-01-06 | 2005-08-22 | 163d | 1d |  | {D8594CA6-D29D-4D78-9D78-480A05C24257} |
| 677 | 7.2.3.1 | Maintain project change log 1 | 1d | 2005-01-06 | 2005-01-06 | 2005-01-06 | 2005-01-06 | 1d | 163d | start no earlier than 2005-01-03 | {B6120013-DB0B-4EA7-8691-8BC4DD683EBB} |
| 678 | 7.2.3.2 | Maintain project change log 2 | 1d | 2005-01-10 | 2005-01-10 | 2005-01-10 | 2005-01-10 | 1d | 161d | start no earlier than 2005-01-10 | {2E2DCC65-2373-427C-B06D-9CC619B23627} |
| 679 | 7.2.3.3 | Maintain project change log 3 | 1d | 2005-01-17 | 2005-01-17 | 2005-01-17 | 2005-01-17 | 1d | 156d | start no earlier than 2005-01-17 | {F31C204A-C9A1-4289-9887-3CFA7CF63E7E} |
| 680 | 7.2.3.4 | Maintain project change log 4 | 1d | 2005-01-24 | 2005-01-24 | 2005-01-24 | 2005-01-24 | 1d | 151d | start no earlier than 2005-01-24 | {1C59CD8D-EC20-40C3-B328-4600C43A7FE0} |
| 681 | 7.2.3.5 | Maintain project change log 5 | 1d | 2005-01-31 | 2005-01-31 | 2005-01-31 | 2005-01-31 | 1d | 146d | start no earlier than 2005-01-31 | {2360FA4B-A1E8-48C3-9D95-082FC675CAE2} |
| 682 | 7.2.3.6 | Maintain project change log 6 | 1d | 2005-02-07 | 2005-02-07 | 2005-02-07 | 2005-02-07 | 1d | 141d | start no earlier than 2005-02-07 | {F2549BE2-C736-48BA-A0AD-8B9ABE1C1953} |
| 683 | 7.2.3.7 | Maintain project change log 7 | 1d | 2005-02-14 | 2005-02-14 | 2005-02-14 | 2005-02-14 | 1d | 136d | start no earlier than 2005-02-14 | {F5B27129-BCC6-4135-B48B-0799E1B09329} |
| 684 | 7.2.3.8 | Maintain project change log 8 | 1d | 2005-02-21 | 2005-02-21 | 2005-02-21 | 2005-02-21 | 1d | 131d | start no earlier than 2005-02-21 | {60A7BCDB-050F-4495-8C77-D11C5B93EF91} |
| 685 | 7.2.3.9 | Maintain project change log 9 | 1d | 2005-02-28 | 2005-02-28 | 2005-02-28 | 2005-02-28 | 1d | 126d | start no earlier than 2005-02-28 | {F1F92502-9A27-4F2B-98F1-3BEE6C5F911F} |
| 686 | 7.2.3.10 | Maintain project change log 10 | 1d | 2005-03-07 | 2005-03-07 | 2005-03-07 | 2005-03-07 | 1d | 121d | start no earlier than 2005-03-07 | {74E34D1F-9165-49F1-9391-044BF3D8356E} |
| 687 | 7.2.3.11 | Maintain project change log 11 | 1d | 2005-03-14 | 2005-03-14 | 2005-03-14 | 2005-03-14 | 1d | 116d | start no earlier than 2005-03-14 | {84668A64-067D-4C64-8FC4-CB5121F5BF02} |
| 688 | 7.2.3.12 | Maintain project change log 12 | 1d | 2005-03-21 | 2005-03-21 | 2005-03-21 | 2005-03-21 | 1d | 111d | start no earlier than 2005-03-21 | {F01AA695-B0C2-48BC-AA0D-6A2D6BCEB2DD} |
| 689 | 7.2.3.13 | Maintain project change log 13 | 1d | 2005-03-28 | 2005-03-28 | 2005-03-28 | 2005-03-28 | 1d | 106d | start no earlier than 2005-03-28 | {BC07B35D-BCFE-43A7-AB56-3CB377BE238F} |
| 690 | 7.2.3.14 | Maintain project change log 14 | 1d | 2005-04-04 | 2005-04-04 | 2005-04-04 | 2005-04-04 | 1d | 101d | start no earlier than 2005-04-04 | {23DFCA54-BB64-48B3-B5B8-2A37F82D429B} |
| 691 | 7.2.3.15 | Maintain project change log 15 | 1d | 2005-04-11 | 2005-04-11 | 2005-04-11 | 2005-04-11 | 1d | 96d | start no earlier than 2005-04-11 | {A9FE702D-F2CB-4591-8EF6-EC58BA6C46D8} |
| 692 | 7.2.3.16 | Maintain project change log 16 | 1d | 2005-04-18 | 2005-04-18 | 2005-04-18 | 2005-04-18 | 1d | 91d | start no earlier than 2005-04-18 | {403C0DE0-3CC1-4A23-981E-55AEB20EE8DD} |
| 693 | 7.2.3.17 | Maintain project change log 17 | 1d | 2005-04-25 | 2005-04-25 | 2005-04-25 | 2005-04-25 | 1d | 86d | start no earlier than 2005-04-25 | {8C636B42-0719-4804-9164-49284ACE5093} |
| 694 | 7.2.3.18 | Maintain project change log 18 | 1d | 2005-05-02 | 2005-05-02 | 2005-05-02 | 2005-05-02 | 1d | 81d | start no earlier than 2005-05-02 | {63998E65-FF5D-421C-BD29-0AD2390F7446} |
| 695 | 7.2.3.19 | Maintain project change log 19 | 1d | 2005-05-09 | 2005-05-09 | 2005-05-09 | 2005-05-09 | 1d | 76d | start no earlier than 2005-05-09 | {A8D8DD3B-C705-4282-AD9D-F09A64779399} |
| 696 | 7.2.3.20 | Maintain project change log 20 | 1d | 2005-05-16 | 2005-05-16 | 2005-05-16 | 2005-05-16 | 1d | 71d | start no earlier than 2005-05-16 | {975FA7C2-B03B-42C6-84C5-32F0D44BB1D1} |
| 697 | 7.2.3.21 | Maintain project change log 21 | 1d | 2005-05-23 | 2005-05-23 | 2005-05-23 | 2005-05-23 | 1d | 66d | start no earlier than 2005-05-23 | {57A95FDA-B666-42F8-B1E0-BA47BCF87F4F} |
| 698 | 7.2.3.22 | Maintain project change log 22 | 1d | 2005-05-30 | 2005-05-30 | 2005-05-30 | 2005-05-30 | 1d | 61d | start no earlier than 2005-05-30 | {D1B98AD4-5852-4EF7-A750-54150816E535} |
| 699 | 7.2.3.23 | Maintain project change log 23 | 1d | 2005-06-06 | 2005-06-06 | 2005-06-06 | 2005-06-06 | 1d | 56d | start no earlier than 2005-06-06 | {B1C29485-75A4-448D-8C88-47E140EA1FD2} |
| 700 | 7.2.3.24 | Maintain project change logs 24 | 1d | 2005-06-13 | 2005-06-13 | 2005-06-13 | 2005-06-13 | 1d | 51d | start no earlier than 2005-06-13 | {99B50628-5664-4344-9170-5B8C25EB4171} |
| 701 | 7.2.3.25 | Maintain project change logs 25 | 1d | 2005-06-20 | 2005-06-20 | 2005-06-20 | 2005-06-20 | 1d | 46d | start no earlier than 2005-06-20 | {E44A23C4-A136-419B-B67F-97E255C6C4C4} |
| 702 | 7.2.3.26 | Maintain change logs 26 | 1d | 2005-06-27 | 2005-06-27 | 2005-06-27 | 2005-06-27 | 1d | 41d | start no earlier than 2005-06-27 | {55CB37CC-57BC-4F40-B5D3-A35BAB1016DF} |
| 703 | 7.2.3.27 | Maintain change logs 27 | 1d | 2005-07-04 | 2005-07-04 | 2005-07-04 | 2005-07-04 | 1d | 36d | start no earlier than 2005-07-04 | {BAB805E9-F5F0-40AE-98DB-A652949CFEB8} |
| 704 | 7.2.3.28 | Maintain change logs 28 | 1d | 2005-07-11 | 2005-07-11 | 2005-07-11 | 2005-07-11 | 1d | 31d | start no earlier than 2005-07-11 | {E18AED17-BDC9-46B4-B652-40727D4D2BA4} |
| 705 | 7.2.3.29 | Maintain change logs 29 | 1d | 2005-07-18 | 2005-07-18 | 2005-07-18 | 2005-07-18 | 1d | 26d | start no earlier than 2005-07-18 | {EDEC8DD9-51DC-427E-9E0D-E1613AD9255B} |
| 706 | 7.2.3.30 | Maintain change logs 30 | 1d | 2005-07-25 | 2005-07-25 | 2005-07-25 | 2005-07-25 | 1d | 21d | start no earlier than 2005-07-25 | {60433AAC-396C-4942-B071-40ED9A026DE5} |
| 707 | 7.2.3.31 | Maintain change logs 31 | 1d | 2005-08-01 | 2005-08-01 | 2005-08-01 | 2005-08-01 | 1d | 16d | start no earlier than 2005-08-01 | {D1ABCA1E-76A6-45EE-A807-D48EE9CB1282} |
| 708 | 7.2.3.32 | Maintain change logs 32 | 1d | 2005-08-08 | 2005-08-08 | 2005-08-08 | 2005-08-08 | 1d | 11d | start no earlier than 2005-08-08 | {B6EF9192-40E3-41C1-A521-3C50C56CFE9C} |
| 709 | 7.2.3.33 | Maintain change logs 33 | 1d | 2005-08-15 | 2005-08-15 | 2005-08-15 | 2005-08-15 | 1d | 6d | start no earlier than 2005-08-15 | {7164FA29-76F1-46A0-A1D5-178F8FB0F3E2} |
| 710 | 7.2.3.34 | Maintain change logs 34 | 1d | 2005-08-22 | 2005-08-22 | 2005-08-22 | 2005-08-22 | 1d | 1d | start no earlier than 2005-08-22 | {F8A69A44-4153-4FBD-B9E1-68750DD66B08} |

Notes:
- 676: Text3: <sync-guid>{D8594CA6-D29D-4D78-9D78-480A05C24257}</sync-guid><sync-parentguid>{55A6A8DD-D0E3-4E39-AE60-4750F7DD10C2}</sync-parentguid><sync-checksum>-844902713</sync-checksum><sync-rootid>0</sync-rootid><sync-itemtype>0</sync-itemtype><sync-timestamp>12/3 / Text5: 0/2004 1:13:16 PM</sync-timestamp><sync-itemid>832</sync-itemid><sync-prioritymapping>0:0-0/1:700-1000/2:300-699/3:1-299</sync-prioritymapping>
- 677: Text3: <sync-guid>{B6120013-DB0B-4EA7-8691-8BC4DD683EBB}</sync-guid><sync-parentguid>{D8594CA6-D29D-4D78-9D78-480A05C24257}</sync-parentguid><sync-checksum>1239479048</sync-checksum><sync-rootid>0</sync-rootid><sync-itemtype>0</sync-itemtype><sync-timestamp>12/3 / Text5: 0/2004 1:13:12 PM</sync-timestamp><sync-itemid>833</sync-itemid><sync-prioritymapping>0:0-0/1:700-1000/2:300-699/3:1-299</sync-prioritymapping>
- 678: Text3: <sync-guid>{2E2DCC65-2373-427C-B06D-9CC619B23627}</sync-guid><sync-parentguid>{D8594CA6-D29D-4D78-9D78-480A05C24257}</sync-parentguid><sync-checksum>1506425958</sync-checksum><sync-rootid>0</sync-rootid><sync-itemtype>0</sync-itemtype><sync-timestamp>12/2 / Text5: 1/2004 9:45:19 AM</sync-timestamp><sync-itemid>834</sync-itemid><sync-prioritymapping>0:0-0/1:700-1000/2:300-699/3:1-299</sync-prioritymapping>
- 679: Text3: <sync-guid>{F31C204A-C9A1-4289-9887-3CFA7CF63E7E}</sync-guid><sync-parentguid>{D8594CA6-D29D-4D78-9D78-480A05C24257}</sync-parentguid><sync-checksum>-616687686</sync-checksum><sync-rootid>0</sync-rootid><sync-itemtype>0</sync-itemtype><sync-timestamp>12/2 / Text5: 1/2004 9:45:19 AM</sync-timestamp><sync-itemid>835</sync-itemid><sync-prioritymapping>0:0-0/1:700-1000/2:300-699/3:1-299</sync-prioritymapping>
- 680: Text3: <sync-guid>{1C59CD8D-EC20-40C3-B328-4600C43A7FE0}</sync-guid><sync-parentguid>{D8594CA6-D29D-4D78-9D78-480A05C24257}</sync-parentguid><sync-checksum>-1610327827</sync-checksum><sync-rootid>0</sync-rootid><sync-itemtype>0</sync-itemtype><sync-timestamp>12 / Text5: 21/2004 9:45:20 AM</sync-timestamp><sync-itemid>836</sync-itemid><sync-prioritymapping>0:0-0/1:700-1000/2:300-699/3:1-299</sync-prioritymapping>
- 681: Text3: <sync-guid>{2360FA4B-A1E8-48C3-9D95-082FC675CAE2}</sync-guid><sync-parentguid>{D8594CA6-D29D-4D78-9D78-480A05C24257}</sync-parentguid><sync-checksum>1179238713</sync-checksum><sync-rootid>0</sync-rootid><sync-itemtype>0</sync-itemtype><sync-timestamp>12/2 / Text5: 1/2004 9:45:20 AM</sync-timestamp><sync-itemid>837</sync-itemid><sync-prioritymapping>0:0-0/1:700-1000/2:300-699/3:1-299</sync-prioritymapping>
- 682: Text3: <sync-guid>{F2549BE2-C736-48BA-A0AD-8B9ABE1C1953}</sync-guid><sync-parentguid>{D8594CA6-D29D-4D78-9D78-480A05C24257}</sync-parentguid><sync-checksum>-750068736</sync-checksum><sync-rootid>0</sync-rootid><sync-itemtype>0</sync-itemtype><sync-timestamp>12/2 / Text5: 1/2004 9:45:20 AM</sync-timestamp><sync-itemid>838</sync-itemid><sync-prioritymapping>0:0-0/1:700-1000/2:300-699/3:1-299</sync-prioritymapping>
- 683: Text3: <sync-guid>{F5B27129-BCC6-4135-B48B-0799E1B09329}</sync-guid><sync-parentguid>{D8594CA6-D29D-4D78-9D78-480A05C24257}</sync-parentguid><sync-checksum>1578728929</sync-checksum><sync-rootid>0</sync-rootid><sync-itemtype>0</sync-itemtype><sync-timestamp>12/2 / Text5: 1/2004 9:45:20 AM</sync-timestamp><sync-itemid>839</sync-itemid><sync-prioritymapping>0:0-0/1:700-1000/2:300-699/3:1-299</sync-prioritymapping>
- 684: Text3: <sync-guid>{60A7BCDB-050F-4495-8C77-D11C5B93EF91}</sync-guid><sync-parentguid>{D8594CA6-D29D-4D78-9D78-480A05C24257}</sync-parentguid><sync-checksum>-142726013</sync-checksum><sync-rootid>0</sync-rootid><sync-itemtype>0</sync-itemtype><sync-timestamp>12/2 / Text5: 1/2004 9:45:20 AM</sync-timestamp><sync-itemid>840</sync-itemid><sync-prioritymapping>0:0-0/1:700-1000/2:300-699/3:1-299</sync-prioritymapping>
- 685: Text3: <sync-guid>{F1F92502-9A27-4F2B-98F1-3BEE6C5F911F}</sync-guid><sync-parentguid>{D8594CA6-D29D-4D78-9D78-480A05C24257}</sync-parentguid><sync-checksum>-2059165914</sync-checksum><sync-rootid>0</sync-rootid><sync-itemtype>0</sync-itemtype><sync-timestamp>12 / Text5: 21/2004 9:45:20 AM</sync-timestamp><sync-itemid>841</sync-itemid><sync-prioritymapping>0:0-0/1:700-1000/2:300-699/3:1-299</sync-prioritymapping>
- 686: Text3: <sync-guid>{74E34D1F-9165-49F1-9391-044BF3D8356E}</sync-guid><sync-parentguid>{D8594CA6-D29D-4D78-9D78-480A05C24257}</sync-parentguid><sync-checksum>-1788612548</sync-checksum><sync-rootid>0</sync-rootid><sync-itemtype>0</sync-itemtype><sync-timestamp>12 / Text5: 21/2004 9:45:20 AM</sync-timestamp><sync-itemid>842</sync-itemid><sync-prioritymapping>0:0-0/1:700-1000/2:300-699/3:1-299</sync-prioritymapping>
- 687: Text3: <sync-guid>{84668A64-067D-4C64-8FC4-CB5121F5BF02}</sync-guid><sync-parentguid>{D8594CA6-D29D-4D78-9D78-480A05C24257}</sync-parentguid><sync-checksum>405819869</sync-checksum><sync-rootid>0</sync-rootid><sync-itemtype>0</sync-itemtype><sync-timestamp>12/21 / Text5: 2004 9:45:20 AM</sync-timestamp><sync-itemid>843</sync-itemid><sync-prioritymapping>0:0-0/1:700-1000/2:300-699/3:1-299</sync-prioritymapping>
- 688: Text3: <sync-guid>{F01AA695-B0C2-48BC-AA0D-6A2D6BCEB2DD}</sync-guid><sync-parentguid>{D8594CA6-D29D-4D78-9D78-480A05C24257}</sync-parentguid><sync-checksum>1421194687</sync-checksum><sync-rootid>0</sync-rootid><sync-itemtype>0</sync-itemtype><sync-timestamp>12/2 / Text5: 1/2004 9:45:20 AM</sync-timestamp><sync-itemid>844</sync-itemid><sync-prioritymapping>0:0-0/1:700-1000/2:300-699/3:1-299</sync-prioritymapping>
- 689: Text3: <sync-guid>{BC07B35D-BCFE-43A7-AB56-3CB377BE238F}</sync-guid><sync-parentguid>{D8594CA6-D29D-4D78-9D78-480A05C24257}</sync-parentguid><sync-checksum>646448666</sync-checksum><sync-rootid>0</sync-rootid><sync-itemtype>0</sync-itemtype><sync-timestamp>12/21 / Text5: 2004 9:45:20 AM</sync-timestamp><sync-itemid>845</sync-itemid><sync-prioritymapping>0:0-0/1:700-1000/2:300-699/3:1-299</sync-prioritymapping>
- 690: Text3: <sync-guid>{23DFCA54-BB64-48B3-B5B8-2A37F82D429B}</sync-guid><sync-parentguid>{D8594CA6-D29D-4D78-9D78-480A05C24257}</sync-parentguid><sync-checksum>302509339</sync-checksum><sync-rootid>0</sync-rootid><sync-itemtype>0</sync-itemtype><sync-timestamp>12/21 / Text5: 2004 9:45:21 AM</sync-timestamp><sync-itemid>846</sync-itemid><sync-prioritymapping>0:0-0/1:700-1000/2:300-699/3:1-299</sync-prioritymapping>
- 691: Text3: <sync-guid>{A9FE702D-F2CB-4591-8EF6-EC58BA6C46D8}</sync-guid><sync-parentguid>{D8594CA6-D29D-4D78-9D78-480A05C24257}</sync-parentguid><sync-checksum>-196447025</sync-checksum><sync-rootid>0</sync-rootid><sync-itemtype>0</sync-itemtype><sync-timestamp>12/2 / Text5: 1/2004 9:45:21 AM</sync-timestamp><sync-itemid>847</sync-itemid><sync-prioritymapping>0:0-0/1:700-1000/2:300-699/3:1-299</sync-prioritymapping>
- 692: Text3: <sync-guid>{403C0DE0-3CC1-4A23-981E-55AEB20EE8DD}</sync-guid><sync-parentguid>{D8594CA6-D29D-4D78-9D78-480A05C24257}</sync-parentguid><sync-checksum>-1473835286</sync-checksum><sync-rootid>0</sync-rootid><sync-itemtype>0</sync-itemtype><sync-timestamp>12 / Text5: 21/2004 9:45:21 AM</sync-timestamp><sync-itemid>848</sync-itemid><sync-prioritymapping>0:0-0/1:700-1000/2:300-699/3:1-299</sync-prioritymapping>
- 693: Text3: <sync-guid>{8C636B42-0719-4804-9164-49284ACE5093}</sync-guid><sync-parentguid>{D8594CA6-D29D-4D78-9D78-480A05C24257}</sync-parentguid><sync-checksum>1361412932</sync-checksum><sync-rootid>0</sync-rootid><sync-itemtype>0</sync-itemtype><sync-timestamp>12/2 / Text5: 1/2004 9:45:21 AM</sync-timestamp><sync-itemid>849</sync-itemid><sync-prioritymapping>0:0-0/1:700-1000/2:300-699/3:1-299</sync-prioritymapping>
- 694: Text3: <sync-guid>{63998E65-FF5D-421C-BD29-0AD2390F7446}</sync-guid><sync-parentguid>{D8594CA6-D29D-4D78-9D78-480A05C24257}</sync-parentguid><sync-checksum>-1670660623</sync-checksum><sync-rootid>0</sync-rootid><sync-itemtype>0</sync-itemtype><sync-timestamp>12 / Text5: 21/2004 9:45:21 AM</sync-timestamp><sync-itemid>850</sync-itemid><sync-prioritymapping>0:0-0/1:700-1000/2:300-699/3:1-299</sync-prioritymapping>
- 695: Text3: <sync-guid>{A8D8DD3B-C705-4282-AD9D-F09A64779399}</sync-guid><sync-parentguid>{D8594CA6-D29D-4D78-9D78-480A05C24257}</sync-parentguid><sync-checksum>-928782777</sync-checksum><sync-rootid>0</sync-rootid><sync-itemtype>0</sync-itemtype><sync-timestamp>12/2 / Text5: 1/2004 9:45:21 AM</sync-timestamp><sync-itemid>851</sync-itemid><sync-prioritymapping>0:0-0/1:700-1000/2:300-699/3:1-299</sync-prioritymapping>
- 696: Text3: <sync-guid>{975FA7C2-B03B-42C6-84C5-32F0D44BB1D1}</sync-guid><sync-parentguid>{D8594CA6-D29D-4D78-9D78-480A05C24257}</sync-parentguid><sync-checksum>1550461169</sync-checksum><sync-rootid>0</sync-rootid><sync-itemtype>0</sync-itemtype><sync-timestamp>12/2 / Text5: 1/2004 9:45:21 AM</sync-timestamp><sync-itemid>852</sync-itemid><sync-prioritymapping>0:0-0/1:700-1000/2:300-699/3:1-299</sync-prioritymapping>
- 697: Text3: <sync-guid>{57A95FDA-B666-42F8-B1E0-BA47BCF87F4F}</sync-guid><sync-parentguid>{D8594CA6-D29D-4D78-9D78-480A05C24257}</sync-parentguid><sync-checksum>1052706067</sync-checksum><sync-rootid>0</sync-rootid><sync-itemtype>0</sync-itemtype><sync-timestamp>12/2 / Text5: 1/2004 9:45:21 AM</sync-timestamp><sync-itemid>853</sync-itemid><sync-prioritymapping>0:0-0/1:700-1000/2:300-699/3:1-299</sync-prioritymapping>
- 698: Text3: <sync-guid>{D1B98AD4-5852-4EF7-A750-54150816E535}</sync-guid><sync-parentguid>{D8594CA6-D29D-4D78-9D78-480A05C24257}</sync-parentguid><sync-checksum>-1648595598</sync-checksum><sync-rootid>0</sync-rootid><sync-itemtype>0</sync-itemtype><sync-timestamp>12 / Text5: 21/2004 9:45:21 AM</sync-timestamp><sync-itemid>854</sync-itemid><sync-prioritymapping>0:0-0/1:700-1000/2:300-699/3:1-299</sync-prioritymapping>
- 699: Text3: <sync-guid>{B1C29485-75A4-448D-8C88-47E140EA1FD2}</sync-guid><sync-parentguid>{D8594CA6-D29D-4D78-9D78-480A05C24257}</sync-parentguid><sync-checksum>653244875</sync-checksum><sync-rootid>0</sync-rootid><sync-itemtype>0</sync-itemtype><sync-timestamp>12/21 / Text5: 2004 9:45:21 AM</sync-timestamp><sync-itemid>855</sync-itemid><sync-prioritymapping>0:0-0/1:700-1000/2:300-699/3:1-299</sync-prioritymapping>
- 700: Text3: <sync-guid>{99B50628-5664-4344-9170-5B8C25EB4171}</sync-guid><sync-parentguid>{D8594CA6-D29D-4D78-9D78-480A05C24257}</sync-parentguid><sync-checksum>1313149448</sync-checksum><sync-rootid>0</sync-rootid><sync-itemtype>0</sync-itemtype><sync-timestamp>12/2 / Text5: 1/2004 9:45:22 AM</sync-timestamp><sync-itemid>892</sync-itemid><sync-prioritymapping>0:0-0/1:700-1000/2:300-699/3:1-299</sync-prioritymapping>
- 701: Text3: <sync-guid>{E44A23C4-A136-419B-B67F-97E255C6C4C4}</sync-guid><sync-parentguid>{D8594CA6-D29D-4D78-9D78-480A05C24257}</sync-parentguid><sync-checksum>1200490463</sync-checksum><sync-rootid>0</sync-rootid><sync-itemtype>0</sync-itemtype><sync-timestamp>12/2 / Text5: 1/2004 9:45:22 AM</sync-timestamp><sync-itemid>893</sync-itemid><sync-prioritymapping>0:0-0/1:700-1000/2:300-699/3:1-299</sync-prioritymapping>
- 702: Text3: <sync-guid>{55CB37CC-57BC-4F40-B5D3-A35BAB1016DF}</sync-guid><sync-parentguid>{D8594CA6-D29D-4D78-9D78-480A05C24257}</sync-parentguid><sync-checksum>1174849274</sync-checksum><sync-rootid>0</sync-rootid><sync-itemtype>0</sync-itemtype><sync-timestamp>12/3 / Text5: 0/2004 1:09:53 PM</sync-timestamp><sync-itemid>1115</sync-itemid><sync-prioritymapping>0:0-0/1:700-1000/2:300-699/3:1-299</sync-prioritymapping>
- 703: Text3: <sync-guid>{BAB805E9-F5F0-40AE-98DB-A652949CFEB8}</sync-guid><sync-parentguid>{D8594CA6-D29D-4D78-9D78-480A05C24257}</sync-parentguid><sync-checksum>219239657</sync-checksum><sync-rootid>0</sync-rootid><sync-itemtype>0</sync-itemtype><sync-timestamp>12/30 / Text5: 2004 1:09:53 PM</sync-timestamp><sync-itemid>1116</sync-itemid><sync-prioritymapping>0:0-0/1:700-1000/2:300-699/3:1-299</sync-prioritymapping>
- 704: Text3: <sync-guid>{E18AED17-BDC9-46B4-B652-40727D4D2BA4}</sync-guid><sync-parentguid>{D8594CA6-D29D-4D78-9D78-480A05C24257}</sync-parentguid><sync-checksum>552513981</sync-checksum><sync-rootid>0</sync-rootid><sync-itemtype>0</sync-itemtype><sync-timestamp>12/30 / Text5: 2004 1:09:54 PM</sync-timestamp><sync-itemid>1117</sync-itemid><sync-prioritymapping>0:0-0/1:700-1000/2:300-699/3:1-299</sync-prioritymapping>
- 705: Text3: <sync-guid>{EDEC8DD9-51DC-427E-9E0D-E1613AD9255B}</sync-guid><sync-parentguid>{D8594CA6-D29D-4D78-9D78-480A05C24257}</sync-parentguid><sync-checksum>1389560344</sync-checksum><sync-rootid>0</sync-rootid><sync-itemtype>0</sync-itemtype><sync-timestamp>12/3 / Text5: 0/2004 1:09:54 PM</sync-timestamp><sync-itemid>1179</sync-itemid><sync-prioritymapping>0:0-0/1:700-1000/2:300-699/3:1-299</sync-prioritymapping>
- 706: Text3: <sync-guid>{60433AAC-396C-4942-B071-40ED9A026DE5}</sync-guid><sync-parentguid>{D8594CA6-D29D-4D78-9D78-480A05C24257}</sync-parentguid><sync-checksum>-1981725854</sync-checksum><sync-rootid>0</sync-rootid><sync-itemtype>0</sync-itemtype><sync-timestamp>12 / Text5: 30/2004 1:09:55 PM</sync-timestamp><sync-itemid>1180</sync-itemid><sync-prioritymapping>0:0-0/1:700-1000/2:300-699/3:1-299</sync-prioritymapping>
- 707: Text3: <sync-guid>{D1ABCA1E-76A6-45EE-A807-D48EE9CB1282}</sync-guid><sync-parentguid>{D8594CA6-D29D-4D78-9D78-480A05C24257}</sync-parentguid><sync-checksum>1355725911</sync-checksum><sync-rootid>0</sync-rootid><sync-itemtype>0</sync-itemtype><sync-timestamp>12/3 / Text5: 0/2004 1:09:55 PM</sync-timestamp><sync-itemid>1181</sync-itemid><sync-prioritymapping>0:0-0/1:700-1000/2:300-699/3:1-299</sync-prioritymapping>
- 708: Text3: <sync-guid>{B6EF9192-40E3-41C1-A521-3C50C56CFE9C}</sync-guid><sync-parentguid>{D8594CA6-D29D-4D78-9D78-480A05C24257}</sync-parentguid><sync-checksum>212059762</sync-checksum><sync-rootid>0</sync-rootid><sync-itemtype>0</sync-itemtype><sync-timestamp>12/30 / Text5: 2004 1:09:55 PM</sync-timestamp><sync-itemid>1276</sync-itemid><sync-prioritymapping>0:0-0/1:700-1000/2:300-699/3:1-299</sync-prioritymapping>
- 709: Text3: <sync-guid>{7164FA29-76F1-46A0-A1D5-178F8FB0F3E2}</sync-guid><sync-parentguid>{D8594CA6-D29D-4D78-9D78-480A05C24257}</sync-parentguid><sync-checksum>1899626474</sync-checksum><sync-rootid>0</sync-rootid><sync-itemtype>0</sync-itemtype><sync-timestamp>12/3 / Text5: 0/2004 1:09:56 PM</sync-timestamp><sync-itemid>1277</sync-itemid><sync-prioritymapping>0:0-0/1:700-1000/2:300-699/3:1-299</sync-prioritymapping>
- 710: Text3: <sync-guid>{F8A69A44-4153-4FBD-B9E1-68750DD66B08}</sync-guid><sync-parentguid>{D8594CA6-D29D-4D78-9D78-480A05C24257}</sync-parentguid><sync-checksum>1206411419</sync-checksum><sync-rootid>0</sync-rootid><sync-itemtype>0</sync-itemtype><sync-timestamp>12/3 / Text5: 0/2004 1:09:56 PM</sync-timestamp><sync-itemid>1278</sync-itemid><sync-prioritymapping>0:0-0/1:700-1000/2:300-699/3:1-299</sync-prioritymapping>

| ID | WBS | Task | Duration | Start | Finish | Baseline start | Baseline finish | Baseline duration | Total slack | Constraint | Text4 |
| --- | --- | --- | --- | --- | --- | --- | --- | --- | --- | --- | --- |
| 711 | 7.2.4 | **Maintain defect logs** | 163d | 2005-01-06 | 2005-08-22 | 2005-01-06 | 2005-08-22 | 163d | 1d |  | {ABED82E4-CCEE-495A-B833-56BC4E6E5F96} |
| 712 | 7.2.4.1 | Maintain defect logs 1 | 1d | 2005-01-06 | 2005-01-06 | 2005-01-06 | 2005-01-06 | 1d | 163d | start no earlier than 2005-01-03 | {842055F5-D80D-4C49-B442-0E874A4C0043} |
| 713 | 7.2.4.2 | Maintain defect logs 2 | 1d | 2005-01-10 | 2005-01-10 | 2005-01-10 | 2005-01-10 | 1d | 161d | start no earlier than 2005-01-10 | {A9B845ED-8EB9-49CC-A215-731983E88AA5} |
| 714 | 7.2.4.3 | Maintain defect logs 3 | 1d | 2005-01-17 | 2005-01-17 | 2005-01-17 | 2005-01-17 | 1d | 156d | start no earlier than 2005-01-17 | {222D75E5-37EB-4BB7-9F16-BE7D01F44CEC} |
| 715 | 7.2.4.4 | Maintain defect logs 4 | 1d | 2005-01-24 | 2005-01-24 | 2005-01-24 | 2005-01-24 | 1d | 151d | start no earlier than 2005-01-24 | {A2685B35-072D-4D89-92A8-ECAB51F61826} |
| 716 | 7.2.4.5 | Maintain defect logs 5 | 1d | 2005-01-31 | 2005-01-31 | 2005-01-31 | 2005-01-31 | 1d | 146d | start no earlier than 2005-01-31 | {CE8A1543-6C6A-4282-8CE2-6371EC16BF74} |
| 717 | 7.2.4.6 | Maintain defect logs 6 | 1d | 2005-02-07 | 2005-02-07 | 2005-02-07 | 2005-02-07 | 1d | 141d | start no earlier than 2005-02-07 | {76646295-4B72-4B2B-9F09-6FB40E44BD21} |
| 718 | 7.2.4.7 | Maintain defect logs 7 | 1d | 2005-02-14 | 2005-02-14 | 2005-02-14 | 2005-02-14 | 1d | 136d | start no earlier than 2005-02-14 | {26E1262A-EFFC-48D5-9CC4-A51D4EA48603} |
| 719 | 7.2.4.8 | Maintain defect logs 8 | 1d | 2005-02-21 | 2005-02-21 | 2005-02-21 | 2005-02-21 | 1d | 131d | start no earlier than 2005-02-21 | {488843CF-FF70-41FD-9937-18962872DD9F} |
| 720 | 7.2.4.9 | Maintain defect logs 9 | 1d | 2005-02-28 | 2005-02-28 | 2005-02-28 | 2005-02-28 | 1d | 126d | start no earlier than 2005-02-28 | {B0DCBF95-7CFC-4FB8-83BF-438A8D78A50C} |
| 721 | 7.2.4.10 | Maintain defect logs 10 | 1d | 2005-03-07 | 2005-03-07 | 2005-03-07 | 2005-03-07 | 1d | 121d | start no earlier than 2005-03-07 | {D0204C71-5AEF-4606-8BDC-9AE304CD09B0} |
| 722 | 7.2.4.11 | Maintain defect logs 11 | 1d | 2005-03-14 | 2005-03-14 | 2005-03-14 | 2005-03-14 | 1d | 116d | start no earlier than 2005-03-14 | {384F3BD4-558F-4A2C-9B06-7ACDBF9026FD} |
| 723 | 7.2.4.12 | Maintain defect logs 12 | 1d | 2005-03-21 | 2005-03-21 | 2005-03-21 | 2005-03-21 | 1d | 111d | start no earlier than 2005-03-21 | {97431C00-735C-4F7D-8F22-1E1B585DAAED} |
| 724 | 7.2.4.13 | Maintain defect logs 13 | 1d | 2005-03-28 | 2005-03-28 | 2005-03-28 | 2005-03-28 | 1d | 106d | start no earlier than 2005-03-28 | {66050DA1-6C5B-4EEF-8387-DA74CE98DC02} |
| 725 | 7.2.4.14 | Maintain defect logs 14 | 1d | 2005-04-04 | 2005-04-04 | 2005-04-04 | 2005-04-04 | 1d | 101d | start no earlier than 2005-04-04 | {0461E4E2-F0BE-47D0-AB0E-22759F1A9226} |
| 726 | 7.2.4.15 | Maintain defect logs 15 | 1d | 2005-04-11 | 2005-04-11 | 2005-04-11 | 2005-04-11 | 1d | 96d | start no earlier than 2005-04-11 | {EF18D4DB-5575-4AA2-B6DD-EE8C3AE707E2} |
| 727 | 7.2.4.16 | Maintain defect logs 16 | 1d | 2005-04-18 | 2005-04-18 | 2005-04-18 | 2005-04-18 | 1d | 91d | start no earlier than 2005-04-18 | {1397AE87-87E2-4A64-B671-24B5E70B655E} |
| 728 | 7.2.4.17 | Maintain defect logs 17 | 1d | 2005-04-25 | 2005-04-25 | 2005-04-25 | 2005-04-25 | 1d | 86d | start no earlier than 2005-04-25 | {1C2CFB8F-AAB7-4544-B2D8-CD44948D4E6C} |
| 729 | 7.2.4.18 | Maintain defect logs 18 | 1d | 2005-05-02 | 2005-05-02 | 2005-05-02 | 2005-05-02 | 1d | 81d | start no earlier than 2005-05-02 | {E978221A-8631-473C-9210-6C0B20423841} |
| 730 | 7.2.4.19 | Maintain defect logs 19 | 1d | 2005-05-09 | 2005-05-09 | 2005-05-09 | 2005-05-09 | 1d | 76d | start no earlier than 2005-05-09 | {702E1EB6-6118-4291-8876-F4791518405D} |
| 731 | 7.2.4.20 | Maintain defect logs 20 | 1d | 2005-05-16 | 2005-05-16 | 2005-05-16 | 2005-05-16 | 1d | 71d | start no earlier than 2005-05-16 | {0488EEDA-D862-478E-A0D5-502B9A098021} |
| 732 | 7.2.4.21 | Maintain defect logs 21 | 1d | 2005-05-23 | 2005-05-23 | 2005-05-23 | 2005-05-23 | 1d | 66d | start no earlier than 2005-05-23 | {A273892E-8026-40F7-AF0E-B997E9079CB0} |
| 733 | 7.2.4.22 | Maintain defect logs 22 | 1d | 2005-05-30 | 2005-05-30 | 2005-05-30 | 2005-05-30 | 1d | 61d | start no earlier than 2005-05-30 | {0CB3CE71-FBA3-437B-8660-B2B1BBAB16A3} |
| 734 | 7.2.4.23 | Maintain defect logs 23 | 1d | 2005-06-06 | 2005-06-06 | 2005-06-06 | 2005-06-06 | 1d | 56d | start no earlier than 2005-06-06 | {9014A465-3ED8-4F5D-85D9-F7123FB752C7} |
| 735 | 7.2.4.24 | Maintain defect logs 24 | 1d | 2005-06-13 | 2005-06-13 | 2005-06-13 | 2005-06-13 | 1d | 51d | start no earlier than 2005-06-13 | {6124EC47-A135-4886-A50D-4EAD6AB1BF8D} |
| 736 | 7.2.4.25 | Maintain defect logs 25 | 1d | 2005-06-20 | 2005-06-20 | 2005-06-20 | 2005-06-20 | 1d | 46d | start no earlier than 2005-06-20 | {BDA97DA3-FDDA-45B5-A02C-A55F5B01D0D3} |
| 737 | 7.2.4.26 | Maintain defect logs 26 | 1d | 2005-06-27 | 2005-06-27 | 2005-06-27 | 2005-06-27 | 1d | 41d | start no earlier than 2005-06-27 | {FCEA7C1D-10CD-4A5C-A0B9-2B1FA142AB6F} |
| 738 | 7.2.4.27 | Maintain defect logs 27 | 1d | 2005-07-04 | 2005-07-04 | 2005-07-04 | 2005-07-04 | 1d | 36d | start no earlier than 2005-07-04 | {3775C925-5485-42B1-99C8-EFE58D40DBC9} |
| 739 | 7.2.4.28 | Maintain defect logs 28 | 1d | 2005-07-11 | 2005-07-11 | 2005-07-11 | 2005-07-11 | 1d | 31d | start no earlier than 2005-07-11 | {523BD154-C6DC-40F6-B569-4266053C3978} |
| 740 | 7.2.4.29 | Maintain defect logs 29 | 1d | 2005-07-18 | 2005-07-18 | 2005-07-18 | 2005-07-18 | 1d | 26d | start no earlier than 2005-07-18 | {9818BF04-3B0D-4E29-A1DA-DAF64A57EB93} |
| 741 | 7.2.4.30 | Maintain defect logs 30 | 1d | 2005-07-25 | 2005-07-25 | 2005-07-25 | 2005-07-25 | 1d | 21d | start no earlier than 2005-07-25 | {0491A9E4-F85C-47FE-973B-7F01B8BD3C09} |
| 742 | 7.2.4.31 | Maintain defect logs 31 | 1d | 2005-08-01 | 2005-08-01 | 2005-08-01 | 2005-08-01 | 1d | 16d | start no earlier than 2005-08-01 | {FD249584-884F-4B5C-BA13-EC4C3EFB90CB} |
| 743 | 7.2.4.32 | Maintain defect logs 32 | 1d | 2005-08-08 | 2005-08-08 | 2005-08-08 | 2005-08-08 | 1d | 11d | start no earlier than 2005-08-08 | {6C1901B9-8D5D-44BC-B10C-0FA31547400C} |
| 744 | 7.2.4.33 | Maintain defect logs 33 | 1d | 2005-08-15 | 2005-08-15 | 2005-08-15 | 2005-08-15 | 1d | 6d | start no earlier than 2005-08-15 | {EC5A5833-F757-4A53-8083-37DD2A864ECE} |
| 745 | 7.2.4.34 | Maintain defect logs 34 | 1d | 2005-08-22 | 2005-08-22 | 2005-08-22 | 2005-08-22 | 1d | 1d | start no earlier than 2005-08-22 | {24744942-528A-4B3A-AC57-C5F3EF6DC65D} |

Notes:
- 711: Text3: <sync-guid>{ABED82E4-CCEE-495A-B833-56BC4E6E5F96}</sync-guid><sync-parentguid>{55A6A8DD-D0E3-4E39-AE60-4750F7DD10C2}</sync-parentguid><sync-checksum>2067766988</sync-checksum><sync-rootid>0</sync-rootid><sync-itemtype>0</sync-itemtype><sync-timestamp>12/3 / Text5: 0/2004 1:13:21 PM</sync-timestamp><sync-itemid>941</sync-itemid><sync-prioritymapping>0:0-0/1:700-1000/2:300-699/3:1-299</sync-prioritymapping>
- 712: Text3: <sync-guid>{842055F5-D80D-4C49-B442-0E874A4C0043}</sync-guid><sync-parentguid>{ABED82E4-CCEE-495A-B833-56BC4E6E5F96}</sync-parentguid><sync-checksum>456619826</sync-checksum><sync-rootid>0</sync-rootid><sync-itemtype>0</sync-itemtype><sync-timestamp>12/30 / Text5: 2004 1:13:16 PM</sync-timestamp><sync-itemid>942</sync-itemid><sync-prioritymapping>0:0-0/1:700-1000/2:300-699/3:1-299</sync-prioritymapping>
- 713: Text3: <sync-guid>{A9B845ED-8EB9-49CC-A215-731983E88AA5}</sync-guid><sync-parentguid>{ABED82E4-CCEE-495A-B833-56BC4E6E5F96}</sync-parentguid><sync-checksum>186497116</sync-checksum><sync-rootid>0</sync-rootid><sync-itemtype>0</sync-itemtype><sync-timestamp>12/21 / Text5: 2004 9:45:22 AM</sync-timestamp><sync-itemid>943</sync-itemid><sync-prioritymapping>0:0-0/1:700-1000/2:300-699/3:1-299</sync-prioritymapping>
- 714: Text3: <sync-guid>{222D75E5-37EB-4BB7-9F16-BE7D01F44CEC}</sync-guid><sync-parentguid>{ABED82E4-CCEE-495A-B833-56BC4E6E5F96}</sync-parentguid><sync-checksum>-1981181056</sync-checksum><sync-rootid>0</sync-rootid><sync-itemtype>0</sync-itemtype><sync-timestamp>12 / Text5: 21/2004 9:45:22 AM</sync-timestamp><sync-itemid>944</sync-itemid><sync-prioritymapping>0:0-0/1:700-1000/2:300-699/3:1-299</sync-prioritymapping>
- 715: Text3: <sync-guid>{A2685B35-072D-4D89-92A8-ECAB51F61826}</sync-guid><sync-parentguid>{ABED82E4-CCEE-495A-B833-56BC4E6E5F96}</sync-parentguid><sync-checksum>-220996393</sync-checksum><sync-rootid>0</sync-rootid><sync-itemtype>0</sync-itemtype><sync-timestamp>12/2 / Text5: 1/2004 9:45:22 AM</sync-timestamp><sync-itemid>945</sync-itemid><sync-prioritymapping>0:0-0/1:700-1000/2:300-699/3:1-299</sync-prioritymapping>
- 716: Text3: <sync-guid>{CE8A1543-6C6A-4282-8CE2-6371EC16BF74}</sync-guid><sync-parentguid>{ABED82E4-CCEE-495A-B833-56BC4E6E5F96}</sync-parentguid><sync-checksum>345916675</sync-checksum><sync-rootid>0</sync-rootid><sync-itemtype>0</sync-itemtype><sync-timestamp>12/21 / Text5: 2004 9:45:22 AM</sync-timestamp><sync-itemid>946</sync-itemid><sync-prioritymapping>0:0-0/1:700-1000/2:300-699/3:1-299</sync-prioritymapping>
- 717: Text3: <sync-guid>{76646295-4B72-4B2B-9F09-6FB40E44BD21}</sync-guid><sync-parentguid>{ABED82E4-CCEE-495A-B833-56BC4E6E5F96}</sync-parentguid><sync-checksum>-2120394694</sync-checksum><sync-rootid>0</sync-rootid><sync-itemtype>0</sync-itemtype><sync-timestamp>12 / Text5: 21/2004 9:45:22 AM</sync-timestamp><sync-itemid>947</sync-itemid><sync-prioritymapping>0:0-0/1:700-1000/2:300-699/3:1-299</sync-prioritymapping>
- 718: Text3: <sync-guid>{26E1262A-EFFC-48D5-9CC4-A51D4EA48603}</sync-guid><sync-parentguid>{ABED82E4-CCEE-495A-B833-56BC4E6E5F96}</sync-parentguid><sync-checksum>214890971</sync-checksum><sync-rootid>0</sync-rootid><sync-itemtype>0</sync-itemtype><sync-timestamp>12/21 / Text5: 2004 9:45:22 AM</sync-timestamp><sync-itemid>948</sync-itemid><sync-prioritymapping>0:0-0/1:700-1000/2:300-699/3:1-299</sync-prioritymapping>
- 719: Text3: <sync-guid>{488843CF-FF70-41FD-9937-18962872DD9F}</sync-guid><sync-parentguid>{ABED82E4-CCEE-495A-B833-56BC4E6E5F96}</sync-parentguid><sync-checksum>-1515607879</sync-checksum><sync-rootid>0</sync-rootid><sync-itemtype>0</sync-itemtype><sync-timestamp>12 / Text5: 21/2004 9:45:23 AM</sync-timestamp><sync-itemid>949</sync-itemid><sync-prioritymapping>0:0-0/1:700-1000/2:300-699/3:1-299</sync-prioritymapping>
- 720: Text3: <sync-guid>{B0DCBF95-7CFC-4FB8-83BF-438A8D78A50C}</sync-guid><sync-parentguid>{ABED82E4-CCEE-495A-B833-56BC4E6E5F96}</sync-parentguid><sync-checksum>-678159588</sync-checksum><sync-rootid>0</sync-rootid><sync-itemtype>0</sync-itemtype><sync-timestamp>12/2 / Text5: 1/2004 9:45:23 AM</sync-timestamp><sync-itemid>950</sync-itemid><sync-prioritymapping>0:0-0/1:700-1000/2:300-699/3:1-299</sync-prioritymapping>
- 721: Text3: <sync-guid>{D0204C71-5AEF-4606-8BDC-9AE304CD09B0}</sync-guid><sync-parentguid>{ABED82E4-CCEE-495A-B833-56BC4E6E5F96}</sync-parentguid><sync-checksum>1396571658</sync-checksum><sync-rootid>0</sync-rootid><sync-itemtype>0</sync-itemtype><sync-timestamp>12/2 / Text5: 1/2004 9:45:23 AM</sync-timestamp><sync-itemid>951</sync-itemid><sync-prioritymapping>0:0-0/1:700-1000/2:300-699/3:1-299</sync-prioritymapping>
- 722: Text3: <sync-guid>{384F3BD4-558F-4A2C-9B06-7ACDBF9026FD}</sync-guid><sync-parentguid>{ABED82E4-CCEE-495A-B833-56BC4E6E5F96}</sync-parentguid><sync-checksum>-563191829</sync-checksum><sync-rootid>0</sync-rootid><sync-itemtype>0</sync-itemtype><sync-timestamp>12/2 / Text5: 1/2004 9:45:23 AM</sync-timestamp><sync-itemid>952</sync-itemid><sync-prioritymapping>0:0-0/1:700-1000/2:300-699/3:1-299</sync-prioritymapping>
- 723: Text3: <sync-guid>{97431C00-735C-4F7D-8F22-1E1B585DAAED}</sync-guid><sync-parentguid>{ABED82E4-CCEE-495A-B833-56BC4E6E5F96}</sync-parentguid><sync-checksum>-1830044791</sync-checksum><sync-rootid>0</sync-rootid><sync-itemtype>0</sync-itemtype><sync-timestamp>12 / Text5: 21/2004 9:45:23 AM</sync-timestamp><sync-itemid>953</sync-itemid><sync-prioritymapping>0:0-0/1:700-1000/2:300-699/3:1-299</sync-prioritymapping>
- 724: Text3: <sync-guid>{66050DA1-6C5B-4EEF-8387-DA74CE98DC02}</sync-guid><sync-parentguid>{ABED82E4-CCEE-495A-B833-56BC4E6E5F96}</sync-parentguid><sync-checksum>-522844116</sync-checksum><sync-rootid>0</sync-rootid><sync-itemtype>0</sync-itemtype><sync-timestamp>12/2 / Text5: 1/2004 9:45:23 AM</sync-timestamp><sync-itemid>954</sync-itemid><sync-prioritymapping>0:0-0/1:700-1000/2:300-699/3:1-299</sync-prioritymapping>
- 725: Text3: <sync-guid>{0461E4E2-F0BE-47D0-AB0E-22759F1A9226}</sync-guid><sync-parentguid>{ABED82E4-CCEE-495A-B833-56BC4E6E5F96}</sync-parentguid><sync-checksum>-732306643</sync-checksum><sync-rootid>0</sync-rootid><sync-itemtype>0</sync-itemtype><sync-timestamp>12/2 / Text5: 1/2004 9:45:23 AM</sync-timestamp><sync-itemid>955</sync-itemid><sync-prioritymapping>0:0-0/1:700-1000/2:300-699/3:1-299</sync-prioritymapping>
- 726: Text3: <sync-guid>{EF18D4DB-5575-4AA2-B6DD-EE8C3AE707E2}</sync-guid><sync-parentguid>{ABED82E4-CCEE-495A-B833-56BC4E6E5F96}</sync-parentguid><sync-checksum>840203001</sync-checksum><sync-rootid>0</sync-rootid><sync-itemtype>0</sync-itemtype><sync-timestamp>12/21 / Text5: 2004 9:45:23 AM</sync-timestamp><sync-itemid>956</sync-itemid><sync-prioritymapping>0:0-0/1:700-1000/2:300-699/3:1-299</sync-prioritymapping>
- 727: Text3: <sync-guid>{1397AE87-87E2-4A64-B671-24B5E70B655E}</sync-guid><sync-parentguid>{ABED82E4-CCEE-495A-B833-56BC4E6E5F96}</sync-parentguid><sync-checksum>1853423836</sync-checksum><sync-rootid>0</sync-rootid><sync-itemtype>0</sync-itemtype><sync-timestamp>12/2 / Text5: 1/2004 9:45:23 AM</sync-timestamp><sync-itemid>957</sync-itemid><sync-prioritymapping>0:0-0/1:700-1000/2:300-699/3:1-299</sync-prioritymapping>
- 728: Text3: <sync-guid>{1C2CFB8F-AAB7-4544-B2D8-CD44948D4E6C}</sync-guid><sync-parentguid>{ABED82E4-CCEE-495A-B833-56BC4E6E5F96}</sync-parentguid><sync-checksum>-1753510542</sync-checksum><sync-rootid>0</sync-rootid><sync-itemtype>0</sync-itemtype><sync-timestamp>12 / Text5: 21/2004 9:45:23 AM</sync-timestamp><sync-itemid>958</sync-itemid><sync-prioritymapping>0:0-0/1:700-1000/2:300-699/3:1-299</sync-prioritymapping>
- 729: Text3: <sync-guid>{E978221A-8631-473C-9210-6C0B20423841}</sync-guid><sync-parentguid>{ABED82E4-CCEE-495A-B833-56BC4E6E5F96}</sync-parentguid><sync-checksum>1513468871</sync-checksum><sync-rootid>0</sync-rootid><sync-itemtype>0</sync-itemtype><sync-timestamp>12/2 / Text5: 1/2004 9:45:24 AM</sync-timestamp><sync-itemid>959</sync-itemid><sync-prioritymapping>0:0-0/1:700-1000/2:300-699/3:1-299</sync-prioritymapping>
- 730: Text3: <sync-guid>{702E1EB6-6118-4291-8876-F4791518405D}</sync-guid><sync-parentguid>{ABED82E4-CCEE-495A-B833-56BC4E6E5F96}</sync-parentguid><sync-checksum>251521137</sync-checksum><sync-rootid>0</sync-rootid><sync-itemtype>0</sync-itemtype><sync-timestamp>12/21 / Text5: 2004 9:45:24 AM</sync-timestamp><sync-itemid>960</sync-itemid><sync-prioritymapping>0:0-0/1:700-1000/2:300-699/3:1-299</sync-prioritymapping>
- 731: Text3: <sync-guid>{0488EEDA-D862-478E-A0D5-502B9A098021}</sync-guid><sync-parentguid>{ABED82E4-CCEE-495A-B833-56BC4E6E5F96}</sync-parentguid><sync-checksum>-1707858233</sync-checksum><sync-rootid>0</sync-rootid><sync-itemtype>0</sync-itemtype><sync-timestamp>12 / Text5: 21/2004 9:45:24 AM</sync-timestamp><sync-itemid>961</sync-itemid><sync-prioritymapping>0:0-0/1:700-1000/2:300-699/3:1-299</sync-prioritymapping>
- 732: Text3: <sync-guid>{A273892E-8026-40F7-AF0E-B997E9079CB0}</sync-guid><sync-parentguid>{ABED82E4-CCEE-495A-B833-56BC4E6E5F96}</sync-parentguid><sync-checksum>-119469275</sync-checksum><sync-rootid>0</sync-rootid><sync-itemtype>0</sync-itemtype><sync-timestamp>12/2 / Text5: 1/2004 9:45:24 AM</sync-timestamp><sync-itemid>962</sync-itemid><sync-prioritymapping>0:0-0/1:700-1000/2:300-699/3:1-299</sync-prioritymapping>
- 733: Text3: <sync-guid>{0CB3CE71-FBA3-437B-8660-B2B1BBAB16A3}</sync-guid><sync-parentguid>{ABED82E4-CCEE-495A-B833-56BC4E6E5F96}</sync-parentguid><sync-checksum>1541563204</sync-checksum><sync-rootid>0</sync-rootid><sync-itemtype>0</sync-itemtype><sync-timestamp>12/2 / Text5: 1/2004 9:45:24 AM</sync-timestamp><sync-itemid>963</sync-itemid><sync-prioritymapping>0:0-0/1:700-1000/2:300-699/3:1-299</sync-prioritymapping>
- 734: Text3: <sync-guid>{9014A465-3ED8-4F5D-85D9-F7123FB752C7}</sync-guid><sync-parentguid>{ABED82E4-CCEE-495A-B833-56BC4E6E5F96}</sync-parentguid><sync-checksum>-525223939</sync-checksum><sync-rootid>0</sync-rootid><sync-itemtype>0</sync-itemtype><sync-timestamp>12/2 / Text5: 1/2004 9:45:24 AM</sync-timestamp><sync-itemid>964</sync-itemid><sync-prioritymapping>0:0-0/1:700-1000/2:300-699/3:1-299</sync-prioritymapping>
- 735: Text3: <sync-guid>{6124EC47-A135-4886-A50D-4EAD6AB1BF8D}</sync-guid><sync-parentguid>{ABED82E4-CCEE-495A-B833-56BC4E6E5F96}</sync-parentguid><sync-checksum>1947038889</sync-checksum><sync-rootid>0</sync-rootid><sync-itemtype>0</sync-itemtype><sync-timestamp>12/2 / Text5: 1/2004 9:45:24 AM</sync-timestamp><sync-itemid>965</sync-itemid><sync-prioritymapping>0:0-0/1:700-1000/2:300-699/3:1-299</sync-prioritymapping>
- 736: Text3: <sync-guid>{BDA97DA3-FDDA-45B5-A02C-A55F5B01D0D3}</sync-guid><sync-parentguid>{ABED82E4-CCEE-495A-B833-56BC4E6E5F96}</sync-parentguid><sync-checksum>2110153086</sync-checksum><sync-rootid>0</sync-rootid><sync-itemtype>0</sync-itemtype><sync-timestamp>12/2 / Text5: 1/2004 9:45:24 AM</sync-timestamp><sync-itemid>966</sync-itemid><sync-prioritymapping>0:0-0/1:700-1000/2:300-699/3:1-299</sync-prioritymapping>
- 737: Text3: <sync-guid>{FCEA7C1D-10CD-4A5C-A0B9-2B1FA142AB6F}</sync-guid><sync-parentguid>{ABED82E4-CCEE-495A-B833-56BC4E6E5F96}</sync-parentguid><sync-checksum>-782073054</sync-checksum><sync-rootid>0</sync-rootid><sync-itemtype>0</sync-itemtype><sync-timestamp>12/2 / Text5: 1/2004 9:45:24 AM</sync-timestamp><sync-itemid>967</sync-itemid><sync-prioritymapping>0:0-0/1:700-1000/2:300-699/3:1-299</sync-prioritymapping>
- 738: Text3: <sync-guid>{3775C925-5485-42B1-99C8-EFE58D40DBC9}</sync-guid><sync-parentguid>{ABED82E4-CCEE-495A-B833-56BC4E6E5F96}</sync-parentguid><sync-checksum>-1703603919</sync-checksum><sync-rootid>0</sync-rootid><sync-itemtype>0</sync-itemtype><sync-timestamp>12 / Text5: 21/2004 9:45:25 AM</sync-timestamp><sync-itemid>968</sync-itemid><sync-prioritymapping>0:0-0/1:700-1000/2:300-699/3:1-299</sync-prioritymapping>
- 739: Text3: <sync-guid>{523BD154-C6DC-40F6-B569-4266053C3978}</sync-guid><sync-parentguid>{ABED82E4-CCEE-495A-B833-56BC4E6E5F96}</sync-parentguid><sync-checksum>-1215630235</sync-checksum><sync-rootid>0</sync-rootid><sync-itemtype>0</sync-itemtype><sync-timestamp>12 / Text5: 21/2004 9:45:25 AM</sync-timestamp><sync-itemid>969</sync-itemid><sync-prioritymapping>0:0-0/1:700-1000/2:300-699/3:1-299</sync-prioritymapping>
- 740: Text3: <sync-guid>{9818BF04-3B0D-4E29-A1DA-DAF64A57EB93}</sync-guid><sync-parentguid>{ABED82E4-CCEE-495A-B833-56BC4E6E5F96}</sync-parentguid><sync-checksum>-977844288</sync-checksum><sync-rootid>0</sync-rootid><sync-itemtype>0</sync-itemtype><sync-timestamp>12/3 / Text5: 0/2004 1:09:59 PM</sync-timestamp><sync-itemid>1182</sync-itemid><sync-prioritymapping>0:0-0/1:700-1000/2:300-699/3:1-299</sync-prioritymapping>
- 741: Text3: <sync-guid>{0491A9E4-F85C-47FE-973B-7F01B8BD3C09}</sync-guid><sync-parentguid>{ABED82E4-CCEE-495A-B833-56BC4E6E5F96}</sync-parentguid><sync-checksum>512034490</sync-checksum><sync-rootid>0</sync-rootid><sync-itemtype>0</sync-itemtype><sync-timestamp>12/30 / Text5: 2004 1:10:00 PM</sync-timestamp><sync-itemid>1183</sync-itemid><sync-prioritymapping>0:0-0/1:700-1000/2:300-699/3:1-299</sync-prioritymapping>
- 742: Text3: <sync-guid>{FD249584-884F-4B5C-BA13-EC4C3EFB90CB}</sync-guid><sync-parentguid>{ABED82E4-CCEE-495A-B833-56BC4E6E5F96}</sync-parentguid><sync-checksum>-945096305</sync-checksum><sync-rootid>0</sync-rootid><sync-itemtype>0</sync-itemtype><sync-timestamp>12/3 / Text5: 0/2004 1:10:00 PM</sync-timestamp><sync-itemid>1184</sync-itemid><sync-prioritymapping>0:0-0/1:700-1000/2:300-699/3:1-299</sync-prioritymapping>
- 743: Text3: <sync-guid>{6C1901B9-8D5D-44BC-B10C-0FA31547400C}</sync-guid><sync-parentguid>{ABED82E4-CCEE-495A-B833-56BC4E6E5F96}</sync-parentguid><sync-checksum>-1681423446</sync-checksum><sync-rootid>0</sync-rootid><sync-itemtype>0</sync-itemtype><sync-timestamp>12 / Text5: 30/2004 1:10:00 PM</sync-timestamp><sync-itemid>1279</sync-itemid><sync-prioritymapping>0:0-0/1:700-1000/2:300-699/3:1-299</sync-prioritymapping>
- 744: Text3: <sync-guid>{EC5A5833-F757-4A53-8083-37DD2A864ECE}</sync-guid><sync-parentguid>{ABED82E4-CCEE-495A-B833-56BC4E6E5F96}</sync-parentguid><sync-checksum>-430065102</sync-checksum><sync-rootid>0</sync-rootid><sync-itemtype>0</sync-itemtype><sync-timestamp>12/3 / Text5: 0/2004 1:10:01 PM</sync-timestamp><sync-itemid>1280</sync-itemid><sync-prioritymapping>0:0-0/1:700-1000/2:300-699/3:1-299</sync-prioritymapping>
- 745: Text3: <sync-guid>{24744942-528A-4B3A-AC57-C5F3EF6DC65D}</sync-guid><sync-parentguid>{ABED82E4-CCEE-495A-B833-56BC4E6E5F96}</sync-parentguid><sync-checksum>-796121789</sync-checksum><sync-rootid>0</sync-rootid><sync-itemtype>0</sync-itemtype><sync-timestamp>12/3 / Text5: 0/2004 1:10:01 PM</sync-timestamp><sync-itemid>1281</sync-itemid><sync-prioritymapping>0:0-0/1:700-1000/2:300-699/3:1-299</sync-prioritymapping>

| ID | WBS | Task | Duration | Start | Finish | Baseline start | Baseline finish | Baseline duration | Total slack | Constraint | Text4 |
| --- | --- | --- | --- | --- | --- | --- | --- | --- | --- | --- | --- |
| 746 | 7.2.5 | **Maintain project plan updates** | 163d | 2005-01-06 | 2005-08-22 | 2005-01-06 | 2005-08-22 | 163d | 1d |  | {7570C640-B263-480D-9A03-8C17E60903A6} |
| 747 | 7.2.5.1 | Maintain project plan updates 1 | 1d | 2005-01-06 | 2005-01-06 | 2005-01-06 | 2005-01-06 | 1d | 163d | start no earlier than 2005-01-03 | {489C535B-5D26-461F-B537-87AB3ECC8DC8} |
| 748 | 7.2.5.2 | Maintain project plan updates 2 | 1d | 2005-01-10 | 2005-01-10 | 2005-01-10 | 2005-01-10 | 1d | 161d | start no earlier than 2005-01-10 | {46585CB1-0B23-46BA-9060-CCFD158E6791} |
| 749 | 7.2.5.3 | Maintain project plan updates 3 | 1d | 2005-01-17 | 2005-01-17 | 2005-01-17 | 2005-01-17 | 1d | 156d | start no earlier than 2005-01-17 | {310C60F1-D610-477E-9417-80AF0176AB77} |
| 750 | 7.2.5.4 | Maintain project plan updates 4 | 1d | 2005-01-24 | 2005-01-24 | 2005-01-24 | 2005-01-24 | 1d | 151d | start no earlier than 2005-01-24 | {9FF871C2-E2D6-456B-9290-98AA6A43C2A4} |
| 751 | 7.2.5.5 | Maintain project plan updates 5 | 1d | 2005-01-31 | 2005-01-31 | 2005-01-31 | 2005-01-31 | 1d | 146d | start no earlier than 2005-01-31 | {1929A982-B00D-46E7-9C8B-7A33A6CB4520} |
| 752 | 7.2.5.6 | Maintain project plan updates 6 | 1d | 2005-02-07 | 2005-02-07 | 2005-02-07 | 2005-02-07 | 1d | 141d | start no earlier than 2005-02-07 | {3DFE8EFD-AB81-42CC-B906-F7AA77A69F81} |
| 753 | 7.2.5.7 | Maintain project plan updates 7 | 1d | 2005-02-14 | 2005-02-14 | 2005-02-14 | 2005-02-14 | 1d | 136d | start no earlier than 2005-02-14 | {9FB34DC7-A93E-41A7-BBBC-A9EBC44B0513} |
| 754 | 7.2.5.8 | Maintain project plan updates 8 | 1d | 2005-02-21 | 2005-02-21 | 2005-02-21 | 2005-02-21 | 1d | 131d | start no earlier than 2005-02-21 | {8EAB5DFB-EB08-4CDB-92C1-D781C2626F49} |
| 755 | 7.2.5.9 | Maintain project plan updates 9 | 1d | 2005-02-28 | 2005-02-28 | 2005-02-28 | 2005-02-28 | 1d | 126d | start no earlier than 2005-02-28 | {8F8E323F-DE30-46F5-9A0E-284347A485A1} |
| 756 | 7.2.5.10 | Maintain project plan updates 10 | 1d | 2005-03-07 | 2005-03-07 | 2005-03-07 | 2005-03-07 | 1d | 121d | start no earlier than 2005-03-07 | {E3745316-C691-4979-A7F3-DDEE47705C79} |
| 757 | 7.2.5.11 | Maintain project plan updates 11 | 1d | 2005-03-14 | 2005-03-14 | 2005-03-14 | 2005-03-14 | 1d | 116d | start no earlier than 2005-03-14 | {51ECC716-95D7-4E25-9962-7C43CB35C28A} |
| 758 | 7.2.5.12 | Maintain project plan updates 12 | 1d | 2005-03-21 | 2005-03-21 | 2005-03-21 | 2005-03-21 | 1d | 111d | start no earlier than 2005-03-21 | {F3324067-118A-4AC9-A154-63591485EA6C} |
| 759 | 7.2.5.13 | Maintain project plan updates 13 | 1d | 2005-03-28 | 2005-03-28 | 2005-03-28 | 2005-03-28 | 1d | 106d | start no earlier than 2005-03-28 | {E461789E-D5ED-4B1D-A806-34E42245210A} |
| 760 | 7.2.5.14 | Maintain project plan updates 14 | 1d | 2005-04-04 | 2005-04-04 | 2005-04-04 | 2005-04-04 | 1d | 101d | start no earlier than 2005-04-04 | {E818B7B9-42C8-454E-91B7-8340F9FDB528} |
| 761 | 7.2.5.15 | Maintain project plan updates 15 | 1d | 2005-04-11 | 2005-04-11 | 2005-04-11 | 2005-04-11 | 1d | 96d | start no earlier than 2005-04-11 | {D06D01B3-3193-4360-B888-E6F32B3F6CEC} |
| 762 | 7.2.5.16 | Maintain project plan updates 16 | 1d | 2005-04-18 | 2005-04-18 | 2005-04-18 | 2005-04-18 | 1d | 91d | start no earlier than 2005-04-18 | {9D3E87D0-FDFA-4168-A6A9-B52CB3D1BF95} |
| 763 | 7.2.5.17 | Maintain project plan updates 17 | 1d | 2005-04-25 | 2005-04-25 | 2005-04-25 | 2005-04-25 | 1d | 86d | start no earlier than 2005-04-25 | {AA0FDED7-DEC7-4EF3-B411-940FA5CE05C5} |
| 764 | 7.2.5.18 | Maintain project plan updates 18 | 1d | 2005-05-02 | 2005-05-02 | 2005-05-02 | 2005-05-02 | 1d | 81d | start no earlier than 2005-05-02 | {3D7F9BE1-0B06-434B-B3FB-4071C1A6897C} |
| 765 | 7.2.5.19 | Maintain project plan updates 19 | 1d | 2005-05-09 | 2005-05-09 | 2005-05-09 | 2005-05-09 | 1d | 76d | start no earlier than 2005-05-09 | {2A58D909-9B16-42F0-8AEC-0E29E5678B5B} |
| 766 | 7.2.5.20 | Maintain project plan updates 20 | 1d | 2005-05-16 | 2005-05-16 | 2005-05-16 | 2005-05-16 | 1d | 71d | start no earlier than 2005-05-16 | {5F6F5C68-90F4-42A6-BB38-BBBE9ED336AF} |
| 767 | 7.2.5.21 | Maintain project plan updates 21 | 1d | 2005-05-23 | 2005-05-23 | 2005-05-23 | 2005-05-23 | 1d | 66d | start no earlier than 2005-05-23 | {5172A804-3C55-4D86-B84E-FE97C2B86D4C} |
| 768 | 7.2.5.22 | Maintain project plan updates 22 | 1d | 2005-05-30 | 2005-05-30 | 2005-05-30 | 2005-05-30 | 1d | 61d | start no earlier than 2005-05-30 | {F31E1377-9AF9-4A3A-B4DF-1B24B7B0C2EE} |
| 769 | 7.2.5.23 | Maintain project plan updates 23 | 1d | 2005-06-06 | 2005-06-06 | 2005-06-06 | 2005-06-06 | 1d | 56d | start no earlier than 2005-06-06 | {E9E154D5-5092-4C24-8EA7-1CCFCEF6D080} |
| 770 | 7.2.5.24 | Maintain project plan updates 24 | 1d | 2005-06-13 | 2005-06-13 | 2005-06-13 | 2005-06-13 | 1d | 51d | start no earlier than 2005-06-13 | {E67E81A2-6181-4829-B5E3-92AFF03B6CC9} |
| 771 | 7.2.5.25 | Maintain project plan updates 25 | 1d | 2005-06-20 | 2005-06-20 | 2005-06-20 | 2005-06-20 | 1d | 46d | start no earlier than 2005-06-20 | {995DCDD2-F8A0-44BC-8005-2871EC282FCA} |
| 772 | 7.2.5.26 | Maintain project plan updates 26 | 1d | 2005-06-27 | 2005-06-27 | 2005-06-27 | 2005-06-27 | 1d | 41d | start no earlier than 2005-06-27 | {50C01101-C756-4827-97E5-1DCEB65785CE} |
| 773 | 7.2.5.27 | Maintain project plan updates 27 | 1d | 2005-07-04 | 2005-07-04 | 2005-07-04 | 2005-07-04 | 1d | 36d | start no earlier than 2005-07-04 | {9301F141-F4AB-4C12-B0A9-6437753762B1} |
| 774 | 7.2.5.28 | Maintain project plan updates 28 | 1d | 2005-07-11 | 2005-07-11 | 2005-07-11 | 2005-07-11 | 1d | 31d | start no earlier than 2005-07-11 | {93DF5A3A-35CE-4339-8DD0-40AE07897B5C} |
| 775 | 7.2.5.29 | Maintain project plan updates 29 | 1d | 2005-07-18 | 2005-07-18 | 2005-07-18 | 2005-07-18 | 1d | 26d | start no earlier than 2005-07-18 | {87699605-B7C1-483B-870B-F6CA6AB2D8D1} |
| 776 | 7.2.5.30 | Maintain project plan updates 30 | 1d | 2005-07-25 | 2005-07-25 | 2005-07-25 | 2005-07-25 | 1d | 21d | start no earlier than 2005-07-25 | {4149369B-496D-4CC5-91A0-04F0B5066AC0} |
| 777 | 7.2.5.31 | Maintain project plan updates 31 | 1d | 2005-08-01 | 2005-08-01 | 2005-08-01 | 2005-08-01 | 1d | 16d | start no earlier than 2005-08-01 | {AD608E72-31FC-4042-8BC6-2D9315215745} |
| 778 | 7.2.5.32 | Maintain project plan updates 32 | 1d | 2005-08-08 | 2005-08-08 | 2005-08-08 | 2005-08-08 | 1d | 11d | start no earlier than 2005-08-08 | {569544C8-79D5-438E-99AD-338E92E3AB33} |
| 779 | 7.2.5.33 | Maintain project plan updates 33 | 1d | 2005-08-15 | 2005-08-15 | 2005-08-15 | 2005-08-15 | 1d | 6d | start no earlier than 2005-08-15 | {3C89A5C9-67D9-4D26-B974-BEDDF45E8665} |
| 780 | 7.2.5.34 | Maintain project plan updates 34 | 1d | 2005-08-22 | 2005-08-22 | 2005-08-22 | 2005-08-22 | 1d | 1d | start no earlier than 2005-08-22 | {7FF77071-42AA-46C2-AD4A-09A0F4DDD4EE} |

Notes:
- 746: Text3: <sync-guid>{7570C640-B263-480D-9A03-8C17E60903A6}</sync-guid><sync-parentguid>{55A6A8DD-D0E3-4E39-AE60-4750F7DD10C2}</sync-parentguid><sync-checksum>-1816587144</sync-checksum><sync-rootid>0</sync-rootid><sync-itemtype>0</sync-itemtype><sync-timestamp>12 / Text5: 30/2004 1:13:25 PM</sync-timestamp><sync-itemid>765</sync-itemid><sync-prioritymapping>0:0-0/1:700-1000/2:300-699/3:1-299</sync-prioritymapping>
- 747: Text3: <sync-guid>{489C535B-5D26-461F-B537-87AB3ECC8DC8}</sync-guid><sync-parentguid>{7570C640-B263-480D-9A03-8C17E60903A6}</sync-parentguid><sync-checksum>-206439034</sync-checksum><sync-rootid>0</sync-rootid><sync-itemtype>0</sync-itemtype><sync-timestamp>12/3 / Text5: 0/2004 1:13:21 PM</sync-timestamp><sync-itemid>766</sync-itemid><sync-prioritymapping>0:0-0/1:700-1000/2:300-699/3:1-299</sync-prioritymapping>
- 748: Text3: <sync-guid>{46585CB1-0B23-46BA-9060-CCFD158E6791}</sync-guid><sync-parentguid>{7570C640-B263-480D-9A03-8C17E60903A6}</sync-parentguid><sync-checksum>-476368152</sync-checksum><sync-rootid>0</sync-rootid><sync-itemtype>0</sync-itemtype><sync-timestamp>12/2 / Text5: 1/2004 9:45:25 AM</sync-timestamp><sync-itemid>767</sync-itemid><sync-prioritymapping>0:0-0/1:700-1000/2:300-699/3:1-299</sync-prioritymapping>
- 749: Text3: <sync-guid>{310C60F1-D610-477E-9417-80AF0176AB77}</sync-guid><sync-parentguid>{7570C640-B263-480D-9A03-8C17E60903A6}</sync-parentguid><sync-checksum>1634670900</sync-checksum><sync-rootid>0</sync-rootid><sync-itemtype>0</sync-itemtype><sync-timestamp>12/2 / Text5: 1/2004 9:45:25 AM</sync-timestamp><sync-itemid>768</sync-itemid><sync-prioritymapping>0:0-0/1:700-1000/2:300-699/3:1-299</sync-prioritymapping>
- 750: Text3: <sync-guid>{9FF871C2-E2D6-456B-9290-98AA6A43C2A4}</sync-guid><sync-parentguid>{7570C640-B263-480D-9A03-8C17E60903A6}</sync-parentguid><sync-checksum>441800291</sync-checksum><sync-rootid>0</sync-rootid><sync-itemtype>0</sync-itemtype><sync-timestamp>12/21 / Text5: 2004 9:45:25 AM</sync-timestamp><sync-itemid>769</sync-itemid><sync-prioritymapping>0:0-0/1:700-1000/2:300-699/3:1-299</sync-prioritymapping>
- 751: Text3: <sync-guid>{1929A982-B00D-46E7-9C8B-7A33A6CB4520}</sync-guid><sync-parentguid>{7570C640-B263-480D-9A03-8C17E60903A6}</sync-parentguid><sync-checksum>-65482825</sync-checksum><sync-rootid>0</sync-rootid><sync-itemtype>0</sync-itemtype><sync-timestamp>12/21 / Text5: 2004 9:45:25 AM</sync-timestamp><sync-itemid>770</sync-itemid><sync-prioritymapping>0:0-0/1:700-1000/2:300-699/3:1-299</sync-prioritymapping>
- 752: Text3: <sync-guid>{3DFE8EFD-AB81-42CC-B906-F7AA77A69F81}</sync-guid><sync-parentguid>{7570C640-B263-480D-9A03-8C17E60903A6}</sync-parentguid><sync-checksum>1763431054</sync-checksum><sync-rootid>0</sync-rootid><sync-itemtype>0</sync-itemtype><sync-timestamp>12/2 / Text5: 1/2004 9:45:25 AM</sync-timestamp><sync-itemid>771</sync-itemid><sync-prioritymapping>0:0-0/1:700-1000/2:300-699/3:1-299</sync-prioritymapping>
- 753: Text3: <sync-guid>{9FB34DC7-A93E-41A7-BBBC-A9EBC44B0513}</sync-guid><sync-parentguid>{7570C640-B263-480D-9A03-8C17E60903A6}</sync-parentguid><sync-checksum>-465013905</sync-checksum><sync-rootid>0</sync-rootid><sync-itemtype>0</sync-itemtype><sync-timestamp>12/2 / Text5: 1/2004 9:45:25 AM</sync-timestamp><sync-itemid>772</sync-itemid><sync-prioritymapping>0:0-0/1:700-1000/2:300-699/3:1-299</sync-prioritymapping>
- 754: Text3: <sync-guid>{8EAB5DFB-EB08-4CDB-92C1-D781C2626F49}</sync-guid><sync-parentguid>{7570C640-B263-480D-9A03-8C17E60903A6}</sync-parentguid><sync-checksum>1294934541</sync-checksum><sync-rootid>0</sync-rootid><sync-itemtype>0</sync-itemtype><sync-timestamp>12/2 / Text5: 1/2004 9:45:26 AM</sync-timestamp><sync-itemid>773</sync-itemid><sync-prioritymapping>0:0-0/1:700-1000/2:300-699/3:1-299</sync-prioritymapping>
- 755: Text3: <sync-guid>{8F8E323F-DE30-46F5-9A0E-284347A485A1}</sync-guid><sync-parentguid>{7570C640-B263-480D-9A03-8C17E60903A6}</sync-parentguid><sync-checksum>1058181544</sync-checksum><sync-rootid>0</sync-rootid><sync-itemtype>0</sync-itemtype><sync-timestamp>12/2 / Text5: 1/2004 9:45:26 AM</sync-timestamp><sync-itemid>774</sync-itemid><sync-prioritymapping>0:0-0/1:700-1000/2:300-699/3:1-299</sync-prioritymapping>
- 756: Text3: <sync-guid>{E3745316-C691-4979-A7F3-DDEE47705C79}</sync-guid><sync-parentguid>{7570C640-B263-480D-9A03-8C17E60903A6}</sync-parentguid><sync-checksum>-1613164779</sync-checksum><sync-rootid>0</sync-rootid><sync-itemtype>0</sync-itemtype><sync-timestamp>12 / Text5: 21/2004 9:45:26 AM</sync-timestamp><sync-itemid>775</sync-itemid><sync-prioritymapping>0:0-0/1:700-1000/2:300-699/3:1-299</sync-prioritymapping>
- 757: Text3: <sync-guid>{51ECC716-95D7-4E25-9962-7C43CB35C28A}</sync-guid><sync-parentguid>{7570C640-B263-480D-9A03-8C17E60903A6}</sync-parentguid><sync-checksum>311078644</sync-checksum><sync-rootid>0</sync-rootid><sync-itemtype>0</sync-itemtype><sync-timestamp>12/21 / Text5: 2004 9:45:26 AM</sync-timestamp><sync-itemid>776</sync-itemid><sync-prioritymapping>0:0-0/1:700-1000/2:300-699/3:1-299</sync-prioritymapping>
- 758: Text3: <sync-guid>{F3324067-118A-4AC9-A154-63591485EA6C}</sync-guid><sync-parentguid>{7570C640-B263-480D-9A03-8C17E60903A6}</sync-parentguid><sync-checksum>1578060438</sync-checksum><sync-rootid>0</sync-rootid><sync-itemtype>0</sync-itemtype><sync-timestamp>12/2 / Text5: 1/2004 9:45:26 AM</sync-timestamp><sync-itemid>777</sync-itemid><sync-prioritymapping>0:0-0/1:700-1000/2:300-699/3:1-299</sync-prioritymapping>
- 759: Text3: <sync-guid>{E461789E-D5ED-4B1D-A806-34E42245210A}</sync-guid><sync-parentguid>{7570C640-B263-480D-9A03-8C17E60903A6}</sync-parentguid><sync-checksum>741538099</sync-checksum><sync-rootid>0</sync-rootid><sync-itemtype>0</sync-itemtype><sync-timestamp>12/21 / Text5: 2004 9:45:26 AM</sync-timestamp><sync-itemid>778</sync-itemid><sync-prioritymapping>0:0-0/1:700-1000/2:300-699/3:1-299</sync-prioritymapping>
- 760: Text3: <sync-guid>{E818B7B9-42C8-454E-91B7-8340F9FDB528}</sync-guid><sync-parentguid>{7570C640-B263-480D-9A03-8C17E60903A6}</sync-parentguid><sync-checksum>415044146</sync-checksum><sync-rootid>0</sync-rootid><sync-itemtype>0</sync-itemtype><sync-timestamp>12/21 / Text5: 2004 9:45:26 AM</sync-timestamp><sync-itemid>779</sync-itemid><sync-prioritymapping>0:0-0/1:700-1000/2:300-699/3:1-299</sync-prioritymapping>
- 761: Text3: <sync-guid>{D06D01B3-3193-4360-B888-E6F32B3F6CEC}</sync-guid><sync-parentguid>{7570C640-B263-480D-9A03-8C17E60903A6}</sync-parentguid><sync-checksum>-17789978</sync-checksum><sync-rootid>0</sync-rootid><sync-itemtype>0</sync-itemtype><sync-timestamp>12/21 / Text5: 2004 9:45:26 AM</sync-timestamp><sync-itemid>780</sync-itemid><sync-prioritymapping>0:0-0/1:700-1000/2:300-699/3:1-299</sync-prioritymapping>
- 762: Text3: <sync-guid>{9D3E87D0-FDFA-4168-A6A9-B52CB3D1BF95}</sync-guid><sync-parentguid>{7570C640-B263-480D-9A03-8C17E60903A6}</sync-parentguid><sync-checksum>-1566707261</sync-checksum><sync-rootid>0</sync-rootid><sync-itemtype>0</sync-itemtype><sync-timestamp>12 / Text5: 21/2004 9:45:26 AM</sync-timestamp><sync-itemid>781</sync-itemid><sync-prioritymapping>0:0-0/1:700-1000/2:300-699/3:1-299</sync-prioritymapping>
- 763: Text3: <sync-guid>{AA0FDED7-DEC7-4EF3-B411-940FA5CE05C5}</sync-guid><sync-parentguid>{7570C640-B263-480D-9A03-8C17E60903A6}</sync-parentguid><sync-checksum>1537178733</sync-checksum><sync-rootid>0</sync-rootid><sync-itemtype>0</sync-itemtype><sync-timestamp>12/2 / Text5: 1/2004 9:45:26 AM</sync-timestamp><sync-itemid>782</sync-itemid><sync-prioritymapping>0:0-0/1:700-1000/2:300-699/3:1-299</sync-prioritymapping>
- 764: Text3: <sync-guid>{3D7F9BE1-0B06-434B-B3FB-4071C1A6897C}</sync-guid><sync-parentguid>{7570C640-B263-480D-9A03-8C17E60903A6}</sync-parentguid><sync-checksum>-1764670760</sync-checksum><sync-rootid>0</sync-rootid><sync-itemtype>0</sync-itemtype><sync-timestamp>12 / Text5: 21/2004 9:45:27 AM</sync-timestamp><sync-itemid>783</sync-itemid><sync-prioritymapping>0:0-0/1:700-1000/2:300-699/3:1-299</sync-prioritymapping>
- 765: Text3: <sync-guid>{2A58D909-9B16-42F0-8AEC-0E29E5678B5B}</sync-guid><sync-parentguid>{7570C640-B263-480D-9A03-8C17E60903A6}</sync-parentguid><sync-checksum>-1038542482</sync-checksum><sync-rootid>0</sync-rootid><sync-itemtype>0</sync-itemtype><sync-timestamp>12 / Text5: 21/2004 9:45:27 AM</sync-timestamp><sync-itemid>784</sync-itemid><sync-prioritymapping>0:0-0/1:700-1000/2:300-699/3:1-299</sync-prioritymapping>
- 766: Text3: <sync-guid>{5F6F5C68-90F4-42A6-BB38-BBBE9ED336AF}</sync-guid><sync-parentguid>{7570C640-B263-480D-9A03-8C17E60903A6}</sync-parentguid><sync-checksum>1456527320</sync-checksum><sync-rootid>0</sync-rootid><sync-itemtype>0</sync-itemtype><sync-timestamp>12/2 / Text5: 1/2004 9:45:27 AM</sync-timestamp><sync-itemid>785</sync-itemid><sync-prioritymapping>0:0-0/1:700-1000/2:300-699/3:1-299</sync-prioritymapping>
- 767: Text3: <sync-guid>{5172A804-3C55-4D86-B84E-FE97C2B86D4C}</sync-guid><sync-parentguid>{7570C640-B263-480D-9A03-8C17E60903A6}</sync-parentguid><sync-checksum>872806970</sync-checksum><sync-rootid>0</sync-rootid><sync-itemtype>0</sync-itemtype><sync-timestamp>12/21 / Text5: 2004 9:45:27 AM</sync-timestamp><sync-itemid>786</sync-itemid><sync-prioritymapping>0:0-0/1:700-1000/2:300-699/3:1-299</sync-prioritymapping>
- 768: Text3: <sync-guid>{F31E1377-9AF9-4A3A-B4DF-1B24B7B0C2EE}</sync-guid><sync-parentguid>{7570C640-B263-480D-9A03-8C17E60903A6}</sync-parentguid><sync-checksum>-1761176997</sync-checksum><sync-rootid>0</sync-rootid><sync-itemtype>0</sync-itemtype><sync-timestamp>12 / Text5: 21/2004 9:45:27 AM</sync-timestamp><sync-itemid>787</sync-itemid><sync-prioritymapping>0:0-0/1:700-1000/2:300-699/3:1-299</sync-prioritymapping>
- 769: Text3: <sync-guid>{E9E154D5-5092-4C24-8EA7-1CCFCEF6D080}</sync-guid><sync-parentguid>{7570C640-B263-480D-9A03-8C17E60903A6}</sync-parentguid><sync-checksum>743786210</sync-checksum><sync-rootid>0</sync-rootid><sync-itemtype>0</sync-itemtype><sync-timestamp>12/21 / Text5: 2004 9:45:27 AM</sync-timestamp><sync-itemid>788</sync-itemid><sync-prioritymapping>0:0-0/1:700-1000/2:300-699/3:1-299</sync-prioritymapping>
- 770: Text3: <sync-guid>{E67E81A2-6181-4829-B5E3-92AFF03B6CC9}</sync-guid><sync-parentguid>{7570C640-B263-480D-9A03-8C17E60903A6}</sync-parentguid><sync-checksum>-1192655434</sync-checksum><sync-rootid>0</sync-rootid><sync-itemtype>0</sync-itemtype><sync-timestamp>12 / Text5: 21/2004 9:45:27 AM</sync-timestamp><sync-itemid>894</sync-itemid><sync-prioritymapping>0:0-0/1:700-1000/2:300-699/3:1-299</sync-prioritymapping>
- 771: Text3: <sync-guid>{995DCDD2-F8A0-44BC-8005-2871EC282FCA}</sync-guid><sync-parentguid>{7570C640-B263-480D-9A03-8C17E60903A6}</sync-parentguid><sync-checksum>-1323134879</sync-checksum><sync-rootid>0</sync-rootid><sync-itemtype>0</sync-itemtype><sync-timestamp>12 / Text5: 21/2004 9:45:27 AM</sync-timestamp><sync-itemid>895</sync-itemid><sync-prioritymapping>0:0-0/1:700-1000/2:300-699/3:1-299</sync-prioritymapping>
- 772: Text3: <sync-guid>{50C01101-C756-4827-97E5-1DCEB65785CE}</sync-guid><sync-parentguid>{7570C640-B263-480D-9A03-8C17E60903A6}</sync-parentguid><sync-checksum>495350333</sync-checksum><sync-rootid>0</sync-rootid><sync-itemtype>0</sync-itemtype><sync-timestamp>12/30 / Text5: 2004 1:10:04 PM</sync-timestamp><sync-itemid>1118</sync-itemid><sync-prioritymapping>0:0-0/1:700-1000/2:300-699/3:1-299</sync-prioritymapping>
- 773: Text3: <sync-guid>{9301F141-F4AB-4C12-B0A9-6437753762B1}</sync-guid><sync-parentguid>{7570C640-B263-480D-9A03-8C17E60903A6}</sync-parentguid><sync-checksum>1452400686</sync-checksum><sync-rootid>0</sync-rootid><sync-itemtype>0</sync-itemtype><sync-timestamp>12/3 / Text5: 0/2004 1:10:05 PM</sync-timestamp><sync-itemid>1119</sync-itemid><sync-prioritymapping>0:0-0/1:700-1000/2:300-699/3:1-299</sync-prioritymapping>
- 774: Text3: <sync-guid>{93DF5A3A-35CE-4339-8DD0-40AE07897B5C}</sync-guid><sync-parentguid>{7570C640-B263-480D-9A03-8C17E60903A6}</sync-parentguid><sync-checksum>2070807930</sync-checksum><sync-rootid>0</sync-rootid><sync-itemtype>0</sync-itemtype><sync-timestamp>12/3 / Text5: 0/2004 1:10:05 PM</sync-timestamp><sync-itemid>1120</sync-itemid><sync-prioritymapping>0:0-0/1:700-1000/2:300-699/3:1-299</sync-prioritymapping>
- 775: Text3: <sync-guid>{87699605-B7C1-483B-870B-F6CA6AB2D8D1}</sync-guid><sync-parentguid>{7570C640-B263-480D-9A03-8C17E60903A6}</sync-parentguid><sync-checksum>156481247</sync-checksum><sync-rootid>0</sync-rootid><sync-itemtype>0</sync-itemtype><sync-timestamp>12/30 / Text5: 2004 1:10:05 PM</sync-timestamp><sync-itemid>1185</sync-itemid><sync-prioritymapping>0:0-0/1:700-1000/2:300-699/3:1-299</sync-prioritymapping>
- 776: Text3: <sync-guid>{4149369B-496D-4CC5-91A0-04F0B5066AC0}</sync-guid><sync-parentguid>{7570C640-B263-480D-9A03-8C17E60903A6}</sync-parentguid><sync-checksum>-765331547</sync-checksum><sync-rootid>0</sync-rootid><sync-itemtype>0</sync-itemtype><sync-timestamp>12/3 / Text5: 0/2004 1:10:06 PM</sync-timestamp><sync-itemid>1186</sync-itemid><sync-prioritymapping>0:0-0/1:700-1000/2:300-699/3:1-299</sync-prioritymapping>
- 777: Text3: <sync-guid>{AD608E72-31FC-4042-8BC6-2D9315215745}</sync-guid><sync-parentguid>{7570C640-B263-480D-9A03-8C17E60903A6}</sync-parentguid><sync-checksum>189663376</sync-checksum><sync-rootid>0</sync-rootid><sync-itemtype>0</sync-itemtype><sync-timestamp>12/30 / Text5: 2004 1:10:06 PM</sync-timestamp><sync-itemid>1187</sync-itemid><sync-prioritymapping>0:0-0/1:700-1000/2:300-699/3:1-299</sync-prioritymapping>
- 778: Text3: <sync-guid>{569544C8-79D5-438E-99AD-338E92E3AB33}</sync-guid><sync-parentguid>{7570C640-B263-480D-9A03-8C17E60903A6}</sync-parentguid><sync-checksum>1461940917</sync-checksum><sync-rootid>0</sync-rootid><sync-itemtype>0</sync-itemtype><sync-timestamp>12/3 / Text5: 0/2004 1:10:06 PM</sync-timestamp><sync-itemid>1282</sync-itemid><sync-prioritymapping>0:0-0/1:700-1000/2:300-699/3:1-299</sync-prioritymapping>
- 779: Text3: <sync-guid>{3C89A5C9-67D9-4D26-B974-BEDDF45E8665}</sync-guid><sync-parentguid>{7570C640-B263-480D-9A03-8C17E60903A6}</sync-parentguid><sync-checksum>716786477</sync-checksum><sync-rootid>0</sync-rootid><sync-itemtype>0</sync-itemtype><sync-timestamp>12/30 / Text5: 2004 1:10:07 PM</sync-timestamp><sync-itemid>1283</sync-itemid><sync-prioritymapping>0:0-0/1:700-1000/2:300-699/3:1-299</sync-prioritymapping>
- 780: Text3: <sync-guid>{7FF77071-42AA-46C2-AD4A-09A0F4DDD4EE}</sync-guid><sync-parentguid>{7570C640-B263-480D-9A03-8C17E60903A6}</sync-parentguid><sync-checksum>476632156</sync-checksum><sync-rootid>0</sync-rootid><sync-itemtype>0</sync-itemtype><sync-timestamp>12/30 / Text5: 2004 1:10:07 PM</sync-timestamp><sync-itemid>1284</sync-itemid><sync-prioritymapping>0:0-0/1:700-1000/2:300-699/3:1-299</sync-prioritymapping>

| ID | WBS | Task | Duration | Start | Finish | Baseline start | Baseline finish | Baseline duration | Total slack | Constraint | Text4 |
| --- | --- | --- | --- | --- | --- | --- | --- | --- | --- | --- | --- |
| 781 | 7.2.6 | **Monitor intergroup agreements** | 163d | 2005-01-06 | 2005-08-22 | 2005-01-06 | 2005-08-22 | 163d | 1d |  | {5D4D3F27-F0D6-4F64-873A-3C263FCC7A81} |
| 782 | 7.2.6.1 | Monitor intergroup agreements 1 | 1d | 2005-01-06 | 2005-01-06 | 2005-01-06 | 2005-01-06 | 1d | 163d | start no earlier than 2005-01-03 | {76390141-34D2-4B25-9CAD-35F9B35D2C90} |
| 783 | 7.2.6.2 | Monitor intergroup agreements 2 | 1d | 2005-01-10 | 2005-01-10 | 2005-01-10 | 2005-01-10 | 1d | 161d | start no earlier than 2005-01-10 | {01570177-0FB5-4638-877F-EB28AF556FD2} |
| 784 | 7.2.6.3 | Monitor intergroup agreements 3 | 1d | 2005-01-17 | 2005-01-17 | 2005-01-17 | 2005-01-17 | 1d | 156d | start no earlier than 2005-01-17 | {860CCD15-2143-4459-8E20-D5172C46CBFA} |
| 785 | 7.2.6.4 | Monitor intergroup agreements 4 | 1d | 2005-01-24 | 2005-01-24 | 2005-01-24 | 2005-01-24 | 1d | 151d | start no earlier than 2005-01-24 | {D65A9745-7BBE-4484-8ABA-5B971C24292D} |
| 786 | 7.2.6.5 | Monitor intergroup agreements 5 | 1d | 2005-01-31 | 2005-01-31 | 2005-01-31 | 2005-01-31 | 1d | 146d | start no earlier than 2005-01-31 | {E716DAE8-B572-4E8E-8F30-24ED42AE4FD9} |
| 787 | 7.2.6.6 | Monitor intergroup agreements 6 | 1d | 2005-02-07 | 2005-02-07 | 2005-02-07 | 2005-02-07 | 1d | 141d | start no earlier than 2005-02-07 | {68F8F90F-7723-4FE0-BF8F-9E9E06F79F84} |
| 788 | 7.2.6.7 | Monitor intergroup agreements 7 | 1d | 2005-02-14 | 2005-02-14 | 2005-02-14 | 2005-02-14 | 1d | 136d | start no earlier than 2005-02-14 | {6D877F95-8C99-4546-9869-0824FD047BE3} |
| 789 | 7.2.6.8 | Monitor intergroup agreements 8 | 1d | 2005-02-21 | 2005-02-21 | 2005-02-21 | 2005-02-21 | 1d | 131d | start no earlier than 2005-02-21 | {21CE8E3D-5DBF-4989-8A14-B817C7488C48} |
| 790 | 7.2.6.9 | Monitor intergroup agreements 9 | 1d | 2005-02-28 | 2005-02-28 | 2005-02-28 | 2005-02-28 | 1d | 126d | start no earlier than 2005-02-28 | {6537926C-C48D-48A7-9245-1DE788DA10E0} |
| 791 | 7.2.6.10 | Monitor intergroup agreements 10 | 1d | 2005-03-07 | 2005-03-07 | 2005-03-07 | 2005-03-07 | 1d | 121d | start no earlier than 2005-03-07 | {7519736C-3DA4-4E5A-BCF8-07255EDBAA1E} |
| 792 | 7.2.6.11 | Monitor intergroup agreements 11 | 1d | 2005-03-14 | 2005-03-14 | 2005-03-14 | 2005-03-14 | 1d | 116d | start no earlier than 2005-03-14 | {6F5EDF68-1A7B-4C15-9747-E3479B0D25FB} |
| 793 | 7.2.6.12 | Monitor intergroup agreements 12 | 1d | 2005-03-21 | 2005-03-21 | 2005-03-21 | 2005-03-21 | 1d | 111d | start no earlier than 2005-03-21 | {1742E56D-500B-4977-845C-9C59910A690C} |
| 794 | 7.2.6.13 | Monitor intergroup agreements 13 | 1d | 2005-03-28 | 2005-03-28 | 2005-03-28 | 2005-03-28 | 1d | 106d | start no earlier than 2005-03-28 | {44959277-ADC4-4254-8EDA-9AB195B582F4} |
| 795 | 7.2.6.14 | Monitor intergroup agreements 14 | 1d | 2005-04-04 | 2005-04-04 | 2005-04-04 | 2005-04-04 | 1d | 101d | start no earlier than 2005-04-04 | {75B1F361-A0D1-495B-89C3-F9937E1C168B} |
| 796 | 7.2.6.15 | Monitor intergroup agreements 15 | 1d | 2005-04-11 | 2005-04-11 | 2005-04-11 | 2005-04-11 | 1d | 96d | start no earlier than 2005-04-11 | {B2C77E44-ABF7-4DC2-A48A-3564D384E771} |
| 797 | 7.2.6.16 | Monitor intergroup agreements 16 | 1d | 2005-04-18 | 2005-04-18 | 2005-04-18 | 2005-04-18 | 1d | 91d | start no earlier than 2005-04-18 | {9D2570E1-995A-421D-9AA1-17A4BC00613B} |
| 798 | 7.2.6.17 | Monitor intergroup agreements 17 | 1d | 2005-04-25 | 2005-04-25 | 2005-04-25 | 2005-04-25 | 1d | 86d | start no earlier than 2005-04-25 | {F33699FF-4539-489F-B2DF-610CBD6CCD9E} |
| 799 | 7.2.6.18 | Monitor intergroup agreements 18 | 1d | 2005-05-02 | 2005-05-02 | 2005-05-02 | 2005-05-02 | 1d | 81d | start no earlier than 2005-05-02 | {C6390619-184D-48EF-BA76-11BD7BEE3A75} |
| 800 | 7.2.6.19 | Monitor intergroup agreements 19 | 1d | 2005-05-09 | 2005-05-09 | 2005-05-09 | 2005-05-09 | 1d | 76d | start no earlier than 2005-05-09 | {3BB25340-32C2-46E8-862D-9CA30F1F2F6F} |
| 801 | 7.2.6.20 | Monitor intergroup agreements 20 | 1d | 2005-05-16 | 2005-05-16 | 2005-05-16 | 2005-05-16 | 1d | 71d | start no earlier than 2005-05-16 | {4EF6AF60-154A-4386-9D1B-E3BCDD8BAA91} |
| 802 | 7.2.6.21 | Monitor intergroup agreements 21 | 1d | 2005-05-23 | 2005-05-23 | 2005-05-23 | 2005-05-23 | 1d | 66d | start no earlier than 2005-05-23 | {46B723F9-0ECA-4D31-97D2-306F67545574} |
| 803 | 7.2.6.22 | Monitor intergroup agreements 22 | 1d | 2005-05-30 | 2005-05-30 | 2005-05-30 | 2005-05-30 | 1d | 61d | start no earlier than 2005-05-30 | {0BB3627A-97F8-4A2E-B6CF-CD4BE109551A} |
| 804 | 7.2.6.23 | Monitor intergroup agreements 23 | 1d | 2005-06-06 | 2005-06-06 | 2005-06-06 | 2005-06-06 | 1d | 56d | start no earlier than 2005-06-06 | {EF43F014-F30B-471E-9BD3-EAB69818D045} |
| 805 | 7.2.6.24 | Monitor intergroup agreements 24 | 1d | 2005-06-13 | 2005-06-13 | 2005-06-13 | 2005-06-13 | 1d | 51d | start no earlier than 2005-06-13 | {757DFE31-9370-4BE2-836D-5C54D40B8A32} |
| 806 | 7.2.6.25 | Monitor intergroup agreements 25 | 1d | 2005-06-20 | 2005-06-20 | 2005-06-20 | 2005-06-20 | 1d | 46d | start no earlier than 2005-06-20 | {2ECA7DF9-4461-46B5-9606-6953F904C4FB} |
| 807 | 7.2.6.26 | Monitor intergroup agreements 26 | 1d | 2005-06-27 | 2005-06-27 | 2005-06-27 | 2005-06-27 | 1d | 41d | start no earlier than 2005-06-27 | {E86D5A52-AA84-4047-8D41-00318D61DF9F} |
| 808 | 7.2.6.27 | Monitor intergroup agreements 27 | 1d | 2005-07-04 | 2005-07-04 | 2005-07-04 | 2005-07-04 | 1d | 36d | start no earlier than 2005-07-04 | {60FEA7B4-2335-4489-97F5-B53989D2517B} |
| 809 | 7.2.6.28 | Monitor intergroup agreements 28 | 1d | 2005-07-11 | 2005-07-11 | 2005-07-11 | 2005-07-11 | 1d | 31d | start no earlier than 2005-07-11 | {A4F389B0-7702-4BC2-9B3A-66DDD8C43930} |
| 810 | 7.2.6.29 | Monitor intergroup agreements 29 | 1d | 2005-07-18 | 2005-07-18 | 2005-07-18 | 2005-07-18 | 1d | 26d | start no earlier than 2005-07-18 | {A0F94271-8F71-4145-B0A7-EFAFFE644445} |
| 811 | 7.2.6.30 | Monitor intergroup agreements 30 | 1d | 2005-07-25 | 2005-07-25 | 2005-07-25 | 2005-07-25 | 1d | 21d | start no earlier than 2005-07-25 | {D2C180A3-4390-4975-AFF2-8858B37C1A17} |
| 812 | 7.2.6.31 | Monitor intergroup agreements 31 | 1d | 2005-08-01 | 2005-08-01 | 2005-08-01 | 2005-08-01 | 1d | 16d | start no earlier than 2005-08-01 | {B2F454FD-C737-43C5-ABF9-B71019F7D434} |
| 813 | 7.2.6.32 | Monitor intergroup agreements 32 | 1d | 2005-08-08 | 2005-08-08 | 2005-08-08 | 2005-08-08 | 1d | 11d | start no earlier than 2005-08-08 | {B6F1D164-24B9-4854-8E43-557D97F5F27A} |
| 814 | 7.2.6.33 | Monitor intergroup agreements 33 | 1d | 2005-08-15 | 2005-08-15 | 2005-08-15 | 2005-08-15 | 1d | 6d | start no earlier than 2005-08-15 | {EF14372B-D0F9-467F-8F42-47D187CC23A3} |
| 815 | 7.2.6.34 | Monitor intergroup agreements 34 | 1d | 2005-08-22 | 2005-08-22 | 2005-08-22 | 2005-08-22 | 1d | 1d | start no earlier than 2005-08-22 | {8DD84AD2-0B74-43A4-B041-1BA513436799} |

Notes:
- 781: Text3: <sync-guid>{5D4D3F27-F0D6-4F64-873A-3C263FCC7A81}</sync-guid><sync-parentguid>{55A6A8DD-D0E3-4E39-AE60-4750F7DD10C2}</sync-parentguid><sync-checksum>-836959254</sync-checksum><sync-rootid>0</sync-rootid><sync-itemtype>0</sync-itemtype><sync-timestamp>12/3 / Text5: 0/2004 1:10:22 PM</sync-timestamp><sync-itemid>1200</sync-itemid><sync-prioritymapping>0:0-0/1:700-1000/2:300-699/3:1-299</sync-prioritymapping>
- 782: Text3: <sync-guid>{76390141-34D2-4B25-9CAD-35F9B35D2C90}</sync-guid><sync-parentguid>{5D4D3F27-F0D6-4F64-873A-3C263FCC7A81}</sync-parentguid><sync-checksum>-1374295532</sync-checksum><sync-rootid>0</sync-rootid><sync-itemtype>0</sync-itemtype><sync-timestamp>12 / Text5: 30/2004 1:10:22 PM</sync-timestamp><sync-itemid>1201</sync-itemid><sync-prioritymapping>0:0-0/1:700-1000/2:300-699/3:1-299</sync-prioritymapping>
- 783: Text3: <sync-guid>{01570177-0FB5-4638-877F-EB28AF556FD2}</sync-guid><sync-parentguid>{5D4D3F27-F0D6-4F64-873A-3C263FCC7A81}</sync-parentguid><sync-checksum>-1103157894</sync-checksum><sync-rootid>0</sync-rootid><sync-itemtype>0</sync-itemtype><sync-timestamp>12 / Text5: 30/2004 1:10:23 PM</sync-timestamp><sync-itemid>1202</sync-itemid><sync-prioritymapping>0:0-0/1:700-1000/2:300-699/3:1-299</sync-prioritymapping>
- 784: Text3: <sync-guid>{860CCD15-2143-4459-8E20-D5172C46CBFA}</sync-guid><sync-parentguid>{5D4D3F27-F0D6-4F64-873A-3C263FCC7A81}</sync-parentguid><sync-checksum>1019940518</sync-checksum><sync-rootid>0</sync-rootid><sync-itemtype>0</sync-itemtype><sync-timestamp>12/3 / Text5: 0/2004 1:10:23 PM</sync-timestamp><sync-itemid>1203</sync-itemid><sync-prioritymapping>0:0-0/1:700-1000/2:300-699/3:1-299</sync-prioritymapping>
- 785: Text3: <sync-guid>{D65A9745-7BBE-4484-8ABA-5B971C24292D}</sync-guid><sync-parentguid>{5D4D3F27-F0D6-4F64-873A-3C263FCC7A81}</sync-parentguid><sync-checksum>1206993393</sync-checksum><sync-rootid>0</sync-rootid><sync-itemtype>0</sync-itemtype><sync-timestamp>12/3 / Text5: 0/2004 1:10:23 PM</sync-timestamp><sync-itemid>1204</sync-itemid><sync-prioritymapping>0:0-0/1:700-1000/2:300-699/3:1-299</sync-prioritymapping>
- 786: Text3: <sync-guid>{E716DAE8-B572-4E8E-8F30-24ED42AE4FD9}</sync-guid><sync-parentguid>{5D4D3F27-F0D6-4F64-873A-3C263FCC7A81}</sync-parentguid><sync-checksum>-1581459419</sync-checksum><sync-rootid>0</sync-rootid><sync-itemtype>0</sync-itemtype><sync-timestamp>12 / Text5: 30/2004 1:10:24 PM</sync-timestamp><sync-itemid>1205</sync-itemid><sync-prioritymapping>0:0-0/1:700-1000/2:300-699/3:1-299</sync-prioritymapping>
- 787: Text3: <sync-guid>{68F8F90F-7723-4FE0-BF8F-9E9E06F79F84}</sync-guid><sync-parentguid>{5D4D3F27-F0D6-4F64-873A-3C263FCC7A81}</sync-parentguid><sync-checksum>884983068</sync-checksum><sync-rootid>0</sync-rootid><sync-itemtype>0</sync-itemtype><sync-timestamp>12/30 / Text5: 2004 1:10:24 PM</sync-timestamp><sync-itemid>1206</sync-itemid><sync-prioritymapping>0:0-0/1:700-1000/2:300-699/3:1-299</sync-prioritymapping>
- 788: Text3: <sync-guid>{6D877F95-8C99-4546-9869-0824FD047BE3}</sync-guid><sync-parentguid>{5D4D3F27-F0D6-4F64-873A-3C263FCC7A81}</sync-parentguid><sync-checksum>-1175689987</sync-checksum><sync-rootid>0</sync-rootid><sync-itemtype>0</sync-itemtype><sync-timestamp>12 / Text5: 30/2004 1:10:24 PM</sync-timestamp><sync-itemid>1207</sync-itemid><sync-prioritymapping>0:0-0/1:700-1000/2:300-699/3:1-299</sync-prioritymapping>
- 789: Text3: <sync-guid>{21CE8E3D-5DBF-4989-8A14-B817C7488C48}</sync-guid><sync-parentguid>{5D4D3F27-F0D6-4F64-873A-3C263FCC7A81}</sync-parentguid><sync-checksum>277558687</sync-checksum><sync-rootid>0</sync-rootid><sync-itemtype>0</sync-itemtype><sync-timestamp>12/30 / Text5: 2004 1:10:25 PM</sync-timestamp><sync-itemid>1208</sync-itemid><sync-prioritymapping>0:0-0/1:700-1000/2:300-699/3:1-299</sync-prioritymapping>
- 790: Text3: <sync-guid>{6537926C-C48D-48A7-9245-1DE788DA10E0}</sync-guid><sync-parentguid>{5D4D3F27-F0D6-4F64-873A-3C263FCC7A81}</sync-parentguid><sync-checksum>1656129082</sync-checksum><sync-rootid>0</sync-rootid><sync-itemtype>0</sync-itemtype><sync-timestamp>12/3 / Text5: 0/2004 1:10:25 PM</sync-timestamp><sync-itemid>1209</sync-itemid><sync-prioritymapping>0:0-0/1:700-1000/2:300-699/3:1-299</sync-prioritymapping>
- 791: Text3: <sync-guid>{7519736C-3DA4-4E5A-BCF8-07255EDBAA1E}</sync-guid><sync-parentguid>{5D4D3F27-F0D6-4F64-873A-3C263FCC7A81}</sync-parentguid><sync-checksum>-2121967254</sync-checksum><sync-rootid>0</sync-rootid><sync-itemtype>0</sync-itemtype><sync-timestamp>12 / Text5: 30/2004 1:10:26 PM</sync-timestamp><sync-itemid>1210</sync-itemid><sync-prioritymapping>0:0-0/1:700-1000/2:300-699/3:1-299</sync-prioritymapping>
- 792: Text3: <sync-guid>{6F5EDF68-1A7B-4C15-9747-E3479B0D25FB}</sync-guid><sync-parentguid>{5D4D3F27-F0D6-4F64-873A-3C263FCC7A81}</sync-parentguid><sync-checksum>215414923</sync-checksum><sync-rootid>0</sync-rootid><sync-itemtype>0</sync-itemtype><sync-timestamp>12/30 / Text5: 2004 1:10:26 PM</sync-timestamp><sync-itemid>1211</sync-itemid><sync-prioritymapping>0:0-0/1:700-1000/2:300-699/3:1-299</sync-prioritymapping>
- 793: Text3: <sync-guid>{1742E56D-500B-4977-845C-9C59910A690C}</sync-guid><sync-parentguid>{5D4D3F27-F0D6-4F64-873A-3C263FCC7A81}</sync-parentguid><sync-checksum>1079188713</sync-checksum><sync-rootid>0</sync-rootid><sync-itemtype>0</sync-itemtype><sync-timestamp>12/3 / Text5: 0/2004 1:10:26 PM</sync-timestamp><sync-itemid>1212</sync-itemid><sync-prioritymapping>0:0-0/1:700-1000/2:300-699/3:1-299</sync-prioritymapping>
- 794: Text3: <sync-guid>{44959277-ADC4-4254-8EDA-9AB195B582F4}</sync-guid><sync-parentguid>{5D4D3F27-F0D6-4F64-873A-3C263FCC7A81}</sync-parentguid><sync-checksum>846114636</sync-checksum><sync-rootid>0</sync-rootid><sync-itemtype>0</sync-itemtype><sync-timestamp>12/30 / Text5: 2004 1:10:27 PM</sync-timestamp><sync-itemid>1213</sync-itemid><sync-prioritymapping>0:0-0/1:700-1000/2:300-699/3:1-299</sync-prioritymapping>
- 795: Text3: <sync-guid>{75B1F361-A0D1-495B-89C3-F9937E1C168B}</sync-guid><sync-parentguid>{5D4D3F27-F0D6-4F64-873A-3C263FCC7A81}</sync-parentguid><sync-checksum>115426381</sync-checksum><sync-rootid>0</sync-rootid><sync-itemtype>0</sync-itemtype><sync-timestamp>12/30 / Text5: 2004 1:10:27 PM</sync-timestamp><sync-itemid>1214</sync-itemid><sync-prioritymapping>0:0-0/1:700-1000/2:300-699/3:1-299</sync-prioritymapping>
- 796: Text3: <sync-guid>{B2C77E44-ABF7-4DC2-A48A-3564D384E771}</sync-guid><sync-parentguid>{5D4D3F27-F0D6-4F64-873A-3C263FCC7A81}</sync-parentguid><sync-checksum>-525541991</sync-checksum><sync-rootid>0</sync-rootid><sync-itemtype>0</sync-itemtype><sync-timestamp>12/3 / Text5: 0/2004 1:10:28 PM</sync-timestamp><sync-itemid>1215</sync-itemid><sync-prioritymapping>0:0-0/1:700-1000/2:300-699/3:1-299</sync-prioritymapping>
- 797: Text3: <sync-guid>{9D2570E1-995A-421D-9AA1-17A4BC00613B}</sync-guid><sync-parentguid>{5D4D3F27-F0D6-4F64-873A-3C263FCC7A81}</sync-parentguid><sync-checksum>-1128159300</sync-checksum><sync-rootid>0</sync-rootid><sync-itemtype>0</sync-itemtype><sync-timestamp>12 / Text5: 30/2004 1:10:28 PM</sync-timestamp><sync-itemid>1216</sync-itemid><sync-prioritymapping>0:0-0/1:700-1000/2:300-699/3:1-299</sync-prioritymapping>
- 798: Text3: <sync-guid>{F33699FF-4539-489F-B2DF-610CBD6CCD9E}</sync-guid><sync-parentguid>{5D4D3F27-F0D6-4F64-873A-3C263FCC7A81}</sync-parentguid><sync-checksum>1170418194</sync-checksum><sync-rootid>0</sync-rootid><sync-itemtype>0</sync-itemtype><sync-timestamp>12/3 / Text5: 0/2004 1:10:29 PM</sync-timestamp><sync-itemid>1217</sync-itemid><sync-prioritymapping>0:0-0/1:700-1000/2:300-699/3:1-299</sync-prioritymapping>
- 799: Text3: <sync-guid>{C6390619-184D-48EF-BA76-11BD7BEE3A75}</sync-guid><sync-parentguid>{5D4D3F27-F0D6-4F64-873A-3C263FCC7A81}</sync-parentguid><sync-checksum>-2004020057</sync-checksum><sync-rootid>0</sync-rootid><sync-itemtype>0</sync-itemtype><sync-timestamp>12 / Text5: 30/2004 1:10:29 PM</sync-timestamp><sync-itemid>1218</sync-itemid><sync-prioritymapping>0:0-0/1:700-1000/2:300-699/3:1-299</sync-prioritymapping>
- 800: Text3: <sync-guid>{3BB25340-32C2-46E8-862D-9CA30F1F2F6F}</sync-guid><sync-parentguid>{5D4D3F27-F0D6-4F64-873A-3C263FCC7A81}</sync-parentguid><sync-checksum>-599437551</sync-checksum><sync-rootid>0</sync-rootid><sync-itemtype>0</sync-itemtype><sync-timestamp>12/3 / Text5: 0/2004 1:10:30 PM</sync-timestamp><sync-itemid>1219</sync-itemid><sync-prioritymapping>0:0-0/1:700-1000/2:300-699/3:1-299</sync-prioritymapping>
- 801: Text3: <sync-guid>{4EF6AF60-154A-4386-9D1B-E3BCDD8BAA91}</sync-guid><sync-parentguid>{5D4D3F27-F0D6-4F64-873A-3C263FCC7A81}</sync-parentguid><sync-checksum>1217167783</sync-checksum><sync-rootid>0</sync-rootid><sync-itemtype>0</sync-itemtype><sync-timestamp>12/3 / Text5: 0/2004 1:10:30 PM</sync-timestamp><sync-itemid>1220</sync-itemid><sync-prioritymapping>0:0-0/1:700-1000/2:300-699/3:1-299</sync-prioritymapping>
- 802: Text3: <sync-guid>{46B723F9-0ECA-4D31-97D2-306F67545574}</sync-guid><sync-parentguid>{5D4D3F27-F0D6-4F64-873A-3C263FCC7A81}</sync-parentguid><sync-checksum>710519877</sync-checksum><sync-rootid>0</sync-rootid><sync-itemtype>0</sync-itemtype><sync-timestamp>12/30 / Text5: 2004 1:10:31 PM</sync-timestamp><sync-itemid>1221</sync-itemid><sync-prioritymapping>0:0-0/1:700-1000/2:300-699/3:1-299</sync-prioritymapping>
- 803: Text3: <sync-guid>{0BB3627A-97F8-4A2E-B6CF-CD4BE109551A}</sync-guid><sync-parentguid>{5D4D3F27-F0D6-4F64-873A-3C263FCC7A81}</sync-parentguid><sync-checksum>-1990540252</sync-checksum><sync-rootid>0</sync-rootid><sync-itemtype>0</sync-itemtype><sync-timestamp>12 / Text5: 30/2004 1:10:31 PM</sync-timestamp><sync-itemid>1222</sync-itemid><sync-prioritymapping>0:0-0/1:700-1000/2:300-699/3:1-299</sync-prioritymapping>
- 804: Text3: <sync-guid>{EF43F014-F30B-471E-9BD3-EAB69818D045}</sync-guid><sync-parentguid>{5D4D3F27-F0D6-4F64-873A-3C263FCC7A81}</sync-parentguid><sync-checksum>839454877</sync-checksum><sync-rootid>0</sync-rootid><sync-itemtype>0</sync-itemtype><sync-timestamp>12/30 / Text5: 2004 1:10:32 PM</sync-timestamp><sync-itemid>1223</sync-itemid><sync-prioritymapping>0:0-0/1:700-1000/2:300-699/3:1-299</sync-prioritymapping>
- 805: Text3: <sync-guid>{757DFE31-9370-4BE2-836D-5C54D40B8A32}</sync-guid><sync-parentguid>{5D4D3F27-F0D6-4F64-873A-3C263FCC7A81}</sync-parentguid><sync-checksum>-1498033207</sync-checksum><sync-rootid>0</sync-rootid><sync-itemtype>0</sync-itemtype><sync-timestamp>12 / Text5: 30/2004 1:10:32 PM</sync-timestamp><sync-itemid>1224</sync-itemid><sync-prioritymapping>0:0-0/1:700-1000/2:300-699/3:1-299</sync-prioritymapping>
- 806: Text3: <sync-guid>{2ECA7DF9-4461-46B5-9606-6953F904C4FB}</sync-guid><sync-parentguid>{5D4D3F27-F0D6-4F64-873A-3C263FCC7A81}</sync-parentguid><sync-checksum>-1350646242</sync-checksum><sync-rootid>0</sync-rootid><sync-itemtype>0</sync-itemtype><sync-timestamp>12 / Text5: 30/2004 1:10:32 PM</sync-timestamp><sync-itemid>1225</sync-itemid><sync-prioritymapping>0:0-0/1:700-1000/2:300-699/3:1-299</sync-prioritymapping>
- 807: Text3: <sync-guid>{E86D5A52-AA84-4047-8D41-00318D61DF9F}</sync-guid><sync-parentguid>{5D4D3F27-F0D6-4F64-873A-3C263FCC7A81}</sync-parentguid><sync-checksum>64627778</sync-checksum><sync-rootid>0</sync-rootid><sync-itemtype>0</sync-itemtype><sync-timestamp>12/30 / Text5: 2004 1:10:33 PM</sync-timestamp><sync-itemid>1226</sync-itemid><sync-prioritymapping>0:0-0/1:700-1000/2:300-699/3:1-299</sync-prioritymapping>
- 808: Text3: <sync-guid>{60FEA7B4-2335-4489-97F5-B53989D2517B}</sync-guid><sync-parentguid>{5D4D3F27-F0D6-4F64-873A-3C263FCC7A81}</sync-parentguid><sync-checksum>1221441105</sync-checksum><sync-rootid>0</sync-rootid><sync-itemtype>0</sync-itemtype><sync-timestamp>12/3 / Text5: 0/2004 1:10:33 PM</sync-timestamp><sync-itemid>1227</sync-itemid><sync-prioritymapping>0:0-0/1:700-1000/2:300-699/3:1-299</sync-prioritymapping>
- 809: Text3: <sync-guid>{A4F389B0-7702-4BC2-9B3A-66DDD8C43930}</sync-guid><sync-parentguid>{5D4D3F27-F0D6-4F64-873A-3C263FCC7A81}</sync-parentguid><sync-checksum>1697796869</sync-checksum><sync-rootid>0</sync-rootid><sync-itemtype>0</sync-itemtype><sync-timestamp>12/3 / Text5: 0/2004 1:10:34 PM</sync-timestamp><sync-itemid>1228</sync-itemid><sync-prioritymapping>0:0-0/1:700-1000/2:300-699/3:1-299</sync-prioritymapping>
- 810: Text3: <sync-guid>{A0F94271-8F71-4145-B0A7-EFAFFE644445}</sync-guid><sync-parentguid>{5D4D3F27-F0D6-4F64-873A-3C263FCC7A81}</sync-parentguid><sync-checksum>386916512</sync-checksum><sync-rootid>0</sync-rootid><sync-itemtype>0</sync-itemtype><sync-timestamp>12/30 / Text5: 2004 1:10:34 PM</sync-timestamp><sync-itemid>1229</sync-itemid><sync-prioritymapping>0:0-0/1:700-1000/2:300-699/3:1-299</sync-prioritymapping>
- 811: Text3: <sync-guid>{D2C180A3-4390-4975-AFF2-8858B37C1A17}</sync-guid><sync-parentguid>{5D4D3F27-F0D6-4F64-873A-3C263FCC7A81}</sync-parentguid><sync-checksum>-868376102</sync-checksum><sync-rootid>0</sync-rootid><sync-itemtype>0</sync-itemtype><sync-timestamp>12/3 / Text5: 0/2004 1:10:35 PM</sync-timestamp><sync-itemid>1230</sync-itemid><sync-prioritymapping>0:0-0/1:700-1000/2:300-699/3:1-299</sync-prioritymapping>
- 812: Text3: <sync-guid>{B2F454FD-C737-43C5-ABF9-B71019F7D434}</sync-guid><sync-parentguid>{5D4D3F27-F0D6-4F64-873A-3C263FCC7A81}</sync-parentguid><sync-checksum>353525487</sync-checksum><sync-rootid>0</sync-rootid><sync-itemtype>0</sync-itemtype><sync-timestamp>12/30 / Text5: 2004 1:10:35 PM</sync-timestamp><sync-itemid>1231</sync-itemid><sync-prioritymapping>0:0-0/1:700-1000/2:300-699/3:1-299</sync-prioritymapping>
- 813: Text3: <sync-guid>{B6F1D164-24B9-4854-8E43-557D97F5F27A}</sync-guid><sync-parentguid>{5D4D3F27-F0D6-4F64-873A-3C263FCC7A81}</sync-parentguid><sync-checksum>1233069258</sync-checksum><sync-rootid>0</sync-rootid><sync-itemtype>0</sync-itemtype><sync-timestamp>12/3 / Text5: 0/2004 1:10:35 PM</sync-timestamp><sync-itemid>1232</sync-itemid><sync-prioritymapping>0:0-0/1:700-1000/2:300-699/3:1-299</sync-prioritymapping>
- 814: Text3: <sync-guid>{EF14372B-D0F9-467F-8F42-47D187CC23A3}</sync-guid><sync-parentguid>{5D4D3F27-F0D6-4F64-873A-3C263FCC7A81}</sync-parentguid><sync-checksum>887430482</sync-checksum><sync-rootid>0</sync-rootid><sync-itemtype>0</sync-itemtype><sync-timestamp>12/30 / Text5: 2004 1:10:36 PM</sync-timestamp><sync-itemid>1233</sync-itemid><sync-prioritymapping>0:0-0/1:700-1000/2:300-699/3:1-299</sync-prioritymapping>
- 815: Text3: <sync-guid>{8DD84AD2-0B74-43A4-B041-1BA513436799}</sync-guid><sync-parentguid>{5D4D3F27-F0D6-4F64-873A-3C263FCC7A81}</sync-parentguid><sync-checksum>36995619</sync-checksum><sync-rootid>0</sync-rootid><sync-itemtype>0</sync-itemtype><sync-timestamp>12/30 / Text5: 2004 1:10:36 PM</sync-timestamp><sync-itemid>1234</sync-itemid><sync-prioritymapping>0:0-0/1:700-1000/2:300-699/3:1-299</sync-prioritymapping>

| ID | WBS | Task | Duration | Start | Finish | Baseline start | Baseline finish | Baseline duration | Total slack | Constraint | Text4 |
| --- | --- | --- | --- | --- | --- | --- | --- | --- | --- | --- | --- |
| 816 | 7.2.7 | **Monitor contracts** | 163d | 2005-01-06 | 2005-08-22 | 2005-01-06 | 2005-08-22 | 163d | 1d |  | {08F1890C-817D-4DE6-9F4B-6875D9C7D010} |
| 817 | 7.2.7.1 | Monitor contracts 1 | 1d | 2005-01-06 | 2005-01-06 | 2005-01-06 | 2005-01-06 | 1d | 163d | start no earlier than 2005-01-03 | {11B3401E-15A4-4199-B3E3-2DD996AE9993} |
| 818 | 7.2.7.2 | Monitor contracts 2 | 1d | 2005-01-10 | 2005-01-10 | 2005-01-10 | 2005-01-10 | 1d | 161d | start no earlier than 2005-01-10 | {605C215C-33B1-4295-9778-EC4360C6BCD7} |
| 819 | 7.2.7.3 | Monitor contracts 3 | 1d | 2005-01-17 | 2005-01-17 | 2005-01-17 | 2005-01-17 | 1d | 156d | start no earlier than 2005-01-17 | {2E252EA6-2A4F-496E-84C3-EF64119C343E} |
| 820 | 7.2.7.4 | Monitor contracts 4 | 1d | 2005-01-24 | 2005-01-24 | 2005-01-24 | 2005-01-24 | 1d | 151d | start no earlier than 2005-01-24 | {51C463D3-3733-4885-844D-958514084D35} |
| 821 | 7.2.7.5 | Monitor contracts 5 | 1d | 2005-01-31 | 2005-01-31 | 2005-01-31 | 2005-01-31 | 1d | 146d | start no earlier than 2005-01-31 | {49E6B61C-66E0-4618-B241-27618CB3C317} |
| 822 | 7.2.7.6 | Monitor contracts 6 | 1d | 2005-02-07 | 2005-02-07 | 2005-02-07 | 2005-02-07 | 1d | 141d | start no earlier than 2005-02-07 | {504C9F79-79FC-417E-9F1C-CE625F411A8B} |
| 823 | 7.2.7.7 | Monitor contracts 7 | 1d | 2005-02-14 | 2005-02-14 | 2005-02-14 | 2005-02-14 | 1d | 136d | start no earlier than 2005-02-14 | {FFF5D726-1FA0-40DC-9EC4-ACD7A4556FAC} |
| 824 | 7.2.7.8 | Monitor contracts 8 | 1d | 2005-02-21 | 2005-02-21 | 2005-02-21 | 2005-02-21 | 1d | 131d | start no earlier than 2005-02-21 | {B533A2FE-B54D-4AF6-ADA6-2F55C4866D80} |
| 825 | 7.2.7.9 | Monitor contracts 9 | 1d | 2005-02-28 | 2005-02-28 | 2005-02-28 | 2005-02-28 | 1d | 126d | start no earlier than 2005-02-28 | {3CF7528D-1D0D-441B-8049-3FE038126080} |
| 826 | 7.2.7.10 | Monitor contracts 10 | 1d | 2005-03-07 | 2005-03-07 | 2005-03-07 | 2005-03-07 | 1d | 121d | start no earlier than 2005-03-07 | {018F91D6-28E9-4F5F-BF09-81A1DBCEE2DC} |
| 827 | 7.2.7.11 | Monitor contracts 11 | 1d | 2005-03-14 | 2005-03-14 | 2005-03-14 | 2005-03-14 | 1d | 116d | start no earlier than 2005-03-14 | {8CFAE9EA-273C-448F-B026-72B914C65FCC} |
| 828 | 7.2.7.12 | Monitor contracts 12 | 1d | 2005-03-21 | 2005-03-21 | 2005-03-21 | 2005-03-21 | 1d | 111d | start no earlier than 2005-03-21 | {A6DCEDD6-CA33-450A-8109-60F5664791CB} |
| 829 | 7.2.7.13 | Monitor contracts 13 | 1d | 2005-03-28 | 2005-03-28 | 2005-03-28 | 2005-03-28 | 1d | 106d | start no earlier than 2005-03-28 | {BA9746F1-87DF-4E2D-8721-DBB7F7701B00} |
| 830 | 7.2.7.14 | Monitor contracts 14 | 1d | 2005-04-04 | 2005-04-04 | 2005-04-04 | 2005-04-04 | 1d | 101d | start no earlier than 2005-04-04 | {E2EAA768-67A0-4B70-93E5-B77AA657B624} |
| 831 | 7.2.7.15 | Monitor contracts 15 | 1d | 2005-04-11 | 2005-04-11 | 2005-04-11 | 2005-04-11 | 1d | 96d | start no earlier than 2005-04-11 | {C9F77A3D-8FC0-4634-9DA0-F82D38803ACA} |
| 832 | 7.2.7.16 | Monitor contracts 16 | 1d | 2005-04-18 | 2005-04-18 | 2005-04-18 | 2005-04-18 | 1d | 91d | start no earlier than 2005-04-18 | {E1135A4D-9362-4C34-992A-27733E88DB79} |
| 833 | 7.2.7.17 | Monitor contracts 17 | 1d | 2005-04-25 | 2005-04-25 | 2005-04-25 | 2005-04-25 | 1d | 86d | start no earlier than 2005-04-25 | {14D0E158-4188-48D4-9385-7ED74B7A39E9} |
| 834 | 7.2.7.18 | Monitor contracts 18 | 1d | 2005-05-02 | 2005-05-02 | 2005-05-02 | 2005-05-02 | 1d | 81d | start no earlier than 2005-05-02 | {4C89E2A9-827F-4F86-8ADC-2EF5D96C7AA0} |
| 835 | 7.2.7.19 | Monitor contracts 19 | 1d | 2005-05-09 | 2005-05-09 | 2005-05-09 | 2005-05-09 | 1d | 76d | start no earlier than 2005-05-09 | {3B496A8D-7C1E-49F5-AB9E-A89CD9ED76D1} |
| 836 | 7.2.7.20 | Monitor contracts 20 | 1d | 2005-05-16 | 2005-05-16 | 2005-05-16 | 2005-05-16 | 1d | 71d | start no earlier than 2005-05-16 | {C96C3C92-05CA-4BCA-8F94-B5E2C5577DEF} |
| 837 | 7.2.7.21 | Monitor contracts 21 | 1d | 2005-05-23 | 2005-05-23 | 2005-05-23 | 2005-05-23 | 1d | 66d | start no earlier than 2005-05-23 | {256156C4-0531-4326-8901-078E9A4B7BE8} |
| 838 | 7.2.7.22 | Monitor contracts 22 | 1d | 2005-05-30 | 2005-05-30 | 2005-05-30 | 2005-05-30 | 1d | 61d | start no earlier than 2005-05-30 | {D8984934-7F8C-4354-AD86-86501704B843} |
| 839 | 7.2.7.23 | Monitor contracts 23 | 1d | 2005-06-06 | 2005-06-06 | 2005-06-06 | 2005-06-06 | 1d | 56d | start no earlier than 2005-06-06 | {BFA1DA0D-8DBB-422D-A38D-C958A11B3CB1} |
| 840 | 7.2.7.24 | Monitor contracts 24 | 1d | 2005-06-13 | 2005-06-13 | 2005-06-13 | 2005-06-13 | 1d | 51d | start no earlier than 2005-06-13 | {81D83265-5EE6-4941-B95B-0B09CA67040F} |
| 841 | 7.2.7.25 | Monitor contracts 25 | 1d | 2005-06-20 | 2005-06-20 | 2005-06-20 | 2005-06-20 | 1d | 46d | start no earlier than 2005-06-20 | {938EDC90-FCC5-4802-8379-B82D43D5FA56} |
| 842 | 7.2.7.26 | Monitor contracts 26 | 1d | 2005-06-27 | 2005-06-27 | 2005-06-27 | 2005-06-27 | 1d | 41d | start no earlier than 2005-06-27 | {7540432F-50CB-42E3-92F4-93C9FD706010} |
| 843 | 7.2.7.27 | Monitor contracts 27 | 1d | 2005-07-04 | 2005-07-04 | 2005-07-04 | 2005-07-04 | 1d | 36d | start no earlier than 2005-07-04 | {BE51E946-1A04-4BED-B54F-4B10841FABE4} |
| 844 | 7.2.7.28 | Monitor contracts 28 | 1d | 2005-07-11 | 2005-07-11 | 2005-07-11 | 2005-07-11 | 1d | 31d | start no earlier than 2005-07-11 | {25B9ACF1-9619-453D-B877-197B4B8258D5} |
| 845 | 7.2.7.29 | Monitor contracts 29 | 1d | 2005-07-18 | 2005-07-18 | 2005-07-18 | 2005-07-18 | 1d | 26d | start no earlier than 2005-07-18 | {CC475556-F641-473F-BBF9-2D8802CF5243} |
| 846 | 7.2.7.30 | Monitor contracts 30 | 1d | 2005-07-25 | 2005-07-25 | 2005-07-25 | 2005-07-25 | 1d | 21d | start no earlier than 2005-07-25 | {F52B7197-CB59-4985-8843-321CDBA39B91} |
| 847 | 7.2.7.31 | Monitor contracts 31 | 1d | 2005-08-01 | 2005-08-01 | 2005-08-01 | 2005-08-01 | 1d | 16d | start no earlier than 2005-08-01 | {54FECC25-B196-431B-ABBB-EA23D779F96A} |
| 848 | 7.2.7.32 | Monitor contracts 32 | 1d | 2005-08-08 | 2005-08-08 | 2005-08-08 | 2005-08-08 | 1d | 11d | start no earlier than 2005-08-08 | {29B48CFA-7CD3-4946-BF10-8F587381B2C0} |
| 849 | 7.2.7.33 | Monitor contracts 33 | 1d | 2005-08-15 | 2005-08-15 | 2005-08-15 | 2005-08-15 | 1d | 6d | start no earlier than 2005-08-15 | {6C13C15D-074A-4C31-AE54-6ACDC6E32979} |
| 850 | 7.2.7.34 | Monitor contracts 34 | 1d | 2005-08-22 | 2005-08-22 | 2005-08-22 | 2005-08-22 | 1d | 1d | start no earlier than 2005-08-22 | {B90210E6-F087-4AB3-A6BE-AD36C9F0DF6A} |

Notes:
- 816: Text3: <sync-guid>{08F1890C-817D-4DE6-9F4B-6875D9C7D010}</sync-guid><sync-parentguid>{55A6A8DD-D0E3-4E39-AE60-4750F7DD10C2}</sync-parentguid><sync-checksum>187422613</sync-checksum><sync-rootid>0</sync-rootid><sync-itemtype>0</sync-itemtype><sync-timestamp>12/30 / Text5: 2004 1:10:36 PM</sync-timestamp><sync-itemid>1235</sync-itemid><sync-prioritymapping>0:0-0/1:700-1000/2:300-699/3:1-299</sync-prioritymapping>
- 817: Text3: <sync-guid>{11B3401E-15A4-4199-B3E3-2DD996AE9993}</sync-guid><sync-parentguid>{08F1890C-817D-4DE6-9F4B-6875D9C7D010}</sync-parentguid><sync-checksum>1797471851</sync-checksum><sync-rootid>0</sync-rootid><sync-itemtype>0</sync-itemtype><sync-timestamp>12/3 / Text5: 0/2004 1:10:37 PM</sync-timestamp><sync-itemid>1236</sync-itemid><sync-prioritymapping>0:0-0/1:700-1000/2:300-699/3:1-299</sync-prioritymapping>
- 818: Text3: <sync-guid>{605C215C-33B1-4295-9778-EC4360C6BCD7}</sync-guid><sync-parentguid>{08F1890C-817D-4DE6-9F4B-6875D9C7D010}</sync-parentguid><sync-checksum>2064249093</sync-checksum><sync-rootid>0</sync-rootid><sync-itemtype>0</sync-itemtype><sync-timestamp>12/3 / Text5: 0/2004 1:10:37 PM</sync-timestamp><sync-itemid>1237</sync-itemid><sync-prioritymapping>0:0-0/1:700-1000/2:300-699/3:1-299</sync-prioritymapping>
- 819: Text3: <sync-guid>{2E252EA6-2A4F-496E-84C3-EF64119C343E}</sync-guid><sync-parentguid>{08F1890C-817D-4DE6-9F4B-6875D9C7D010}</sync-parentguid><sync-checksum>-100803879</sync-checksum><sync-rootid>0</sync-rootid><sync-itemtype>0</sync-itemtype><sync-timestamp>12/3 / Text5: 0/2004 1:10:37 PM</sync-timestamp><sync-itemid>1238</sync-itemid><sync-prioritymapping>0:0-0/1:700-1000/2:300-699/3:1-299</sync-prioritymapping>
- 820: Text3: <sync-guid>{51C463D3-3733-4885-844D-958514084D35}</sync-guid><sync-parentguid>{08F1890C-817D-4DE6-9F4B-6875D9C7D010}</sync-parentguid><sync-checksum>-2100849266</sync-checksum><sync-rootid>0</sync-rootid><sync-itemtype>0</sync-itemtype><sync-timestamp>12 / Text5: 30/2004 1:10:38 PM</sync-timestamp><sync-itemid>1239</sync-itemid><sync-prioritymapping>0:0-0/1:700-1000/2:300-699/3:1-299</sync-prioritymapping>
- 821: Text3: <sync-guid>{49E6B61C-66E0-4618-B241-27618CB3C317}</sync-guid><sync-parentguid>{08F1890C-817D-4DE6-9F4B-6875D9C7D010}</sync-parentguid><sync-checksum>1686768730</sync-checksum><sync-rootid>0</sync-rootid><sync-itemtype>0</sync-itemtype><sync-timestamp>12/3 / Text5: 0/2004 1:10:38 PM</sync-timestamp><sync-itemid>1240</sync-itemid><sync-prioritymapping>0:0-0/1:700-1000/2:300-699/3:1-299</sync-prioritymapping>
- 822: Text3: <sync-guid>{504C9F79-79FC-417E-9F1C-CE625F411A8B}</sync-guid><sync-parentguid>{08F1890C-817D-4DE6-9F4B-6875D9C7D010}</sync-parentguid><sync-checksum>-242675357</sync-checksum><sync-rootid>0</sync-rootid><sync-itemtype>0</sync-itemtype><sync-timestamp>12/3 / Text5: 0/2004 1:10:39 PM</sync-timestamp><sync-itemid>1241</sync-itemid><sync-prioritymapping>0:0-0/1:700-1000/2:300-699/3:1-299</sync-prioritymapping>
- 823: Text3: <sync-guid>{FFF5D726-1FA0-40DC-9EC4-ACD7A4556FAC}</sync-guid><sync-parentguid>{08F1890C-817D-4DE6-9F4B-6875D9C7D010}</sync-parentguid><sync-checksum>2094706818</sync-checksum><sync-rootid>0</sync-rootid><sync-itemtype>0</sync-itemtype><sync-timestamp>12/3 / Text5: 0/2004 1:10:39 PM</sync-timestamp><sync-itemid>1242</sync-itemid><sync-prioritymapping>0:0-0/1:700-1000/2:300-699/3:1-299</sync-prioritymapping>
- 824: Text3: <sync-guid>{B533A2FE-B54D-4AF6-ADA6-2F55C4866D80}</sync-guid><sync-parentguid>{08F1890C-817D-4DE6-9F4B-6875D9C7D010}</sync-parentguid><sync-checksum>-708976160</sync-checksum><sync-rootid>0</sync-rootid><sync-itemtype>0</sync-itemtype><sync-timestamp>12/3 / Text5: 0/2004 1:10:39 PM</sync-timestamp><sync-itemid>1243</sync-itemid><sync-prioritymapping>0:0-0/1:700-1000/2:300-699/3:1-299</sync-prioritymapping>
- 825: Text3: <sync-guid>{3CF7528D-1D0D-441B-8049-3FE038126080}</sync-guid><sync-parentguid>{08F1890C-817D-4DE6-9F4B-6875D9C7D010}</sync-parentguid><sync-checksum>-1484762555</sync-checksum><sync-rootid>0</sync-rootid><sync-itemtype>0</sync-itemtype><sync-timestamp>12 / Text5: 30/2004 1:10:40 PM</sync-timestamp><sync-itemid>1244</sync-itemid><sync-prioritymapping>0:0-0/1:700-1000/2:300-699/3:1-299</sync-prioritymapping>
- 826: Text3: <sync-guid>{018F91D6-28E9-4F5F-BF09-81A1DBCEE2DC}</sync-guid><sync-parentguid>{08F1890C-817D-4DE6-9F4B-6875D9C7D010}</sync-parentguid><sync-checksum>1106903827</sync-checksum><sync-rootid>0</sync-rootid><sync-itemtype>0</sync-itemtype><sync-timestamp>12/3 / Text5: 0/2004 1:10:40 PM</sync-timestamp><sync-itemid>1245</sync-itemid><sync-prioritymapping>0:0-0/1:700-1000/2:300-699/3:1-299</sync-prioritymapping>
- 827: Text3: <sync-guid>{8CFAE9EA-273C-448F-B026-72B914C65FCC}</sync-guid><sync-parentguid>{08F1890C-817D-4DE6-9F4B-6875D9C7D010}</sync-parentguid><sync-checksum>-861297934</sync-checksum><sync-rootid>0</sync-rootid><sync-itemtype>0</sync-itemtype><sync-timestamp>12/3 / Text5: 0/2004 1:10:41 PM</sync-timestamp><sync-itemid>1246</sync-itemid><sync-prioritymapping>0:0-0/1:700-1000/2:300-699/3:1-299</sync-prioritymapping>
- 828: Text3: <sync-guid>{A6DCEDD6-CA33-450A-8109-60F5664791CB}</sync-guid><sync-parentguid>{08F1890C-817D-4DE6-9F4B-6875D9C7D010}</sync-parentguid><sync-checksum>-2144582000</sync-checksum><sync-rootid>0</sync-rootid><sync-itemtype>0</sync-itemtype><sync-timestamp>12 / Text5: 30/2004 1:10:41 PM</sync-timestamp><sync-itemid>1247</sync-itemid><sync-prioritymapping>0:0-0/1:700-1000/2:300-699/3:1-299</sync-prioritymapping>
- 829: Text3: <sync-guid>{BA9746F1-87DF-4E2D-8721-DBB7F7701B00}</sync-guid><sync-parentguid>{08F1890C-817D-4DE6-9F4B-6875D9C7D010}</sync-parentguid><sync-checksum>-233704139</sync-checksum><sync-rootid>0</sync-rootid><sync-itemtype>0</sync-itemtype><sync-timestamp>12/3 / Text5: 0/2004 1:10:42 PM</sync-timestamp><sync-itemid>1248</sync-itemid><sync-prioritymapping>0:0-0/1:700-1000/2:300-699/3:1-299</sync-prioritymapping>
- 830: Text3: <sync-guid>{E2EAA768-67A0-4B70-93E5-B77AA657B624}</sync-guid><sync-parentguid>{08F1890C-817D-4DE6-9F4B-6875D9C7D010}</sync-parentguid><sync-checksum>-962716108</sync-checksum><sync-rootid>0</sync-rootid><sync-itemtype>0</sync-itemtype><sync-timestamp>12/3 / Text5: 0/2004 1:10:42 PM</sync-timestamp><sync-itemid>1249</sync-itemid><sync-prioritymapping>0:0-0/1:700-1000/2:300-699/3:1-299</sync-prioritymapping>
- 831: Text3: <sync-guid>{C9F77A3D-8FC0-4634-9DA0-F82D38803ACA}</sync-guid><sync-parentguid>{08F1890C-817D-4DE6-9F4B-6875D9C7D010}</sync-parentguid><sync-checksum>550733792</sync-checksum><sync-rootid>0</sync-rootid><sync-itemtype>0</sync-itemtype><sync-timestamp>12/30 / Text5: 2004 1:10:43 PM</sync-timestamp><sync-itemid>1250</sync-itemid><sync-prioritymapping>0:0-0/1:700-1000/2:300-699/3:1-299</sync-prioritymapping>
- 832: Text3: <sync-guid>{E1135A4D-9362-4C34-992A-27733E88DB79}</sync-guid><sync-parentguid>{08F1890C-817D-4DE6-9F4B-6875D9C7D010}</sync-parentguid><sync-checksum>2092891589</sync-checksum><sync-rootid>0</sync-rootid><sync-itemtype>0</sync-itemtype><sync-timestamp>12/3 / Text5: 0/2004 1:10:43 PM</sync-timestamp><sync-itemid>1251</sync-itemid><sync-prioritymapping>0:0-0/1:700-1000/2:300-699/3:1-299</sync-prioritymapping>
- 833: Text3: <sync-guid>{14D0E158-4188-48D4-9385-7ED74B7A39E9}</sync-guid><sync-parentguid>{08F1890C-817D-4DE6-9F4B-6875D9C7D010}</sync-parentguid><sync-checksum>-2051248021</sync-checksum><sync-rootid>0</sync-rootid><sync-itemtype>0</sync-itemtype><sync-timestamp>12 / Text5: 30/2004 1:10:43 PM</sync-timestamp><sync-itemid>1252</sync-itemid><sync-prioritymapping>0:0-0/1:700-1000/2:300-699/3:1-299</sync-prioritymapping>
- 834: Text3: <sync-guid>{4C89E2A9-827F-4F86-8ADC-2EF5D96C7AA0}</sync-guid><sync-parentguid>{08F1890C-817D-4DE6-9F4B-6875D9C7D010}</sync-parentguid><sync-checksum>1223839454</sync-checksum><sync-rootid>0</sync-rootid><sync-itemtype>0</sync-itemtype><sync-timestamp>12/3 / Text5: 0/2004 1:10:44 PM</sync-timestamp><sync-itemid>1253</sync-itemid><sync-prioritymapping>0:0-0/1:700-1000/2:300-699/3:1-299</sync-prioritymapping>
- 835: Text3: <sync-guid>{3B496A8D-7C1E-49F5-AB9E-A89CD9ED76D1}</sync-guid><sync-parentguid>{08F1890C-817D-4DE6-9F4B-6875D9C7D010}</sync-parentguid><sync-checksum>473568616</sync-checksum><sync-rootid>0</sync-rootid><sync-itemtype>0</sync-itemtype><sync-timestamp>12/30 / Text5: 2004 1:10:44 PM</sync-timestamp><sync-itemid>1254</sync-itemid><sync-prioritymapping>0:0-0/1:700-1000/2:300-699/3:1-299</sync-prioritymapping>
- 836: Text3: <sync-guid>{C96C3C92-05CA-4BCA-8F94-B5E2C5577DEF}</sync-guid><sync-parentguid>{08F1890C-817D-4DE6-9F4B-6875D9C7D010}</sync-parentguid><sync-checksum>-1997284386</sync-checksum><sync-rootid>0</sync-rootid><sync-itemtype>0</sync-itemtype><sync-timestamp>12 / Text5: 30/2004 1:10:45 PM</sync-timestamp><sync-itemid>1255</sync-itemid><sync-prioritymapping>0:0-0/1:700-1000/2:300-699/3:1-299</sync-prioritymapping>
- 837: Text3: <sync-guid>{256156C4-0531-4326-8901-078E9A4B7BE8}</sync-guid><sync-parentguid>{08F1890C-817D-4DE6-9F4B-6875D9C7D010}</sync-parentguid><sync-checksum>-366545348</sync-checksum><sync-rootid>0</sync-rootid><sync-itemtype>0</sync-itemtype><sync-timestamp>12/3 / Text5: 0/2004 1:10:45 PM</sync-timestamp><sync-itemid>1256</sync-itemid><sync-prioritymapping>0:0-0/1:700-1000/2:300-699/3:1-299</sync-prioritymapping>
- 838: Text3: <sync-guid>{D8984934-7F8C-4354-AD86-86501704B843}</sync-guid><sync-parentguid>{08F1890C-817D-4DE6-9F4B-6875D9C7D010}</sync-parentguid><sync-checksum>1227202141</sync-checksum><sync-rootid>0</sync-rootid><sync-itemtype>0</sync-itemtype><sync-timestamp>12/3 / Text5: 0/2004 1:10:46 PM</sync-timestamp><sync-itemid>1257</sync-itemid><sync-prioritymapping>0:0-0/1:700-1000/2:300-699/3:1-299</sync-prioritymapping>
- 839: Text3: <sync-guid>{BFA1DA0D-8DBB-422D-A38D-C958A11B3CB1}</sync-guid><sync-parentguid>{08F1890C-817D-4DE6-9F4B-6875D9C7D010}</sync-parentguid><sync-checksum>-227128604</sync-checksum><sync-rootid>0</sync-rootid><sync-itemtype>0</sync-itemtype><sync-timestamp>12/3 / Text5: 0/2004 1:10:46 PM</sync-timestamp><sync-itemid>1258</sync-itemid><sync-prioritymapping>0:0-0/1:700-1000/2:300-699/3:1-299</sync-prioritymapping>
- 840: Text3: <sync-guid>{81D83265-5EE6-4941-B95B-0B09CA67040F}</sync-guid><sync-parentguid>{08F1890C-817D-4DE6-9F4B-6875D9C7D010}</sync-parentguid><sync-checksum>1724549552</sync-checksum><sync-rootid>0</sync-rootid><sync-itemtype>0</sync-itemtype><sync-timestamp>12/3 / Text5: 0/2004 1:10:47 PM</sync-timestamp><sync-itemid>1259</sync-itemid><sync-prioritymapping>0:0-0/1:700-1000/2:300-699/3:1-299</sync-prioritymapping>
- 841: Text3: <sync-guid>{938EDC90-FCC5-4802-8379-B82D43D5FA56}</sync-guid><sync-parentguid>{08F1890C-817D-4DE6-9F4B-6875D9C7D010}</sync-parentguid><sync-checksum>1862376551</sync-checksum><sync-rootid>0</sync-rootid><sync-itemtype>0</sync-itemtype><sync-timestamp>12/3 / Text5: 0/2004 1:10:47 PM</sync-timestamp><sync-itemid>1260</sync-itemid><sync-prioritymapping>0:0-0/1:700-1000/2:300-699/3:1-299</sync-prioritymapping>
- 842: Text3: <sync-guid>{7540432F-50CB-42E3-92F4-93C9FD706010}</sync-guid><sync-parentguid>{08F1890C-817D-4DE6-9F4B-6875D9C7D010}</sync-parentguid><sync-checksum>-1012564421</sync-checksum><sync-rootid>0</sync-rootid><sync-itemtype>0</sync-itemtype><sync-timestamp>12 / Text5: 30/2004 1:10:48 PM</sync-timestamp><sync-itemid>1261</sync-itemid><sync-prioritymapping>0:0-0/1:700-1000/2:300-699/3:1-299</sync-prioritymapping>
- 843: Text3: <sync-guid>{BE51E946-1A04-4BED-B54F-4B10841FABE4}</sync-guid><sync-parentguid>{08F1890C-817D-4DE6-9F4B-6875D9C7D010}</sync-parentguid><sync-checksum>-2001540056</sync-checksum><sync-rootid>0</sync-rootid><sync-itemtype>0</sync-itemtype><sync-timestamp>12 / Text5: 30/2004 1:10:48 PM</sync-timestamp><sync-itemid>1262</sync-itemid><sync-prioritymapping>0:0-0/1:700-1000/2:300-699/3:1-299</sync-prioritymapping>
- 844: Text3: <sync-guid>{25B9ACF1-9619-453D-B877-197B4B8258D5}</sync-guid><sync-parentguid>{08F1890C-817D-4DE6-9F4B-6875D9C7D010}</sync-parentguid><sync-checksum>-1521677956</sync-checksum><sync-rootid>0</sync-rootid><sync-itemtype>0</sync-itemtype><sync-timestamp>12 / Text5: 30/2004 1:10:49 PM</sync-timestamp><sync-itemid>1263</sync-itemid><sync-prioritymapping>0:0-0/1:700-1000/2:300-699/3:1-299</sync-prioritymapping>
- 845: Text3: <sync-guid>{CC475556-F641-473F-BBF9-2D8802CF5243}</sync-guid><sync-parentguid>{08F1890C-817D-4DE6-9F4B-6875D9C7D010}</sync-parentguid><sync-checksum>-680477991</sync-checksum><sync-rootid>0</sync-rootid><sync-itemtype>0</sync-itemtype><sync-timestamp>12/3 / Text5: 0/2004 1:10:49 PM</sync-timestamp><sync-itemid>1264</sync-itemid><sync-prioritymapping>0:0-0/1:700-1000/2:300-699/3:1-299</sync-prioritymapping>
- 846: Text3: <sync-guid>{F52B7197-CB59-4985-8843-321CDBA39B91}</sync-guid><sync-parentguid>{08F1890C-817D-4DE6-9F4B-6875D9C7D010}</sync-parentguid><sync-checksum>205716387</sync-checksum><sync-rootid>0</sync-rootid><sync-itemtype>0</sync-itemtype><sync-timestamp>12/30 / Text5: 2004 1:10:49 PM</sync-timestamp><sync-itemid>1265</sync-itemid><sync-prioritymapping>0:0-0/1:700-1000/2:300-699/3:1-299</sync-prioritymapping>
- 847: Text3: <sync-guid>{54FECC25-B196-431B-ABBB-EA23D779F96A}</sync-guid><sync-parentguid>{08F1890C-817D-4DE6-9F4B-6875D9C7D010}</sync-parentguid><sync-checksum>-714275690</sync-checksum><sync-rootid>0</sync-rootid><sync-itemtype>0</sync-itemtype><sync-timestamp>12/3 / Text5: 0/2004 1:10:50 PM</sync-timestamp><sync-itemid>1266</sync-itemid><sync-prioritymapping>0:0-0/1:700-1000/2:300-699/3:1-299</sync-prioritymapping>
- 848: Text3: <sync-guid>{29B48CFA-7CD3-4946-BF10-8F587381B2C0}</sync-guid><sync-parentguid>{08F1890C-817D-4DE6-9F4B-6875D9C7D010}</sync-parentguid><sync-checksum>-1996456269</sync-checksum><sync-rootid>0</sync-rootid><sync-itemtype>0</sync-itemtype><sync-timestamp>12 / Text5: 30/2004 1:10:50 PM</sync-timestamp><sync-itemid>1267</sync-itemid><sync-prioritymapping>0:0-0/1:700-1000/2:300-699/3:1-299</sync-prioritymapping>
- 849: Text3: <sync-guid>{6C13C15D-074A-4C31-AE54-6ACDC6E32979}</sync-guid><sync-parentguid>{08F1890C-817D-4DE6-9F4B-6875D9C7D010}</sync-parentguid><sync-checksum>-191215829</sync-checksum><sync-rootid>0</sync-rootid><sync-itemtype>0</sync-itemtype><sync-timestamp>12/3 / Text5: 0/2004 1:10:51 PM</sync-timestamp><sync-itemid>1268</sync-itemid><sync-prioritymapping>0:0-0/1:700-1000/2:300-699/3:1-299</sync-prioritymapping>
- 850: Text3: <sync-guid>{B90210E6-F087-4AB3-A6BE-AD36C9F0DF6A}</sync-guid><sync-parentguid>{08F1890C-817D-4DE6-9F4B-6875D9C7D010}</sync-parentguid><sync-checksum>-1035216806</sync-checksum><sync-rootid>0</sync-rootid><sync-itemtype>0</sync-itemtype><sync-timestamp>12 / Text5: 30/2004 1:10:51 PM</sync-timestamp><sync-itemid>1269</sync-itemid><sync-prioritymapping>0:0-0/1:700-1000/2:300-699/3:1-299</sync-prioritymapping>

| ID | WBS | Task | Duration | Start | Finish | Baseline start | Baseline finish | Baseline duration | Total slack | Constraint | Text4 |
| --- | --- | --- | --- | --- | --- | --- | --- | --- | --- | --- | --- |
| 851 | 7.2.8 | **Review status of related projects** | 163d | 2005-01-06 | 2005-08-22 | 2005-01-06 | 2005-08-22 | 163d | 1d |  | {20DA0495-57E7-4085-A5BC-7B0250DD3375} |
| 852 | 7.2.8.1 | Review status of related projects 1 | 1d | 2005-01-06 | 2005-01-06 | 2005-01-06 | 2005-01-06 | 1d | 163d | start no earlier than 2005-01-03 | {03A433FC-A94C-4F6A-A8DE-3D915069C2CB} |
| 853 | 7.2.8.2 | Review status of related projects 2 | 1d | 2005-01-10 | 2005-01-10 | 2005-01-10 | 2005-01-10 | 1d | 161d | start no earlier than 2005-01-10 | {E2AB4776-B5B5-433B-A012-40FDF05A3416} |
| 854 | 7.2.8.3 | Review status of related projects 3 | 1d | 2005-01-17 | 2005-01-17 | 2005-01-17 | 2005-01-17 | 1d | 156d | start no earlier than 2005-01-17 | {6849F99F-EF14-45B8-B728-5DC158F1E409} |
| 855 | 7.2.8.4 | Review status of related projects 4 | 1d | 2005-01-24 | 2005-01-24 | 2005-01-24 | 2005-01-24 | 1d | 151d | start no earlier than 2005-01-24 | {DF0CAE92-4562-4614-84A0-057AAE2A3B1C} |
| 856 | 7.2.8.5 | Review status of related projects 5 | 1d | 2005-01-31 | 2005-01-31 | 2005-01-31 | 2005-01-31 | 1d | 146d | start no earlier than 2005-01-31 | {6957AE45-D739-4081-9792-166C29BFBAF4} |
| 857 | 7.2.8.6 | Review status of related projects 6 | 1d | 2005-02-07 | 2005-02-07 | 2005-02-07 | 2005-02-07 | 1d | 141d | start no earlier than 2005-02-07 | {4AD1D0E4-B4A3-470F-941D-3EDF383B4B60} |
| 858 | 7.2.8.7 | Review status of related projects 7 | 1d | 2005-02-14 | 2005-02-14 | 2005-02-14 | 2005-02-14 | 1d | 136d | start no earlier than 2005-02-14 | {55785DCB-E03A-4B63-8C89-12CF4F9EC181} |
| 859 | 7.2.8.8 | Review status of related projects 8 | 1d | 2005-02-21 | 2005-02-21 | 2005-02-21 | 2005-02-21 | 1d | 131d | start no earlier than 2005-02-21 | {415553F3-C9E8-417D-9C04-ECFEA6C09945} |
| 860 | 7.2.8.9 | Review status of related projects 9 | 1d | 2005-02-28 | 2005-02-28 | 2005-02-28 | 2005-02-28 | 1d | 126d | start no earlier than 2005-02-28 | {5D4C70C7-D87B-45D6-AC33-ED2DABD6B7C6} |
| 861 | 7.2.8.10 | Review status of related projects 10 | 1d | 2005-03-07 | 2005-03-07 | 2005-03-07 | 2005-03-07 | 1d | 121d | start no earlier than 2005-03-07 | {4818FB46-CB0A-40FD-9C9E-79B4459E39B9} |
| 862 | 7.2.8.11 | Review status of related projects 11 | 1d | 2005-03-14 | 2005-03-14 | 2005-03-14 | 2005-03-14 | 1d | 116d | start no earlier than 2005-03-14 | {EC8B8A76-5B1D-4B24-8E50-A77C9900951C} |
| 863 | 7.2.8.12 | Review status of related projects 12 | 1d | 2005-03-21 | 2005-03-21 | 2005-03-21 | 2005-03-21 | 1d | 111d | start no earlier than 2005-03-21 | {2F652086-78A5-49BA-A903-0A7C6A1A7D60} |
| 864 | 7.2.8.13 | Review status of related projects 13 | 1d | 2005-03-28 | 2005-03-28 | 2005-03-28 | 2005-03-28 | 1d | 106d | start no earlier than 2005-03-28 | {C3D7D76C-3B95-42F9-AED9-1B05D174D3A4} |
| 865 | 7.2.8.14 | Review status of related projects 14 | 1d | 2005-04-04 | 2005-04-04 | 2005-04-04 | 2005-04-04 | 1d | 101d | start no earlier than 2005-04-04 | {B1495236-C5DB-493E-BB27-CEA8BFE69E65} |
| 866 | 7.2.8.15 | Review status of related projects 15 | 1d | 2005-04-11 | 2005-04-11 | 2005-04-11 | 2005-04-11 | 1d | 96d | start no earlier than 2005-04-11 | {5BE014C1-508F-47AB-A22A-B25178BA8BF7} |
| 867 | 7.2.8.16 | Review status of related projects 16 | 1d | 2005-04-18 | 2005-04-18 | 2005-04-18 | 2005-04-18 | 1d | 91d | start no earlier than 2005-04-18 | {524FACC8-84F9-451E-A5EB-1A25DC727FED} |
| 868 | 7.2.8.17 | Review status of related projects 17 | 1d | 2005-04-25 | 2005-04-25 | 2005-04-25 | 2005-04-25 | 1d | 86d | start no earlier than 2005-04-25 | {AE69D131-78F6-46A3-8190-8915EF1375CF} |
| 869 | 7.2.8.18 | Review status of related projects 18 | 1d | 2005-05-02 | 2005-05-02 | 2005-05-02 | 2005-05-02 | 1d | 81d | start no earlier than 2005-05-02 | {186C3C5D-67C9-4C57-8F2F-117E20955E2E} |
| 870 | 7.2.8.19 | Review status of related projects 19 | 1d | 2005-05-09 | 2005-05-09 | 2005-05-09 | 2005-05-09 | 1d | 76d | start no earlier than 2005-05-09 | {B5FBF530-2595-4A40-A7EA-BF57AC8E5C38} |
| 871 | 7.2.8.20 | Review status of related projects 20 | 1d | 2005-05-16 | 2005-05-16 | 2005-05-16 | 2005-05-16 | 1d | 71d | start no earlier than 2005-05-16 | {5EADA581-C731-4250-8EFB-96622D6BAF15} |
| 872 | 7.2.8.21 | Review status of related projects 21 | 1d | 2005-05-23 | 2005-05-23 | 2005-05-23 | 2005-05-23 | 1d | 66d | start no earlier than 2005-05-23 | {B70A5B11-5885-46D7-BAFB-B86EFBD8F295} |
| 873 | 7.2.8.22 | Review status of related projects 22 | 1d | 2005-05-30 | 2005-05-30 | 2005-05-30 | 2005-05-30 | 1d | 61d | start no earlier than 2005-05-30 | {8B64D218-E14A-4BE9-917E-4B3CC4DE57BE} |
| 874 | 7.2.8.23 | Review status of related projects 23 | 1d | 2005-06-06 | 2005-06-06 | 2005-06-06 | 2005-06-06 | 1d | 56d | start no earlier than 2005-06-06 | {A05CEBA0-368E-4318-B170-85916F20684C} |
| 875 | 7.2.8.24 | Review status of related projects 24 | 1d | 2005-06-13 | 2005-06-13 | 2005-06-13 | 2005-06-13 | 1d | 51d | start no earlier than 2005-06-13 | {DB97F187-DC43-4EB7-BDBD-B1F250511634} |
| 876 | 7.2.8.25 | Review status of related projects 25 | 1d | 2005-06-20 | 2005-06-20 | 2005-06-20 | 2005-06-20 | 1d | 46d | start no earlier than 2005-06-20 | {47114526-1C95-4AD3-8D1C-9A03DD145050} |
| 877 | 7.2.8.26 | Review status of related projects 26 | 1d | 2005-06-27 | 2005-06-27 | 2005-06-27 | 2005-06-27 | 1d | 41d | start no earlier than 2005-06-27 | {B9672C88-45C3-4A09-8603-55684752B196} |
| 878 | 7.2.8.27 | Review status of related projects 27 | 1d | 2005-07-04 | 2005-07-04 | 2005-07-04 | 2005-07-04 | 1d | 36d | start no earlier than 2005-07-04 | {68619E18-4488-40C8-85BA-CAB05B7ABF25} |
| 879 | 7.2.8.28 | Review status of related projects 28 | 1d | 2005-07-11 | 2005-07-11 | 2005-07-11 | 2005-07-11 | 1d | 31d | start no earlier than 2005-07-11 | {ED5027C9-519A-4D20-843F-AFC82507A3AA} |
| 880 | 7.2.8.29 | Review status of related projects 29 | 1d | 2005-07-18 | 2005-07-18 | 2005-07-18 | 2005-07-18 | 1d | 26d | start no earlier than 2005-07-18 | {3AE095A4-5936-43A7-9D1E-BADD99824A5F} |
| 881 | 7.2.8.30 | Review status of related projects 30 | 1d | 2005-07-25 | 2005-07-25 | 2005-07-25 | 2005-07-25 | 1d | 21d | start no earlier than 2005-07-25 | {CC1018BB-DF24-4B55-9CF0-B0DEEB2006C2} |
| 882 | 7.2.8.31 | Review status of related projects 31 | 1d | 2005-08-01 | 2005-08-01 | 2005-08-01 | 2005-08-01 | 1d | 16d | start no earlier than 2005-08-01 | {455483FE-A118-4256-B29C-1A630C04F365} |
| 883 | 7.2.8.32 | Review status of related projects 32 | 1d | 2005-08-08 | 2005-08-08 | 2005-08-08 | 2005-08-08 | 1d | 11d | start no earlier than 2005-08-08 | {A21480FD-5A06-4F04-9E56-263BFC010A52} |
| 884 | 7.2.8.33 | Review status of related projects 33 | 1d | 2005-08-15 | 2005-08-15 | 2005-08-15 | 2005-08-15 | 1d | 6d | start no earlier than 2005-08-15 | {6F5683C9-B3F1-4AC9-8AA6-0B592B192BDA} |
| 885 | 7.2.8.34 | Review status of related projects 34 | 1d | 2005-08-22 | 2005-08-22 | 2005-08-22 | 2005-08-22 | 1d | 1d | start no earlier than 2005-08-22 | {2FC448D9-8805-4548-A8FB-187B66959E41} |

Notes:
- 851: Text3: <sync-guid>{20DA0495-57E7-4085-A5BC-7B0250DD3375}</sync-guid><sync-parentguid>{55A6A8DD-D0E3-4E39-AE60-4750F7DD10C2}</sync-parentguid><sync-checksum>-1466626087</sync-checksum><sync-rootid>0</sync-rootid><sync-itemtype>0</sync-itemtype><sync-timestamp>12 / Text5: 30/2004 1:13:38 PM</sync-timestamp><sync-itemid>862</sync-itemid><sync-prioritymapping>0:0-0/1:700-1000/2:300-699/3:1-299</sync-prioritymapping>
- 852: Text3: <sync-guid>{03A433FC-A94C-4F6A-A8DE-3D915069C2CB}</sync-guid><sync-parentguid>{20DA0495-57E7-4085-A5BC-7B0250DD3375}</sync-parentguid><sync-checksum>-929176025</sync-checksum><sync-rootid>0</sync-rootid><sync-itemtype>0</sync-itemtype><sync-timestamp>12/3 / Text5: 0/2004 1:13:34 PM</sync-timestamp><sync-itemid>863</sync-itemid><sync-prioritymapping>0:0-0/1:700-1000/2:300-699/3:1-299</sync-prioritymapping>
- 853: Text3: <sync-guid>{E2AB4776-B5B5-433B-A012-40FDF05A3416}</sync-guid><sync-parentguid>{20DA0495-57E7-4085-A5BC-7B0250DD3375}</sync-parentguid><sync-checksum>-659084983</sync-checksum><sync-rootid>0</sync-rootid><sync-itemtype>0</sync-itemtype><sync-timestamp>12/2 / Text5: 1/2004 9:45:28 AM</sync-timestamp><sync-itemid>864</sync-itemid><sync-prioritymapping>0:0-0/1:700-1000/2:300-699/3:1-299</sync-prioritymapping>
- 854: Text3: <sync-guid>{6849F99F-EF14-45B8-B728-5DC158F1E409}</sync-guid><sync-parentguid>{20DA0495-57E7-4085-A5BC-7B0250DD3375}</sync-parentguid><sync-checksum>1514341013</sync-checksum><sync-rootid>0</sync-rootid><sync-itemtype>0</sync-itemtype><sync-timestamp>12/2 / Text5: 1/2004 9:45:28 AM</sync-timestamp><sync-itemid>865</sync-itemid><sync-prioritymapping>0:0-0/1:700-1000/2:300-699/3:1-299</sync-prioritymapping>
- 855: Text3: <sync-guid>{DF0CAE92-4562-4614-84A0-057AAE2A3B1C}</sync-guid><sync-parentguid>{20DA0495-57E7-4085-A5BC-7B0250DD3375}</sync-parentguid><sync-checksum>561597890</sync-checksum><sync-rootid>0</sync-rootid><sync-itemtype>0</sync-itemtype><sync-timestamp>12/21 / Text5: 2004 9:45:28 AM</sync-timestamp><sync-itemid>866</sync-itemid><sync-prioritymapping>0:0-0/1:700-1000/2:300-699/3:1-299</sync-prioritymapping>
- 856: Text3: <sync-guid>{6957AE45-D739-4081-9792-166C29BFBAF4}</sync-guid><sync-parentguid>{20DA0495-57E7-4085-A5BC-7B0250DD3375}</sync-parentguid><sync-checksum>-952839146</sync-checksum><sync-rootid>0</sync-rootid><sync-itemtype>0</sync-itemtype><sync-timestamp>12/2 / Text5: 1/2004 9:45:28 AM</sync-timestamp><sync-itemid>867</sync-itemid><sync-prioritymapping>0:0-0/1:700-1000/2:300-699/3:1-299</sync-prioritymapping>
- 857: Text3: <sync-guid>{4AD1D0E4-B4A3-470F-941D-3EDF383B4B60}</sync-guid><sync-parentguid>{20DA0495-57E7-4085-A5BC-7B0250DD3375}</sync-parentguid><sync-checksum>1379387695</sync-checksum><sync-rootid>0</sync-rootid><sync-itemtype>0</sync-itemtype><sync-timestamp>12/2 / Text5: 1/2004 9:45:28 AM</sync-timestamp><sync-itemid>868</sync-itemid><sync-prioritymapping>0:0-0/1:700-1000/2:300-699/3:1-299</sync-prioritymapping>
- 858: Text3: <sync-guid>{55785DCB-E03A-4B63-8C89-12CF4F9EC181}</sync-guid><sync-parentguid>{20DA0495-57E7-4085-A5BC-7B0250DD3375}</sync-parentguid><sync-checksum>-547067698</sync-checksum><sync-rootid>0</sync-rootid><sync-itemtype>0</sync-itemtype><sync-timestamp>12/2 / Text5: 1/2004 9:45:28 AM</sync-timestamp><sync-itemid>869</sync-itemid><sync-prioritymapping>0:0-0/1:700-1000/2:300-699/3:1-299</sync-prioritymapping>
- 859: Text3: <sync-guid>{415553F3-C9E8-417D-9C04-ECFEA6C09945}</sync-guid><sync-parentguid>{20DA0495-57E7-4085-A5BC-7B0250DD3375}</sync-parentguid><sync-checksum>1979922860</sync-checksum><sync-rootid>0</sync-rootid><sync-itemtype>0</sync-itemtype><sync-timestamp>12/2 / Text5: 1/2004 9:45:28 AM</sync-timestamp><sync-itemid>870</sync-itemid><sync-prioritymapping>0:0-0/1:700-1000/2:300-699/3:1-299</sync-prioritymapping>
- 860: Text3: <sync-guid>{5D4C70C7-D87B-45D6-AC33-ED2DABD6B7C6}</sync-guid><sync-parentguid>{20DA0495-57E7-4085-A5BC-7B0250DD3375}</sync-parentguid><sync-checksum>71207433</sync-checksum><sync-rootid>0</sync-rootid><sync-itemtype>0</sync-itemtype><sync-timestamp>12/21 / Text5: 2004 9:45:28 AM</sync-timestamp><sync-itemid>871</sync-itemid><sync-prioritymapping>0:0-0/1:700-1000/2:300-699/3:1-299</sync-prioritymapping>
- 861: Text3: <sync-guid>{4818FB46-CB0A-40FD-9C9E-79B4459E39B9}</sync-guid><sync-parentguid>{20DA0495-57E7-4085-A5BC-7B0250DD3375}</sync-parentguid><sync-checksum>1043574896</sync-checksum><sync-rootid>0</sync-rootid><sync-itemtype>0</sync-itemtype><sync-timestamp>12/2 / Text5: 1/2004 9:45:28 AM</sync-timestamp><sync-itemid>872</sync-itemid><sync-prioritymapping>0:0-0/1:700-1000/2:300-699/3:1-299</sync-prioritymapping>
- 862: Text3: <sync-guid>{EC8B8A76-5B1D-4B24-8E50-A77C9900951C}</sync-guid><sync-parentguid>{20DA0495-57E7-4085-A5BC-7B0250DD3375}</sync-parentguid><sync-checksum>-1285549679</sync-checksum><sync-rootid>0</sync-rootid><sync-itemtype>0</sync-itemtype><sync-timestamp>12 / Text5: 21/2004 9:45:29 AM</sync-timestamp><sync-itemid>873</sync-itemid><sync-prioritymapping>0:0-0/1:700-1000/2:300-699/3:1-299</sync-prioritymapping>
- 863: Text3: <sync-guid>{2F652086-78A5-49BA-A903-0A7C6A1A7D60}</sync-guid><sync-parentguid>{20DA0495-57E7-4085-A5BC-7B0250DD3375}</sync-parentguid><sync-checksum>-1706509</sync-checksum><sync-rootid>0</sync-rootid><sync-itemtype>0</sync-itemtype><sync-timestamp>12/21 / Text5: 2004 9:45:29 AM</sync-timestamp><sync-itemid>874</sync-itemid><sync-prioritymapping>0:0-0/1:700-1000/2:300-699/3:1-299</sync-prioritymapping>
- 864: Text3: <sync-guid>{C3D7D76C-3B95-42F9-AED9-1B05D174D3A4}</sync-guid><sync-parentguid>{20DA0495-57E7-4085-A5BC-7B0250DD3375}</sync-parentguid><sync-checksum>-1915206058</sync-checksum><sync-rootid>0</sync-rootid><sync-itemtype>0</sync-itemtype><sync-timestamp>12 / Text5: 21/2004 9:45:29 AM</sync-timestamp><sync-itemid>875</sync-itemid><sync-prioritymapping>0:0-0/1:700-1000/2:300-699/3:1-299</sync-prioritymapping>
- 865: Text3: <sync-guid>{B1495236-C5DB-493E-BB27-CEA8BFE69E65}</sync-guid><sync-parentguid>{20DA0495-57E7-4085-A5BC-7B0250DD3375}</sync-parentguid><sync-checksum>-1185436329</sync-checksum><sync-rootid>0</sync-rootid><sync-itemtype>0</sync-itemtype><sync-timestamp>12 / Text5: 21/2004 9:45:29 AM</sync-timestamp><sync-itemid>876</sync-itemid><sync-prioritymapping>0:0-0/1:700-1000/2:300-699/3:1-299</sync-prioritymapping>
- 866: Text3: <sync-guid>{5BE014C1-508F-47AB-A22A-B25178BA8BF7}</sync-guid><sync-parentguid>{20DA0495-57E7-4085-A5BC-7B0250DD3375}</sync-parentguid><sync-checksum>1595552899</sync-checksum><sync-rootid>0</sync-rootid><sync-itemtype>0</sync-itemtype><sync-timestamp>12/2 / Text5: 1/2004 9:45:29 AM</sync-timestamp><sync-itemid>877</sync-itemid><sync-prioritymapping>0:0-0/1:700-1000/2:300-699/3:1-299</sync-prioritymapping>
- 867: Text3: <sync-guid>{524FACC8-84F9-451E-A5EB-1A25DC727FED}</sync-guid><sync-parentguid>{20DA0495-57E7-4085-A5BC-7B0250DD3375}</sync-parentguid><sync-checksum>58150566</sync-checksum><sync-rootid>0</sync-rootid><sync-itemtype>0</sync-itemtype><sync-timestamp>12/21 / Text5: 2004 9:45:29 AM</sync-timestamp><sync-itemid>878</sync-itemid><sync-prioritymapping>0:0-0/1:700-1000/2:300-699/3:1-299</sync-prioritymapping>
- 868: Text3: <sync-guid>{AE69D131-78F6-46A3-8190-8915EF1375CF}</sync-guid><sync-parentguid>{20DA0495-57E7-4085-A5BC-7B0250DD3375}</sync-parentguid><sync-checksum>-92945656</sync-checksum><sync-rootid>0</sync-rootid><sync-itemtype>0</sync-itemtype><sync-timestamp>12/21 / Text5: 2004 9:45:29 AM</sync-timestamp><sync-itemid>879</sync-itemid><sync-prioritymapping>0:0-0/1:700-1000/2:300-699/3:1-299</sync-prioritymapping>
- 869: Text3: <sync-guid>{186C3C5D-67C9-4C57-8F2F-117E20955E2E}</sync-guid><sync-parentguid>{20DA0495-57E7-4085-A5BC-7B0250DD3375}</sync-parentguid><sync-checksum>926678461</sync-checksum><sync-rootid>0</sync-rootid><sync-itemtype>0</sync-itemtype><sync-timestamp>12/21 / Text5: 2004 9:45:29 AM</sync-timestamp><sync-itemid>880</sync-itemid><sync-prioritymapping>0:0-0/1:700-1000/2:300-699/3:1-299</sync-prioritymapping>
- 870: Text3: <sync-guid>{B5FBF530-2595-4A40-A7EA-BF57AC8E5C38}</sync-guid><sync-parentguid>{20DA0495-57E7-4085-A5BC-7B0250DD3375}</sync-parentguid><sync-checksum>1676912139</sync-checksum><sync-rootid>0</sync-rootid><sync-itemtype>0</sync-itemtype><sync-timestamp>12/2 / Text5: 1/2004 9:45:29 AM</sync-timestamp><sync-itemid>881</sync-itemid><sync-prioritymapping>0:0-0/1:700-1000/2:300-699/3:1-299</sync-prioritymapping>
- 871: Text3: <sync-guid>{5EADA581-C731-4250-8EFB-96622D6BAF15}</sync-guid><sync-parentguid>{20DA0495-57E7-4085-A5BC-7B0250DD3375}</sync-parentguid><sync-checksum>-147167043</sync-checksum><sync-rootid>0</sync-rootid><sync-itemtype>0</sync-itemtype><sync-timestamp>12/2 / Text5: 1/2004 9:45:30 AM</sync-timestamp><sync-itemid>882</sync-itemid><sync-prioritymapping>0:0-0/1:700-1000/2:300-699/3:1-299</sync-prioritymapping>
- 872: Text3: <sync-guid>{B70A5B11-5885-46D7-BAFB-B86EFBD8F295}</sync-guid><sync-parentguid>{20DA0495-57E7-4085-A5BC-7B0250DD3375}</sync-parentguid><sync-checksum>-1779481249</sync-checksum><sync-rootid>0</sync-rootid><sync-itemtype>0</sync-itemtype><sync-timestamp>12 / Text5: 21/2004 9:45:30 AM</sync-timestamp><sync-itemid>883</sync-itemid><sync-prioritymapping>0:0-0/1:700-1000/2:300-699/3:1-299</sync-prioritymapping>
- 873: Text3: <sync-guid>{8B64D218-E14A-4BE9-917E-4B3CC4DE57BE}</sync-guid><sync-parentguid>{20DA0495-57E7-4085-A5BC-7B0250DD3375}</sync-parentguid><sync-checksum>921447742</sync-checksum><sync-rootid>0</sync-rootid><sync-itemtype>0</sync-itemtype><sync-timestamp>12/21 / Text5: 2004 9:45:30 AM</sync-timestamp><sync-itemid>884</sync-itemid><sync-prioritymapping>0:0-0/1:700-1000/2:300-699/3:1-299</sync-prioritymapping>
- 874: Text3: <sync-guid>{A05CEBA0-368E-4318-B170-85916F20684C}</sync-guid><sync-parentguid>{20DA0495-57E7-4085-A5BC-7B0250DD3375}</sync-parentguid><sync-checksum>-1916798585</sync-checksum><sync-rootid>0</sync-rootid><sync-itemtype>0</sync-itemtype><sync-timestamp>12 / Text5: 21/2004 9:45:30 AM</sync-timestamp><sync-itemid>885</sync-itemid><sync-prioritymapping>0:0-0/1:700-1000/2:300-699/3:1-299</sync-prioritymapping>
- 875: Text3: <sync-guid>{DB97F187-DC43-4EB7-BDBD-B1F250511634}</sync-guid><sync-parentguid>{20DA0495-57E7-4085-A5BC-7B0250DD3375}</sync-parentguid><sync-checksum>419642067</sync-checksum><sync-rootid>0</sync-rootid><sync-itemtype>0</sync-itemtype><sync-timestamp>12/21 / Text5: 2004 9:45:30 AM</sync-timestamp><sync-itemid>886</sync-itemid><sync-prioritymapping>0:0-0/1:700-1000/2:300-699/3:1-299</sync-prioritymapping>
- 876: Text3: <sync-guid>{47114526-1C95-4AD3-8D1C-9A03DD145050}</sync-guid><sync-parentguid>{20DA0495-57E7-4085-A5BC-7B0250DD3375}</sync-parentguid><sync-checksum>281554692</sync-checksum><sync-rootid>0</sync-rootid><sync-itemtype>0</sync-itemtype><sync-timestamp>12/21 / Text5: 2004 9:45:30 AM</sync-timestamp><sync-itemid>887</sync-itemid><sync-prioritymapping>0:0-0/1:700-1000/2:300-699/3:1-299</sync-prioritymapping>
- 877: Text3: <sync-guid>{B9672C88-45C3-4A09-8603-55684752B196}</sync-guid><sync-parentguid>{20DA0495-57E7-4085-A5BC-7B0250DD3375}</sync-parentguid><sync-checksum>-1133720232</sync-checksum><sync-rootid>0</sync-rootid><sync-itemtype>0</sync-itemtype><sync-timestamp>12 / Text5: 30/2004 1:10:10 PM</sync-timestamp><sync-itemid>1121</sync-itemid><sync-prioritymapping>0:0-0/1:700-1000/2:300-699/3:1-299</sync-prioritymapping>
- 878: Text3: <sync-guid>{68619E18-4488-40C8-85BA-CAB05B7ABF25}</sync-guid><sync-parentguid>{20DA0495-57E7-4085-A5BC-7B0250DD3375}</sync-parentguid><sync-checksum>-142909621</sync-checksum><sync-rootid>0</sync-rootid><sync-itemtype>0</sync-itemtype><sync-timestamp>12/3 / Text5: 0/2004 1:10:11 PM</sync-timestamp><sync-itemid>1122</sync-itemid><sync-prioritymapping>0:0-0/1:700-1000/2:300-699/3:1-299</sync-prioritymapping>
- 879: Text3: <sync-guid>{ED5027C9-519A-4D20-843F-AFC82507A3AA}</sync-guid><sync-parentguid>{20DA0495-57E7-4085-A5BC-7B0250DD3375}</sync-parentguid><sync-checksum>-628835809</sync-checksum><sync-rootid>0</sync-rootid><sync-itemtype>0</sync-itemtype><sync-timestamp>12/3 / Text5: 0/2004 1:10:11 PM</sync-timestamp><sync-itemid>1123</sync-itemid><sync-prioritymapping>0:0-0/1:700-1000/2:300-699/3:1-299</sync-prioritymapping>
- 880: Text3: <sync-guid>{3AE095A4-5936-43A7-9D1E-BADD99824A5F}</sync-guid><sync-parentguid>{20DA0495-57E7-4085-A5BC-7B0250DD3375}</sync-parentguid><sync-checksum>-1464268358</sync-checksum><sync-rootid>0</sync-rootid><sync-itemtype>0</sync-itemtype><sync-timestamp>12 / Text5: 30/2004 1:10:12 PM</sync-timestamp><sync-itemid>1188</sync-itemid><sync-prioritymapping>0:0-0/1:700-1000/2:300-699/3:1-299</sync-prioritymapping>
- 881: Text3: <sync-guid>{CC1018BB-DF24-4B55-9CF0-B0DEEB2006C2}</sync-guid><sync-parentguid>{20DA0495-57E7-4085-A5BC-7B0250DD3375}</sync-parentguid><sync-checksum>1938507968</sync-checksum><sync-rootid>0</sync-rootid><sync-itemtype>0</sync-itemtype><sync-timestamp>12/3 / Text5: 0/2004 1:10:12 PM</sync-timestamp><sync-itemid>1189</sync-itemid><sync-prioritymapping>0:0-0/1:700-1000/2:300-699/3:1-299</sync-prioritymapping>
- 882: Text3: <sync-guid>{455483FE-A118-4256-B29C-1A630C04F365}</sync-guid><sync-parentguid>{20DA0495-57E7-4085-A5BC-7B0250DD3375}</sync-parentguid><sync-checksum>-1432045579</sync-checksum><sync-rootid>0</sync-rootid><sync-itemtype>0</sync-itemtype><sync-timestamp>12 / Text5: 30/2004 1:10:12 PM</sync-timestamp><sync-itemid>1190</sync-itemid><sync-prioritymapping>0:0-0/1:700-1000/2:300-699/3:1-299</sync-prioritymapping>
- 883: Text3: <sync-guid>{A21480FD-5A06-4F04-9E56-263BFC010A52}</sync-guid><sync-parentguid>{20DA0495-57E7-4085-A5BC-7B0250DD3375}</sync-parentguid><sync-checksum>-154546736</sync-checksum><sync-rootid>0</sync-rootid><sync-itemtype>0</sync-itemtype><sync-timestamp>12/3 / Text5: 0/2004 1:10:13 PM</sync-timestamp><sync-itemid>1285</sync-itemid><sync-prioritymapping>0:0-0/1:700-1000/2:300-699/3:1-299</sync-prioritymapping>
- 884: Text3: <sync-guid>{6F5683C9-B3F1-4AC9-8AA6-0B592B192BDA}</sync-guid><sync-parentguid>{20DA0495-57E7-4085-A5BC-7B0250DD3375}</sync-parentguid><sync-checksum>-1957432248</sync-checksum><sync-rootid>0</sync-rootid><sync-itemtype>0</sync-itemtype><sync-timestamp>12 / Text5: 30/2004 1:10:13 PM</sync-timestamp><sync-itemid>1286</sync-itemid><sync-prioritymapping>0:0-0/1:700-1000/2:300-699/3:1-299</sync-prioritymapping>
- 885: Text3: <sync-guid>{2FC448D9-8805-4548-A8FB-187B66959E41}</sync-guid><sync-parentguid>{20DA0495-57E7-4085-A5BC-7B0250DD3375}</sync-parentguid><sync-checksum>-1115526343</sync-checksum><sync-rootid>0</sync-rootid><sync-itemtype>0</sync-itemtype><sync-timestamp>12 / Text5: 30/2004 1:10:13 PM</sync-timestamp><sync-itemid>1287</sync-itemid><sync-prioritymapping>0:0-0/1:700-1000/2:300-699/3:1-299</sync-prioritymapping>

| ID | WBS | Task | Duration | Start | Finish | Baseline start | Baseline finish | Baseline duration | Total slack | Constraint | Text4 |
| --- | --- | --- | --- | --- | --- | --- | --- | --- | --- | --- | --- |
| 886 | 7.2.9 | **Produce project status reports** | 163d | 2005-01-06 | 2005-08-22 | 2005-01-06 | 2005-08-22 | 163d | 1d |  | {A118358A-81F9-4BBE-90EF-1B08667C1158} |
| 887 | 7.2.9.1 | Produce project status reports 1 | 1d | 2005-01-06 | 2005-01-06 | 2005-01-06 | 2005-01-06 | 1d | 163d | start no earlier than 2005-01-03 | {5A016931-4428-4B9C-9B21-F61D0C879C52} |
| 888 | 7.2.9.2 | Produce project status reports 2 | 1d | 2005-01-10 | 2005-01-10 | 2005-01-10 | 2005-01-10 | 1d | 161d | start no earlier than 2005-01-10 | {D34A8432-24B4-4A90-B953-3618923A69B7} |
| 889 | 7.2.9.3 | Produce project status reports 3 | 1d | 2005-01-17 | 2005-01-17 | 2005-01-17 | 2005-01-17 | 1d | 156d | start no earlier than 2005-01-17 | {42B82851-B8A1-49E6-8CF2-17C099C40B8E} |
| 890 | 7.2.9.4 | Produce project status reports 4 | 1d | 2005-01-24 | 2005-01-24 | 2005-01-24 | 2005-01-24 | 1d | 151d | start no earlier than 2005-01-24 | {56EF6119-0940-4561-8A13-8D22BAC1A130} |
| 891 | 7.2.9.5 | Produce project status reports 5 | 1d | 2005-01-31 | 2005-01-31 | 2005-01-31 | 2005-01-31 | 1d | 146d | start no earlier than 2005-01-31 | {3CC9FA1D-06C5-401B-A659-4F374DFB1EBB} |
| 892 | 7.2.9.6 | Produce project status reports 6 | 1d | 2005-02-07 | 2005-02-07 | 2005-02-07 | 2005-02-07 | 1d | 141d | start no earlier than 2005-02-07 | {FE9C0497-50EB-4D14-97FB-A2EE96A75C71} |
| 893 | 7.2.9.7 | Produce project status reports 7 | 1d | 2005-02-14 | 2005-02-14 | 2005-02-14 | 2005-02-14 | 1d | 136d | start no earlier than 2005-02-14 | {A55ACFA3-8CF1-46A4-BDDF-60DAF483498E} |
| 894 | 7.2.9.8 | Produce project status reports 8 | 1d | 2005-02-21 | 2005-02-21 | 2005-02-21 | 2005-02-21 | 1d | 131d | start no earlier than 2005-02-21 | {669801E9-AE38-456F-9B26-C6A8ADFE8CBC} |
| 895 | 7.2.9.9 | Produce project status reports 9 | 1d | 2005-02-28 | 2005-02-28 | 2005-02-28 | 2005-02-28 | 1d | 126d | start no earlier than 2005-02-28 | {5E7F35B2-EF75-4C0B-8C74-EE310FD0DA9B} |
| 896 | 7.2.9.10 | Produce project status reports 10 | 1d | 2005-03-07 | 2005-03-07 | 2005-03-07 | 2005-03-07 | 1d | 121d | start no earlier than 2005-03-07 | {587B6215-F6D2-47C7-A8D2-D00FD843668A} |
| 897 | 7.2.9.11 | Produce project status reports 11 | 1d | 2005-03-14 | 2005-03-14 | 2005-03-14 | 2005-03-14 | 1d | 116d | start no earlier than 2005-03-14 | {44F1C919-5512-442D-B1CB-82DEC4F13DF2} |
| 898 | 7.2.9.12 | Produce project status reports 12 | 1d | 2005-03-21 | 2005-03-21 | 2005-03-21 | 2005-03-21 | 1d | 111d | start no earlier than 2005-03-21 | {00600DDF-BBC3-4DD8-A432-BE36414C717F} |
| 899 | 7.2.9.13 | Produce project status reports 13 | 1d | 2005-03-28 | 2005-03-28 | 2005-03-28 | 2005-03-28 | 1d | 106d | start no earlier than 2005-03-28 | {58C2A0A5-D3E7-4DC9-A6DA-4860BAB1D9F9} |
| 900 | 7.2.9.14 | Produce project status reports 14 | 1d | 2005-04-04 | 2005-04-04 | 2005-04-04 | 2005-04-04 | 1d | 101d | start no earlier than 2005-04-04 | {7F96D20F-6F85-4D65-BC07-E0169A5A902A} |
| 901 | 7.2.9.15 | Produce project status reports 15 | 1d | 2005-04-11 | 2005-04-11 | 2005-04-11 | 2005-04-11 | 1d | 96d | start no earlier than 2005-04-11 | {0A554BB8-A7C7-43F5-ADFF-E1892A766227} |
| 902 | 7.2.9.16 | Produce project status reports 16 | 1d | 2005-04-18 | 2005-04-18 | 2005-04-18 | 2005-04-18 | 1d | 91d | start no earlier than 2005-04-18 | {D64795E8-6E11-48BD-B86A-9A9CA38FF49B} |
| 903 | 7.2.9.17 | Produce project status reports 17 | 1d | 2005-04-25 | 2005-04-25 | 2005-04-25 | 2005-04-25 | 1d | 86d | start no earlier than 2005-04-25 | {0210BEFD-04F1-488C-9124-7C9868A116E1} |
| 904 | 7.2.9.18 | Produce project status reports 18 | 1d | 2005-05-02 | 2005-05-02 | 2005-05-02 | 2005-05-02 | 1d | 81d | start no earlier than 2005-05-02 | {C872BC42-BE54-4F63-B65C-C13CFA2F0562} |
| 905 | 7.2.9.19 | Produce project status reports 19 | 1d | 2005-05-09 | 2005-05-09 | 2005-05-09 | 2005-05-09 | 1d | 76d | start no earlier than 2005-05-09 | {526F35A1-7957-4784-85B7-5D5D1EC4F21D} |
| 906 | 7.2.9.20 | Produce project status reports 20 | 1d | 2005-05-16 | 2005-05-16 | 2005-05-16 | 2005-05-16 | 1d | 71d | start no earlier than 2005-05-16 | {4BB5BBE8-8B5F-4306-84AF-5D03DDCAE766} |
| 907 | 7.2.9.21 | Produce project status reports 21 | 1d | 2005-05-23 | 2005-05-23 | 2005-05-23 | 2005-05-23 | 1d | 66d | start no earlier than 2005-05-23 | {0D491C28-E2E6-46EE-9971-280D8EC7062A} |
| 908 | 7.2.9.22 | Produce project status reports 22 | 1d | 2005-05-30 | 2005-05-30 | 2005-05-30 | 2005-05-30 | 1d | 61d | start no earlier than 2005-05-30 | {9EE5187D-943B-4982-8955-CCF85F1E8657} |
| 909 | 7.2.9.23 | Produce project status reports 23 | 1d | 2005-06-06 | 2005-06-06 | 2005-06-06 | 2005-06-06 | 1d | 56d | start no earlier than 2005-06-06 | {0088095D-F194-4215-BC5F-F771C14206B5} |
| 910 | 7.2.9.24 | Produce project status reports 24 | 1d | 2005-06-13 | 2005-06-13 | 2005-06-13 | 2005-06-13 | 1d | 51d | start no earlier than 2005-06-13 | {706E92D0-D656-410E-A4AA-DE63EC2F7347} |
| 911 | 7.2.9.25 | Produce project status reports 25 | 1d | 2005-06-20 | 2005-06-20 | 2005-06-20 | 2005-06-20 | 1d | 46d | start no earlier than 2005-06-20 | {06583E67-9B8D-416E-BFBC-5B32E04289AB} |
| 912 | 7.2.9.26 | Produce project status reports 26 | 1d | 2005-06-27 | 2005-06-27 | 2005-06-27 | 2005-06-27 | 1d | 41d | start no earlier than 2005-06-27 | {72B26ED7-B450-45DB-AB59-F99BB6AD0B9F} |
| 913 | 7.2.9.27 | Produce project status reports 27 | 1d | 2005-07-04 | 2005-07-04 | 2005-07-04 | 2005-07-04 | 1d | 36d | start no earlier than 2005-07-04 | {9ECCC48B-3427-4280-996E-4E7F66377C56} |
| 914 | 7.2.9.28 | Produce project status reports 28 | 1d | 2005-07-11 | 2005-07-11 | 2005-07-11 | 2005-07-11 | 1d | 31d | start no earlier than 2005-07-11 | {AB46D77C-34BD-4161-A177-F7E503220BD8} |
| 915 | 7.2.9.29 | Produce project status reports 29 | 1d | 2005-07-18 | 2005-07-18 | 2005-07-18 | 2005-07-18 | 1d | 26d | start no earlier than 2005-07-18 | {73792CC6-4D6C-4C31-A1BD-DAFCE4B2008D} |
| 916 | 7.2.9.30 | Produce project status reports 30 | 1d | 2005-07-25 | 2005-07-25 | 2005-07-25 | 2005-07-25 | 1d | 21d | start no earlier than 2005-07-25 | {AAC8EB02-F999-4B8C-98D4-8981F927779D} |
| 917 | 7.2.9.31 | Produce project status reports 31 | 1d | 2005-08-01 | 2005-08-01 | 2005-08-01 | 2005-08-01 | 1d | 16d | start no earlier than 2005-08-01 | {D2CD4FE3-CB64-4DD3-BCFB-2536B993EF52} |
| 918 | 7.2.9.32 | Produce project status reports 32 | 1d | 2005-08-08 | 2005-08-08 | 2005-08-08 | 2005-08-08 | 1d | 11d | start no earlier than 2005-08-08 | {ABA67922-7F85-4154-920A-84915FF78AB5} |
| 919 | 7.2.9.33 | Produce project status reports 33 | 1d | 2005-08-15 | 2005-08-15 | 2005-08-15 | 2005-08-15 | 1d | 6d | start no earlier than 2005-08-15 | {3AD0C980-2757-4EB7-ABB5-1AAC2800FF80} |
| 920 | 7.2.9.34 | Produce project status reports 34 | 1d | 2005-08-22 | 2005-08-22 | 2005-08-22 | 2005-08-22 | 1d | 1d | start no earlier than 2005-08-22 | {B93C3B60-5F10-49AC-9D22-004C26305611} |

Notes:
- 886: Text3: <sync-guid>{A118358A-81F9-4BBE-90EF-1B08667C1158}</sync-guid><sync-parentguid>{55A6A8DD-D0E3-4E39-AE60-4750F7DD10C2}</sync-parentguid><sync-checksum>-1762983210</sync-checksum><sync-rootid>0</sync-rootid><sync-itemtype>0</sync-itemtype><sync-timestamp>12 / Text5: 30/2004 1:13:42 PM</sync-timestamp><sync-itemid>789</sync-itemid><sync-prioritymapping>0:0-0/1:700-1000/2:300-699/3:1-299</sync-prioritymapping>
- 887: Text3: <sync-guid>{5A016931-4428-4B9C-9B21-F61D0C879C52}</sync-guid><sync-parentguid>{A118358A-81F9-4BBE-90EF-1B08667C1158}</sync-parentguid><sync-checksum>-152835288</sync-checksum><sync-rootid>0</sync-rootid><sync-itemtype>0</sync-itemtype><sync-timestamp>12/3 / Text5: 0/2004 1:13:38 PM</sync-timestamp><sync-itemid>790</sync-itemid><sync-prioritymapping>0:0-0/1:700-1000/2:300-699/3:1-299</sync-prioritymapping>
- 888: Text3: <sync-guid>{D34A8432-24B4-4A90-B953-3618923A69B7}</sync-guid><sync-parentguid>{A118358A-81F9-4BBE-90EF-1B08667C1158}</sync-parentguid><sync-checksum>-423025594</sync-checksum><sync-rootid>0</sync-rootid><sync-itemtype>0</sync-itemtype><sync-timestamp>12/2 / Text5: 1/2004 9:45:30 AM</sync-timestamp><sync-itemid>791</sync-itemid><sync-prioritymapping>0:0-0/1:700-1000/2:300-699/3:1-299</sync-prioritymapping>
- 889: Text3: <sync-guid>{42B82851-B8A1-49E6-8CF2-17C099C40B8E}</sync-guid><sync-parentguid>{A118358A-81F9-4BBE-90EF-1B08667C1158}</sync-parentguid><sync-checksum>1681723290</sync-checksum><sync-rootid>0</sync-rootid><sync-itemtype>0</sync-itemtype><sync-timestamp>12/2 / Text5: 1/2004 9:45:30 AM</sync-timestamp><sync-itemid>792</sync-itemid><sync-prioritymapping>0:0-0/1:700-1000/2:300-699/3:1-299</sync-prioritymapping>
- 890: Text3: <sync-guid>{56EF6119-0940-4561-8A13-8D22BAC1A130}</sync-guid><sync-parentguid>{A118358A-81F9-4BBE-90EF-1B08667C1158}</sync-parentguid><sync-checksum>520569037</sync-checksum><sync-rootid>0</sync-rootid><sync-itemtype>0</sync-itemtype><sync-timestamp>12/21 / Text5: 2004 9:45:31 AM</sync-timestamp><sync-itemid>793</sync-itemid><sync-prioritymapping>0:0-0/1:700-1000/2:300-699/3:1-299</sync-prioritymapping>
- 891: Text3: <sync-guid>{3CC9FA1D-06C5-401B-A659-4F374DFB1EBB}</sync-guid><sync-parentguid>{A118358A-81F9-4BBE-90EF-1B08667C1158}</sync-parentguid><sync-checksum>-112535271</sync-checksum><sync-rootid>0</sync-rootid><sync-itemtype>0</sync-itemtype><sync-timestamp>12/2 / Text5: 1/2004 9:45:31 AM</sync-timestamp><sync-itemid>794</sync-itemid><sync-prioritymapping>0:0-0/1:700-1000/2:300-699/3:1-299</sync-prioritymapping>
- 892: Text3: <sync-guid>{FE9C0497-50EB-4D14-97FB-A2EE96A75C71}</sync-guid><sync-parentguid>{A118358A-81F9-4BBE-90EF-1B08667C1158}</sync-parentguid><sync-checksum>1816773664</sync-checksum><sync-rootid>0</sync-rootid><sync-itemtype>0</sync-itemtype><sync-timestamp>12/2 / Text5: 1/2004 9:45:31 AM</sync-timestamp><sync-itemid>795</sync-itemid><sync-prioritymapping>0:0-0/1:700-1000/2:300-699/3:1-299</sync-prioritymapping>
- 893: Text3: <sync-guid>{A55ACFA3-8CF1-46A4-BDDF-60DAF483498E}</sync-guid><sync-parentguid>{A118358A-81F9-4BBE-90EF-1B08667C1158}</sync-parentguid><sync-checksum>-518363711</sync-checksum><sync-rootid>0</sync-rootid><sync-itemtype>0</sync-itemtype><sync-timestamp>12/2 / Text5: 1/2004 9:45:31 AM</sync-timestamp><sync-itemid>796</sync-itemid><sync-prioritymapping>0:0-0/1:700-1000/2:300-699/3:1-299</sync-prioritymapping>
- 894: Text3: <sync-guid>{669801E9-AE38-456F-9B26-C6A8ADFE8CBC}</sync-guid><sync-parentguid>{A118358A-81F9-4BBE-90EF-1B08667C1158}</sync-parentguid><sync-checksum>1216165027</sync-checksum><sync-rootid>0</sync-rootid><sync-itemtype>0</sync-itemtype><sync-timestamp>12/2 / Text5: 1/2004 9:45:31 AM</sync-timestamp><sync-itemid>797</sync-itemid><sync-prioritymapping>0:0-0/1:700-1000/2:300-699/3:1-299</sync-prioritymapping>
- 895: Text3: <sync-guid>{5E7F35B2-EF75-4C0B-8C74-EE310FD0DA9B}</sync-guid><sync-parentguid>{A118358A-81F9-4BBE-90EF-1B08667C1158}</sync-parentguid><sync-checksum>977307398</sync-checksum><sync-rootid>0</sync-rootid><sync-itemtype>0</sync-itemtype><sync-timestamp>12/21 / Text5: 2004 9:45:31 AM</sync-timestamp><sync-itemid>798</sync-itemid><sync-prioritymapping>0:0-0/1:700-1000/2:300-699/3:1-299</sync-prioritymapping>
- 896: Text3: <sync-guid>{587B6215-F6D2-47C7-A8D2-D00FD843668A}</sync-guid><sync-parentguid>{A118358A-81F9-4BBE-90EF-1B08667C1158}</sync-parentguid><sync-checksum>-1364012052</sync-checksum><sync-rootid>0</sync-rootid><sync-itemtype>0</sync-itemtype><sync-timestamp>12 / Text5: 21/2004 9:45:31 AM</sync-timestamp><sync-itemid>799</sync-itemid><sync-prioritymapping>0:0-0/1:700-1000/2:300-699/3:1-299</sync-prioritymapping>
- 897: Text3: <sync-guid>{44F1C919-5512-442D-B1CB-82DEC4F13DF2}</sync-guid><sync-parentguid>{A118358A-81F9-4BBE-90EF-1B08667C1158}</sync-parentguid><sync-checksum>601977357</sync-checksum><sync-rootid>0</sync-rootid><sync-itemtype>0</sync-itemtype><sync-timestamp>12/21 / Text5: 2004 9:45:31 AM</sync-timestamp><sync-itemid>800</sync-itemid><sync-prioritymapping>0:0-0/1:700-1000/2:300-699/3:1-299</sync-prioritymapping>
- 898: Text3: <sync-guid>{00600DDF-BBC3-4DD8-A432-BE36414C717F}</sync-guid><sync-parentguid>{A118358A-81F9-4BBE-90EF-1B08667C1158}</sync-parentguid><sync-checksum>1868863087</sync-checksum><sync-rootid>0</sync-rootid><sync-itemtype>0</sync-itemtype><sync-timestamp>12/2 / Text5: 1/2004 9:45:31 AM</sync-timestamp><sync-itemid>801</sync-itemid><sync-prioritymapping>0:0-0/1:700-1000/2:300-699/3:1-299</sync-prioritymapping>
- 899: Text3: <sync-guid>{58C2A0A5-D3E7-4DC9-A6DA-4860BAB1D9F9}</sync-guid><sync-parentguid>{A118358A-81F9-4BBE-90EF-1B08667C1158}</sync-parentguid><sync-checksum>492381642</sync-checksum><sync-rootid>0</sync-rootid><sync-itemtype>0</sync-itemtype><sync-timestamp>12/21 / Text5: 2004 9:45:32 AM</sync-timestamp><sync-itemid>802</sync-itemid><sync-prioritymapping>0:0-0/1:700-1000/2:300-699/3:1-299</sync-prioritymapping>
- 900: Text3: <sync-guid>{7F96D20F-6F85-4D65-BC07-E0169A5A902A}</sync-guid><sync-parentguid>{A118358A-81F9-4BBE-90EF-1B08667C1158}</sync-parentguid><sync-checksum>701943499</sync-checksum><sync-rootid>0</sync-rootid><sync-itemtype>0</sync-itemtype><sync-timestamp>12/21 / Text5: 2004 9:45:32 AM</sync-timestamp><sync-itemid>803</sync-itemid><sync-prioritymapping>0:0-0/1:700-1000/2:300-699/3:1-299</sync-prioritymapping>
- 901: Text3: <sync-guid>{0A554BB8-A7C7-43F5-ADFF-E1892A766227}</sync-guid><sync-parentguid>{A118358A-81F9-4BBE-90EF-1B08667C1158}</sync-parentguid><sync-checksum>-811903201</sync-checksum><sync-rootid>0</sync-rootid><sync-itemtype>0</sync-itemtype><sync-timestamp>12/2 / Text5: 1/2004 9:45:32 AM</sync-timestamp><sync-itemid>804</sync-itemid><sync-prioritymapping>0:0-0/1:700-1000/2:300-699/3:1-299</sync-prioritymapping>
- 902: Text3: <sync-guid>{D64795E8-6E11-48BD-B86A-9A9CA38FF49B}</sync-guid><sync-parentguid>{A118358A-81F9-4BBE-90EF-1B08667C1158}</sync-parentguid><sync-checksum>-1812583110</sync-checksum><sync-rootid>0</sync-rootid><sync-itemtype>0</sync-itemtype><sync-timestamp>12 / Text5: 21/2004 9:45:32 AM</sync-timestamp><sync-itemid>805</sync-itemid><sync-prioritymapping>0:0-0/1:700-1000/2:300-699/3:1-299</sync-prioritymapping>
- 903: Text3: <sync-guid>{0210BEFD-04F1-488C-9124-7C9868A116E1}</sync-guid><sync-parentguid>{A118358A-81F9-4BBE-90EF-1B08667C1158}</sync-parentguid><sync-checksum>1794416788</sync-checksum><sync-rootid>0</sync-rootid><sync-itemtype>0</sync-itemtype><sync-timestamp>12/2 / Text5: 1/2004 9:45:32 AM</sync-timestamp><sync-itemid>806</sync-itemid><sync-prioritymapping>0:0-0/1:700-1000/2:300-699/3:1-299</sync-prioritymapping>
- 904: Text3: <sync-guid>{C872BC42-BE54-4F63-B65C-C13CFA2F0562}</sync-guid><sync-parentguid>{A118358A-81F9-4BBE-90EF-1B08667C1158}</sync-parentguid><sync-checksum>-1480942047</sync-checksum><sync-rootid>0</sync-rootid><sync-itemtype>0</sync-itemtype><sync-timestamp>12 / Text5: 21/2004 9:45:32 AM</sync-timestamp><sync-itemid>807</sync-itemid><sync-prioritymapping>0:0-0/1:700-1000/2:300-699/3:1-299</sync-prioritymapping>
- 905: Text3: <sync-guid>{526F35A1-7957-4784-85B7-5D5D1EC4F21D}</sync-guid><sync-parentguid>{A118358A-81F9-4BBE-90EF-1B08667C1158}</sync-parentguid><sync-checksum>-210582121</sync-checksum><sync-rootid>0</sync-rootid><sync-itemtype>0</sync-itemtype><sync-timestamp>12/2 / Text5: 1/2004 9:45:32 AM</sync-timestamp><sync-itemid>808</sync-itemid><sync-prioritymapping>0:0-0/1:700-1000/2:300-699/3:1-299</sync-prioritymapping>
- 906: Text3: <sync-guid>{4BB5BBE8-8B5F-4306-84AF-5D03DDCAE766}</sync-guid><sync-parentguid>{A118358A-81F9-4BBE-90EF-1B08667C1158}</sync-parentguid><sync-checksum>1740311329</sync-checksum><sync-rootid>0</sync-rootid><sync-itemtype>0</sync-itemtype><sync-timestamp>12/2 / Text5: 1/2004 9:45:32 AM</sync-timestamp><sync-itemid>809</sync-itemid><sync-prioritymapping>0:0-0/1:700-1000/2:300-699/3:1-299</sync-prioritymapping>
- 907: Text3: <sync-guid>{0D491C28-E2E6-46EE-9971-280D8EC7062A}</sync-guid><sync-parentguid>{A118358A-81F9-4BBE-90EF-1B08667C1158}</sync-parentguid><sync-checksum>91104963</sync-checksum><sync-rootid>0</sync-rootid><sync-itemtype>0</sync-itemtype><sync-timestamp>12/21 / Text5: 2004 9:45:32 AM</sync-timestamp><sync-itemid>810</sync-itemid><sync-prioritymapping>0:0-0/1:700-1000/2:300-699/3:1-299</sync-prioritymapping>
- 908: Text3: <sync-guid>{9EE5187D-943B-4982-8955-CCF85F1E8657}</sync-guid><sync-parentguid>{A118358A-81F9-4BBE-90EF-1B08667C1158}</sync-parentguid><sync-checksum>-1502785886</sync-checksum><sync-rootid>0</sync-rootid><sync-itemtype>0</sync-itemtype><sync-timestamp>12 / Text5: 21/2004 9:45:33 AM</sync-timestamp><sync-itemid>811</sync-itemid><sync-prioritymapping>0:0-0/1:700-1000/2:300-699/3:1-299</sync-prioritymapping>
- 909: Text3: <sync-guid>{0088095D-F194-4215-BC5F-F771C14206B5}</sync-guid><sync-parentguid>{A118358A-81F9-4BBE-90EF-1B08667C1158}</sync-parentguid><sync-checksum>490641947</sync-checksum><sync-rootid>0</sync-rootid><sync-itemtype>0</sync-itemtype><sync-timestamp>12/21 / Text5: 2004 9:45:33 AM</sync-timestamp><sync-itemid>812</sync-itemid><sync-prioritymapping>0:0-0/1:700-1000/2:300-699/3:1-299</sync-prioritymapping>
- 910: Text3: <sync-guid>{706E92D0-D656-410E-A4AA-DE63EC2F7347}</sync-guid><sync-parentguid>{A118358A-81F9-4BBE-90EF-1B08667C1158}</sync-parentguid><sync-checksum>-1987946161</sync-checksum><sync-rootid>0</sync-rootid><sync-itemtype>0</sync-itemtype><sync-timestamp>12 / Text5: 21/2004 9:45:33 AM</sync-timestamp><sync-itemid>896</sync-itemid><sync-prioritymapping>0:0-0/1:700-1000/2:300-699/3:1-299</sync-prioritymapping>
- 911: Text3: <sync-guid>{06583E67-9B8D-416E-BFBC-5B32E04289AB}</sync-guid><sync-parentguid>{A118358A-81F9-4BBE-90EF-1B08667C1158}</sync-parentguid><sync-checksum>-2142679912</sync-checksum><sync-rootid>0</sync-rootid><sync-itemtype>0</sync-itemtype><sync-timestamp>12 / Text5: 21/2004 9:45:33 AM</sync-timestamp><sync-itemid>897</sync-itemid><sync-prioritymapping>0:0-0/1:700-1000/2:300-699/3:1-299</sync-prioritymapping>
- 912: Text3: <sync-guid>{72B26ED7-B450-45DB-AB59-F99BB6AD0B9F}</sync-guid><sync-parentguid>{A118358A-81F9-4BBE-90EF-1B08667C1158}</sync-parentguid><sync-checksum>753774276</sync-checksum><sync-rootid>0</sync-rootid><sync-itemtype>0</sync-itemtype><sync-timestamp>12/30 / Text5: 2004 1:10:17 PM</sync-timestamp><sync-itemid>1124</sync-itemid><sync-prioritymapping>0:0-0/1:700-1000/2:300-699/3:1-299</sync-prioritymapping>
- 913: Text3: <sync-guid>{9ECCC48B-3427-4280-996E-4E7F66377C56}</sync-guid><sync-parentguid>{A118358A-81F9-4BBE-90EF-1B08667C1158}</sync-parentguid><sync-checksum>1744452823</sync-checksum><sync-rootid>0</sync-rootid><sync-itemtype>0</sync-itemtype><sync-timestamp>12/3 / Text5: 0/2004 1:10:17 PM</sync-timestamp><sync-itemid>1125</sync-itemid><sync-prioritymapping>0:0-0/1:700-1000/2:300-699/3:1-299</sync-prioritymapping>
- 914: Text3: <sync-guid>{AB46D77C-34BD-4161-A177-F7E503220BD8}</sync-guid><sync-parentguid>{A118358A-81F9-4BBE-90EF-1B08667C1158}</sync-parentguid><sync-checksum>1241897347</sync-checksum><sync-rootid>0</sync-rootid><sync-itemtype>0</sync-itemtype><sync-timestamp>12/3 / Text5: 0/2004 1:10:18 PM</sync-timestamp><sync-itemid>1126</sync-itemid><sync-prioritymapping>0:0-0/1:700-1000/2:300-699/3:1-299</sync-prioritymapping>
- 915: Text3: <sync-guid>{73792CC6-4D6C-4C31-A1BD-DAFCE4B2008D}</sync-guid><sync-parentguid>{A118358A-81F9-4BBE-90EF-1B08667C1158}</sync-parentguid><sync-checksum>943221286</sync-checksum><sync-rootid>0</sync-rootid><sync-itemtype>0</sync-itemtype><sync-timestamp>12/30 / Text5: 2004 1:10:18 PM</sync-timestamp><sync-itemid>1191</sync-itemid><sync-prioritymapping>0:0-0/1:700-1000/2:300-699/3:1-299</sync-prioritymapping>
- 916: Text3: <sync-guid>{AAC8EB02-F999-4B8C-98D4-8981F927779D}</sync-guid><sync-parentguid>{A118358A-81F9-4BBE-90EF-1B08667C1158}</sync-parentguid><sync-checksum>-485872804</sync-checksum><sync-rootid>0</sync-rootid><sync-itemtype>0</sync-itemtype><sync-timestamp>12/3 / Text5: 0/2004 1:10:18 PM</sync-timestamp><sync-itemid>1192</sync-itemid><sync-prioritymapping>0:0-0/1:700-1000/2:300-699/3:1-299</sync-prioritymapping>
- 917: Text3: <sync-guid>{D2CD4FE3-CB64-4DD3-BCFB-2536B993EF52}</sync-guid><sync-parentguid>{A118358A-81F9-4BBE-90EF-1B08667C1158}</sync-parentguid><sync-checksum>975557737</sync-checksum><sync-rootid>0</sync-rootid><sync-itemtype>0</sync-itemtype><sync-timestamp>12/30 / Text5: 2004 1:10:19 PM</sync-timestamp><sync-itemid>1193</sync-itemid><sync-prioritymapping>0:0-0/1:700-1000/2:300-699/3:1-299</sync-prioritymapping>
- 918: Text3: <sync-guid>{ABA67922-7F85-4154-920A-84915FF78AB5}</sync-guid><sync-parentguid>{A118358A-81F9-4BBE-90EF-1B08667C1158}</sync-parentguid><sync-checksum>1716039244</sync-checksum><sync-rootid>0</sync-rootid><sync-itemtype>0</sync-itemtype><sync-timestamp>12/3 / Text5: 0/2004 1:10:19 PM</sync-timestamp><sync-itemid>1288</sync-itemid><sync-prioritymapping>0:0-0/1:700-1000/2:300-699/3:1-299</sync-prioritymapping>
- 919: Text3: <sync-guid>{3AD0C980-2757-4EB7-ABB5-1AAC2800FF80}</sync-guid><sync-parentguid>{A118358A-81F9-4BBE-90EF-1B08667C1158}</sync-parentguid><sync-checksum>466786260</sync-checksum><sync-rootid>0</sync-rootid><sync-itemtype>0</sync-itemtype><sync-timestamp>12/30 / Text5: 2004 1:10:20 PM</sync-timestamp><sync-itemid>1289</sync-itemid><sync-prioritymapping>0:0-0/1:700-1000/2:300-699/3:1-299</sync-prioritymapping>
- 920: Text3: <sync-guid>{B93C3B60-5F10-49AC-9D22-004C26305611}</sync-guid><sync-parentguid>{A118358A-81F9-4BBE-90EF-1B08667C1158}</sync-parentguid><sync-checksum>755173541</sync-checksum><sync-rootid>0</sync-rootid><sync-itemtype>0</sync-itemtype><sync-timestamp>12/30 / Text5: 2004 1:10:20 PM</sync-timestamp><sync-itemid>1290</sync-itemid><sync-prioritymapping>0:0-0/1:700-1000/2:300-699/3:1-299</sync-prioritymapping>

| ID | WBS | Task | Type | Duration | Start | Finish | Predecessors | Baseline start | Baseline finish | Baseline duration | Total slack | Free slack | Constraint | Text4 |
| --- | --- | --- | --- | --- | --- | --- | --- | --- | --- | --- | --- | --- | --- | --- |
| 921 | 7.2.10 | **Build management reports** |  | 148d | 2005-01-06 | 2005-08-01 |  | 2005-01-06 | 2005-08-01 | 148d | 16d |  |  | {3EBB864E-A734-4AF9-9B41-EF394542252A} |
| 922 | 7.2.10.1 | Build management reports 1 |  | 1d | 2005-01-06 | 2005-01-06 |  | 2005-01-06 | 2005-01-06 | 1d | 163d |  | start no earlier than 2005-01-03 | {4F99EC55-BDFF-4F2B-9279-A0CCDBF100F9} |
| 923 | 7.2.10.2 | Build management reports 2 |  | 1d | 2005-02-07 | 2005-02-07 |  | 2005-02-07 | 2005-02-07 | 1d | 141d |  | start no earlier than 2005-02-07 | {AD53EFCC-3342-4944-9B77-E8DA8B52FD77} |
| 924 | 7.2.10.3 | Build management reports 3 |  | 1d | 2005-03-07 | 2005-03-07 |  | 2005-03-07 | 2005-03-07 | 1d | 121d |  | start no earlier than 2005-03-07 | {5E7F54F1-0AD3-4E0D-93EA-4D7A3AB8A47F} |
| 925 | 7.2.10.4 | Build management reports 4 |  | 1d | 2005-04-04 | 2005-04-04 |  | 2005-04-04 | 2005-04-04 | 1d | 101d |  | start no earlier than 2005-04-04 | {5EBF483E-E2CB-4818-8634-9FCC58DFD8BA} |
| 926 | 7.2.10.5 | Build management reports 5 |  | 1d | 2005-05-02 | 2005-05-02 |  | 2005-05-02 | 2005-05-02 | 1d | 81d |  | start no earlier than 2005-05-02 | {6B8F700B-E1BC-4364-920F-373CD574C1F2} |
| 927 | 7.2.10.6 | Build management reports 6 |  | 1d | 2005-06-06 | 2005-06-06 |  | 2005-06-06 | 2005-06-06 | 1d | 56d |  | start no earlier than 2005-06-06 | {670A96F3-E273-45BE-9DBD-64C51B25E60F} |
| 928 | 7.2.10.7 | Build management reports 7 |  | 1d | 2005-07-04 | 2005-07-04 |  | 2005-07-04 | 2005-07-04 | 1d | 36d |  | start no earlier than 2005-07-04 | {565B8004-63F9-4A90-9BFC-7D840CE63260} |
| 929 | 7.2.10.8 | Build management reports 8 |  | 1d | 2005-08-01 | 2005-08-01 |  | 2005-08-01 | 2005-08-01 | 1d | 16d |  | start no earlier than 2005-08-01 | {1AB2C33F-4E56-41D6-858F-ABE975227B4E} |
| 930 | 7.2.11 | **Participate in operations reviews** |  | 148d | 2005-01-06 | 2005-08-01 |  | 2005-01-06 | 2005-08-01 | 148d | 16d |  |  | {157265F8-9C4B-4635-98CB-623080486C69} |
| 931 | 7.2.11.1 | Participate in operations reviews 1 |  | 1d | 2005-01-06 | 2005-01-06 |  | 2005-01-06 | 2005-01-06 | 1d | 163d |  | start no earlier than 2005-01-03 | {7C6016DC-AB77-4E57-BC3B-9F93FFD47C74} |
| 932 | 7.2.11.2 | Participate in operations reviews 2 |  | 1d | 2005-02-07 | 2005-02-07 |  | 2005-02-07 | 2005-02-07 | 1d | 141d |  | start no earlier than 2005-02-07 | {3835DE29-46B4-4960-9360-F57E1578658D} |
| 933 | 7.2.11.3 | Participate in operations reviews 3 |  | 1d | 2005-03-07 | 2005-03-07 |  | 2005-03-07 | 2005-03-07 | 1d | 121d |  | start no earlier than 2005-03-07 | {DC5600CC-235B-44D3-92C1-99519EB50705} |
| 934 | 7.2.11.4 | Participate in operations reviews 4 |  | 1d | 2005-04-04 | 2005-04-04 |  | 2005-04-04 | 2005-04-04 | 1d | 101d |  | start no earlier than 2005-04-04 | {69F635CC-5245-4991-BBD1-C512B1EA7F9D} |
| 935 | 7.2.11.5 | Participate in operations reviews 5 |  | 1d | 2005-05-02 | 2005-05-02 |  | 2005-05-02 | 2005-05-02 | 1d | 81d |  | start no earlier than 2005-05-02 | {E185988C-09E2-40D1-9754-48EB7700ADE1} |
| 936 | 7.2.11.6 | Participate in operations reviews 6 |  | 1d | 2005-06-06 | 2005-06-06 |  | 2005-06-06 | 2005-06-06 | 1d | 56d |  | start no earlier than 2005-06-06 | {962D549C-965E-4373-BD8E-27737156BE32} |
| 937 | 7.2.11.7 | Participate in operations reviews 7 |  | 1d | 2005-07-04 | 2005-07-04 |  | 2005-07-04 | 2005-07-04 | 1d | 36d |  | start no earlier than 2005-07-04 | {6414AB12-A57F-4CC8-917D-5FC708345433} |
| 938 | 7.2.11.8 | Participate in operations reviews 8 |  | 1d | 2005-08-01 | 2005-08-01 |  | 2005-08-01 | 2005-08-01 | 1d | 16d |  | start no earlier than 2005-08-01 | {F92E0B59-1D22-4C8F-802A-D5D84F1B5412} |
| 939 | 7.3 | **Project Shutdown** |  | 2d | 2005-08-19 | 2005-08-22 |  | 2005-08-19 | 2005-08-22 | 2d | 1d |  |  | {8FEE8DA1-BA7E-4DFF-B2EB-67EC905FA2AB} |
| 940 | 7.3.1 | Close change logs |  | 2d | 2005-08-19 | 2005-08-22 | 605FF | 2005-08-19 | 2005-08-22 | 2d | 1d | 0d |  | {91F978A1-F5F9-4C36-9C0B-3C1A51E59D1F} |
| 941 | 7.3.2 | Close defect logs |  | 2d | 2005-08-19 | 2005-08-22 | 605FF | 2005-08-19 | 2005-08-22 | 2d | 1d |  |  | {A53B57F5-E19C-4698-8A62-242185CB1015} |
| 942 | 7.3.3 | Close risk management logs |  | 2d | 2005-08-19 | 2005-08-22 | 605FF | 2005-08-19 | 2005-08-22 | 2d | 1d | 0d |  | {809EAE4A-8AEA-4752-B6E6-B77B0E54D16D} |
| 943 | 7.3.4 | Close issue management logs |  | 2d | 2005-08-19 | 2005-08-22 | 605FF | 2005-08-19 | 2005-08-22 | 2d | 1d | 0d |  | {0FB57E91-EC91-4E93-8E95-6FF5A4DFF4B6} |
| 944 | 7.3.5 | Close project control files | milestone | 0d | 2005-08-22 | 2005-08-22 | 942, 943, 940 | 2005-08-22 | 2005-08-22 | 0d | 1d |  |  | {44DB1219-F0DB-4C6B-B69C-889C5352D60D} |

Notes:
- 921: Text3: <sync-guid>{3EBB864E-A734-4AF9-9B41-EF394542252A}</sync-guid><sync-parentguid>{55A6A8DD-D0E3-4E39-AE60-4750F7DD10C2}</sync-parentguid><sync-checksum>533439860</sync-checksum><sync-rootid>0</sync-rootid><sync-itemtype>0</sync-itemtype><sync-timestamp>12/30 / Text5: 2004 1:13:43 PM</sync-timestamp><sync-itemid>816</sync-itemid><sync-prioritymapping>0:0-0/1:700-1000/2:300-699/3:1-299</sync-prioritymapping>
- 922: Text3: <sync-guid>{4F99EC55-BDFF-4F2B-9279-A0CCDBF100F9}</sync-guid><sync-parentguid>{3EBB864E-A734-4AF9-9B41-EF394542252A}</sync-parentguid><sync-checksum>-152315288</sync-checksum><sync-rootid>0</sync-rootid><sync-itemtype>0</sync-itemtype><sync-timestamp>12/3 / Text5: 0/2004 1:13:42 PM</sync-timestamp><sync-itemid>817</sync-itemid><sync-prioritymapping>0:0-0/1:700-1000/2:300-699/3:1-299</sync-prioritymapping>
- 923: Text3: <sync-guid>{AD53EFCC-3342-4944-9B77-E8DA8B52FD77}</sync-guid><sync-parentguid>{3EBB864E-A734-4AF9-9B41-EF394542252A}</sync-parentguid><sync-checksum>820012640</sync-checksum><sync-rootid>0</sync-rootid><sync-itemtype>0</sync-itemtype><sync-timestamp>12/21 / Text5: 2004 9:45:33 AM</sync-timestamp><sync-itemid>818</sync-itemid><sync-prioritymapping>0:0-0/1:700-1000/2:300-699/3:1-299</sync-prioritymapping>
- 924: Text3: <sync-guid>{5E7F54F1-0AD3-4E0D-93EA-4D7A3AB8A47F}</sync-guid><sync-parentguid>{3EBB864E-A734-4AF9-9B41-EF394542252A}</sync-parentguid><sync-checksum>660135807</sync-checksum><sync-rootid>0</sync-rootid><sync-itemtype>0</sync-itemtype><sync-timestamp>12/21 / Text5: 2004 9:45:33 AM</sync-timestamp><sync-itemid>819</sync-itemid><sync-prioritymapping>0:0-0/1:700-1000/2:300-699/3:1-299</sync-prioritymapping>
- 925: Text3: <sync-guid>{5EBF483E-E2CB-4818-8634-9FCC58DFD8BA}</sync-guid><sync-parentguid>{3EBB864E-A734-4AF9-9B41-EF394542252A}</sync-parentguid><sync-checksum>-1723568360</sync-checksum><sync-rootid>0</sync-rootid><sync-itemtype>0</sync-itemtype><sync-timestamp>12 / Text5: 21/2004 9:45:33 AM</sync-timestamp><sync-itemid>820</sync-itemid><sync-prioritymapping>0:0-0/1:700-1000/2:300-699/3:1-299</sync-prioritymapping>
- 926: Text3: <sync-guid>{6B8F700B-E1BC-4364-920F-373CD574C1F2}</sync-guid><sync-parentguid>{3EBB864E-A734-4AF9-9B41-EF394542252A}</sync-parentguid><sync-checksum>-438112718</sync-checksum><sync-rootid>0</sync-rootid><sync-itemtype>0</sync-itemtype><sync-timestamp>12/2 / Text5: 1/2004 9:45:34 AM</sync-timestamp><sync-itemid>821</sync-itemid><sync-prioritymapping>0:0-0/1:700-1000/2:300-699/3:1-299</sync-prioritymapping>
- 927: Text3: <sync-guid>{670A96F3-E273-45BE-9DBD-64C51B25E60F}</sync-guid><sync-parentguid>{3EBB864E-A734-4AF9-9B41-EF394542252A}</sync-parentguid><sync-checksum>-1866402507</sync-checksum><sync-rootid>0</sync-rootid><sync-itemtype>0</sync-itemtype><sync-timestamp>12 / Text5: 21/2004 9:45:34 AM</sync-timestamp><sync-itemid>822</sync-itemid><sync-prioritymapping>0:0-0/1:700-1000/2:300-699/3:1-299</sync-prioritymapping>
- 928: Text3: <sync-guid>{565B8004-63F9-4A90-9BFC-7D840CE63260}</sync-guid><sync-parentguid>{3EBB864E-A734-4AF9-9B41-EF394542252A}</sync-parentguid><sync-checksum>-1584552903</sync-checksum><sync-rootid>0</sync-rootid><sync-itemtype>0</sync-itemtype><sync-timestamp>12 / Text5: 30/2004 1:10:21 PM</sync-timestamp><sync-itemid>1127</sync-itemid><sync-prioritymapping>0:0-0/1:700-1000/2:300-699/3:1-299</sync-prioritymapping>
- 929: Text3: <sync-guid>{1AB2C33F-4E56-41D6-858F-ABE975227B4E}</sync-guid><sync-parentguid>{3EBB864E-A734-4AF9-9B41-EF394542252A}</sync-parentguid><sync-checksum>-917838701</sync-checksum><sync-rootid>0</sync-rootid><sync-itemtype>0</sync-itemtype><sync-timestamp>12/3 / Text5: 0/2004 1:10:21 PM</sync-timestamp><sync-itemid>1194</sync-itemid><sync-prioritymapping>0:0-0/1:700-1000/2:300-699/3:1-299</sync-prioritymapping>
- 930: Text3: <sync-guid>{157265F8-9C4B-4635-98CB-623080486C69}</sync-guid><sync-parentguid>{55A6A8DD-D0E3-4E39-AE60-4750F7DD10C2}</sync-parentguid><sync-checksum>1497690880</sync-checksum><sync-rootid>0</sync-rootid><sync-itemtype>0</sync-itemtype><sync-timestamp>12/3 / Text5: 0/2004 1:13:43 PM</sync-timestamp><sync-itemid>823</sync-itemid><sync-prioritymapping>0:0-0/1:700-1000/2:300-699/3:1-299</sync-prioritymapping>
- 931: Text3: <sync-guid>{7C6016DC-AB77-4E57-BC3B-9F93FFD47C74}</sync-guid><sync-parentguid>{157265F8-9C4B-4635-98CB-623080486C69}</sync-parentguid><sync-checksum>-1335587812</sync-checksum><sync-rootid>0</sync-rootid><sync-itemtype>0</sync-itemtype><sync-timestamp>12 / Text5: 30/2004 1:13:43 PM</sync-timestamp><sync-itemid>824</sync-itemid><sync-prioritymapping>0:0-0/1:700-1000/2:300-699/3:1-299</sync-prioritymapping>
- 932: Text3: <sync-guid>{3835DE29-46B4-4960-9360-F57E1578658D}</sync-guid><sync-parentguid>{157265F8-9C4B-4635-98CB-623080486C69}</sync-parentguid><sync-checksum>1986998292</sync-checksum><sync-rootid>0</sync-rootid><sync-itemtype>0</sync-itemtype><sync-timestamp>12/2 / Text5: 1/2004 9:45:34 AM</sync-timestamp><sync-itemid>825</sync-itemid><sync-prioritymapping>0:0-0/1:700-1000/2:300-699/3:1-299</sync-prioritymapping>
- 933: Text3: <sync-guid>{DC5600CC-235B-44D3-92C1-99519EB50705}</sync-guid><sync-parentguid>{157265F8-9C4B-4635-98CB-623080486C69}</sync-parentguid><sync-checksum>1641515275</sync-checksum><sync-rootid>0</sync-rootid><sync-itemtype>0</sync-itemtype><sync-timestamp>12/2 / Text5: 1/2004 9:45:34 AM</sync-timestamp><sync-itemid>826</sync-itemid><sync-prioritymapping>0:0-0/1:700-1000/2:300-699/3:1-299</sync-prioritymapping>
- 934: Text3: <sync-guid>{69F635CC-5245-4991-BBD1-C512B1EA7F9D}</sync-guid><sync-parentguid>{157265F8-9C4B-4635-98CB-623080486C69}</sync-parentguid><sync-checksum>-540329620</sync-checksum><sync-rootid>0</sync-rootid><sync-itemtype>0</sync-itemtype><sync-timestamp>12/2 / Text5: 1/2004 9:45:34 AM</sync-timestamp><sync-itemid>827</sync-itemid><sync-prioritymapping>0:0-0/1:700-1000/2:300-699/3:1-299</sync-prioritymapping>
- 935: Text3: <sync-guid>{E185988C-09E2-40D1-9754-48EB7700ADE1}</sync-guid><sync-parentguid>{157265F8-9C4B-4635-98CB-623080486C69}</sync-parentguid><sync-checksum>-1553090490</sync-checksum><sync-rootid>0</sync-rootid><sync-itemtype>0</sync-itemtype><sync-timestamp>12 / Text5: 21/2004 9:45:34 AM</sync-timestamp><sync-itemid>828</sync-itemid><sync-prioritymapping>0:0-0/1:700-1000/2:300-699/3:1-299</sync-prioritymapping>
- 936: Text3: <sync-guid>{962D549C-965E-4373-BD8E-27737156BE32}</sync-guid><sync-parentguid>{157265F8-9C4B-4635-98CB-623080486C69}</sync-parentguid><sync-checksum>-699423935</sync-checksum><sync-rootid>0</sync-rootid><sync-itemtype>0</sync-itemtype><sync-timestamp>12/2 / Text5: 1/2004 9:45:34 AM</sync-timestamp><sync-itemid>829</sync-itemid><sync-prioritymapping>0:0-0/1:700-1000/2:300-699/3:1-299</sync-prioritymapping>
- 937: Text3: <sync-guid>{6414AB12-A57F-4CC8-917D-5FC708345433}</sync-guid><sync-parentguid>{157265F8-9C4B-4635-98CB-623080486C69}</sync-parentguid><sync-checksum>-419237299</sync-checksum><sync-rootid>0</sync-rootid><sync-itemtype>0</sync-itemtype><sync-timestamp>12/3 / Text5: 0/2004 1:10:21 PM</sync-timestamp><sync-itemid>1129</sync-itemid><sync-prioritymapping>0:0-0/1:700-1000/2:300-699/3:1-299</sync-prioritymapping>
- 938: Text3: <sync-guid>{F92E0B59-1D22-4C8F-802A-D5D84F1B5412}</sync-guid><sync-parentguid>{157265F8-9C4B-4635-98CB-623080486C69}</sync-parentguid><sync-checksum>-1882869017</sync-checksum><sync-rootid>0</sync-rootid><sync-itemtype>0</sync-itemtype><sync-timestamp>12 / Text5: 30/2004 1:10:22 PM</sync-timestamp><sync-itemid>1196</sync-itemid><sync-prioritymapping>0:0-0/1:700-1000/2:300-699/3:1-299</sync-prioritymapping>
- 939: Text3: <sync-guid>{8FEE8DA1-BA7E-4DFF-B2EB-67EC905FA2AB}</sync-guid><sync-parentguid>{9E55DC8E-FCA4-4D95-BBCF-9F2DDD4601DA}</sync-parentguid><sync-checksum>-1119364464</sync-checksum><sync-rootid>0</sync-rootid><sync-itemtype>0</sync-itemtype><sync-timestamp>12 / Text5: 30/2004 1:13:44 PM</sync-timestamp><sync-itemid>710</sync-itemid><sync-prioritymapping>0:0-0/1:700-1000/2:300-699/3:1-299</sync-prioritymapping>
- 940: Text3: <sync-guid>{91F978A1-F5F9-4C36-9C0B-3C1A51E59D1F}</sync-guid><sync-parentguid>{8FEE8DA1-BA7E-4DFF-B2EB-67EC905FA2AB}</sync-parentguid><sync-checksum>-939990690</sync-checksum><sync-rootid>0</sync-rootid><sync-itemtype>0</sync-itemtype><sync-timestamp>12/3 / Text5: 0/2004 1:13:44 PM</sync-timestamp><sync-itemid>856</sync-itemid><sync-prioritymapping>0:0-0/1:700-1000/2:300-699/3:1-299</sync-prioritymapping>
- 941: Text3: <sync-guid>{A53B57F5-E19C-4698-8A62-242185CB1015}</sync-guid><sync-parentguid>{8FEE8DA1-BA7E-4DFF-B2EB-67EC905FA2AB}</sync-parentguid><sync-checksum>-1242317504</sync-checksum><sync-rootid>0</sync-rootid><sync-itemtype>0</sync-itemtype><sync-timestamp>12 / Text5: 30/2004 1:13:44 PM</sync-timestamp><sync-itemid>939</sync-itemid><sync-prioritymapping>0:0-0/1:700-1000/2:300-699/3:1-299</sync-prioritymapping>
- 942: Text3: <sync-guid>{809EAE4A-8AEA-4752-B6E6-B77B0E54D16D}</sync-guid><sync-parentguid>{8FEE8DA1-BA7E-4DFF-B2EB-67EC905FA2AB}</sync-parentguid><sync-checksum>-984178668</sync-checksum><sync-rootid>0</sync-rootid><sync-itemtype>0</sync-itemtype><sync-timestamp>12/3 / Text5: 0/2004 1:13:44 PM</sync-timestamp><sync-itemid>814</sync-itemid><sync-prioritymapping>0:0-0/1:700-1000/2:300-699/3:1-299</sync-prioritymapping>
- 943: Text3: <sync-guid>{0FB57E91-EC91-4E93-8E95-6FF5A4DFF4B6}</sync-guid><sync-parentguid>{8FEE8DA1-BA7E-4DFF-B2EB-67EC905FA2AB}</sync-parentguid><sync-checksum>-446792689</sync-checksum><sync-rootid>0</sync-rootid><sync-itemtype>0</sync-itemtype><sync-timestamp>12/3 / Text5: 0/2004 1:13:44 PM</sync-timestamp><sync-itemid>813</sync-itemid><sync-prioritymapping>0:0-0/1:700-1000/2:300-699/3:1-299</sync-prioritymapping>
- 944: Text3: <sync-guid>{44DB1219-F0DB-4C6B-B69C-889C5352D60D}</sync-guid><sync-parentguid>{8FEE8DA1-BA7E-4DFF-B2EB-67EC905FA2AB}</sync-parentguid><sync-checksum>968956512</sync-checksum><sync-rootid>0</sync-rootid><sync-itemtype>0</sync-itemtype><sync-timestamp>12/30 / Text5: 2004 1:13:44 PM</sync-timestamp><sync-itemid>712</sync-itemid><sync-prioritymapping>0:0-0/1:700-1000/2:300-699/3:1-299</sync-prioritymapping>
